# 3GPP_Work Plan

Schedule from MS Project, 2000-01-01 to 2004-04-30, A marks actual dates.

## Calendars

- Standard: Mon-Fri 08:00-12:00, 13:00-17:00; Sat-Sun off.

## Resources

| Resource |
| --- |
| NP |
| N1 |
| N2 |
| N3 |
| N4 |
| N5 |
| TP |
| T1 |
| T2 |
| T3 |
| RP |
| R1 |
| R2 |
| R3 |
| R4 |
| SP |
| S1 |
| S2 |
| S3 |
| S4 |
| S5 |
| PCG |
| GP |
| No |
| CN4 |
| ? |
| WG G2 |
| G2 |
| G1 |
| G4 |
| G3 |
| All |
| Generic |
| MLST |
| G5 |
| S3, G2 |

## Schedule

| ID | WBS | Task | Duration | Start | Finish | Complete | Remaining | Baseline start | Baseline finish | Baseline duration | Total slack | Constraint | Resources | Work | Actual work | Text6 | Text9 | Text1 | Text4 | Text7 | Text8 | Text2 | Text5 |
| --- | --- | --- | --- | --- | --- | --- | --- | --- | --- | --- | --- | --- | --- | --- | --- | --- | --- | --- | --- | --- | --- | --- | --- |
| 1 | 1 | VERSION 2003 February 19th | 1d | 2000-01-03 | 2000-01-03 |  |  | 2000-01-03 | 2000-01-03 | 1d | 1034d |  |  |  |  | Rel | 2044 |  |  |  |  |  |  |
| 2 | 2 | "CTRL + a" to display all the 3GPP fields | 1d | 2000-01-03 | 2000-01-03 |  |  | 2000-01-03 | 2000-01-03 | 1d | 976d |  |  |  |  |  | 1462 |  |  |  |  |  |  |
| 3 | 3 | Content of Rel4 and Rel5 frozen. Rel6 and after not frozen. | 1d | 2000-01-03 | 2000-01-03 |  |  | 2000-01-03 | 2000-01-03 | 1d | 976d |  |  |  |  | Rel | 2058 |  |  |  |  |  |  |
| 6 | 6 | Evolutions of the transport in the UTRAN | 445d | 2000-07-17 A | 2002-03-29 A | 100% |  | 2000-07-17 | 2002-03-29 | 445d |  |  | RP | 3560h | 3560h | NA |  | ETRAN | Francois Courau | TSG | Joern |  |  |
| 7 | 7 | **Evolutions of the transport in the CN** | 261d | 2002-06-07 A | 2003-06-06 | 50% | 130.5d | 2001-03-12 | 2001-12-21 | 205d | 235d |  | N4 | 3136h | 2088h | NA |  | CNTRSP |  |  | Kimmo | BaAS |  |
| 8 | 7.1 | Preferred Framing Protocol for bearer independent CS architecture | 261d | 2002-06-07 A | 2003-06-06 | 50% | 130.5d |  |  |  | 167d | finish no earlier than 2003-06-06 | N4 | 2088h | 1044h | Rel6 |  | PFP | Phli Hodges, Ericsson | TSG |  |  | philip.hodges@ericsson.com.au |
| 9 | 8 | **Improvements of Radio Interface** | 975d? | 2000-06-19 A | 2004-03-12 | 32% | 663.65d? | 2000-06-19 | 2003-06-30 | 791d | 35d |  | RP | 66888h | 24643.1h | NA |  | RInImp |  | TSG | Tsukasa |  |  |
| 10 | 8.1 | Improvement of inter-frequency and inter-system measurement | 635d | 2001-01-01 A | 2003-06-06 | 5% | 603.25d | 2001-01-01 | 2002-12-03 | 502d | 200d | finish no earlier than 2003-06-06 | R1 | 5080h | 254h | Rel6 | 1470 | RInImp-IfIsM | Nokia (Antti Toskala) | TSG |  | BaAS |  |
| 11 | 8.2 | **Base station classification** | 603d | 2000-08-14 A | 2002-12-04 A | 100% |  |  |  |  |  |  | R4 | 9648h | 9648h | Rel6 |  | RInImp-BSClass |  | TSG |  |  |  |
| 12 | 8.2.1 | FDD Base station classification | 603d | 2000-08-14 A | 2002-12-04 A | 100% |  | 2000-08-14 | 2002-12-20 | 615d |  | finish no earlier than 2002-12-04 | R4 | 4824h | 4824h | Rel6 | 1476 | RInImp-BSClass-FDD | A. Toskala, Nokia | TSG |  | BaAs |  |
| 13 | 8.4 | Terminal Power Saving features | 791d | 2000-06-19 | 2003-06-30 |  |  | 2000-06-19 | 2003-06-30 | 791d | 184d | finish no earlier than 2003-06-30 | R2 | 6328h |  | Rel6 | 1507 | RInImp-TPS | M. Park, Samsung | TSG |  | BaAS |  |
| 14 | 8.5 | Multiple Input Multiple Output antennas (MIMO) | 656d | 2001-03-16 A | 2003-09-19 | 40% | 393.6d | 2001-03-16 | 2003-03-11 | 518d | 125d | finish no earlier than 2003-09-19 | R1 | 5248h | 2099.2h | Rel6 | 2468 | RInImp-MIMO | Howard Huang, Lucent | TSG |  |  |  |
| 15 | 8.6 | Improving Receiver Performance Requirements for the FDD UE | 401d | 2002-03-08 A | 2003-09-19 | 29% | 284.71d | 2002-03-08 | 2002-12-06 | 196d | 125d | finish no earlier than 2003-09-19 | R4 | 3208h | 930.32h | Rel6 |  | RInImp-UERecPerf | Shimon Moshavi, Intel | TSG |  |  |  |
| 16 | 6.6 | UMTS-850 | 331d? | 2002-12-06 | 2004-03-12 |  |  |  |  |  | 35d | finish no earlier than 2004-03-12 | R4 | 2648h |  |  |  | RInImp-UMTS850 | TBD | TSG |  |  |  |
| 17 | 8.7 | FS for the viable deployment of UTRA in additional and diverse spectrum arrangements | 386d | 2001-09-21 A | 2003-03-14 | 75% | 96.5d | 2001-09-21 | 2002-06-21 | 196d | 260d | finish no earlier than 2003-03-14 | R4 | 3088h | 2316h | Rel6 |  | RInImp-UMTSBands | Peter Ståhlfjäll, Ericsson | TSG | Cesar |  |  |
| 18 | 8.8 | FS on UE antenna efficiency test methods performance requirements (2) | 131d | 2002-03-08 A | 2002-09-06 A | 100% |  | 2002-03-08 | 2002-12-06 | 196d |  | finish no earlier than 2002-09-06 | R4 | 1048h | 1048h | Rel6 |  | RInImp-UEAnTM2 | Alf Ahlström, Allgon | TSG |  |  |  |
| 19 | 8.9 | FS on Fast Cell Selection (FCS) for HS-DSCH | 521d | 2001-03-16 A | 2003-03-14 | 20% | 416.8d | 2001-03-16 | 2002-12-03 | 448d | 260d | finish no earlier than 2003-03-14 | R1 | 4168h | 833.6h | Rel6 | 2471 | RInImp-FCS | Rizwan Hassan, Lucent | TSG |  |  |  |
| 20 | 8.10 | FS on Radio link performance enhancements | 810d | 2000-08-14 A | 2003-09-19 | 31% | 558.9d | 2000-08-14 | 2002-09-03 | 537d | 125d | finish no earlier than 2003-09-19 | R1 | 6480h | 2008.8h | Rel6 | 1506 | RInImp-Rlperf | Antti Toskala, Nokia Networks | TSG |  |  |  |
| 21 | 8.11 | FS on UTRA WideBand Distribution Systems | 525d | 2001-03-12 A | 2003-03-14 | 40% | 315d | 2001-03-12 | 2003-03-14 | 525d | 260d | finish no earlier than 2003-03-14 | R4 | 4200h | 1680h | Rel6 |  | RInImp-WDS | Andrea Casini, Tekmar Sistemi | TSG |  |  |  |
| 22 | 8.12 | FS on Improvement of inter-frequency and inter-system measurements for 1.28 Mcps TDD | 326d | 2001-12-14 A | 2003-03-14 | 45% | 179.3d | 2001-12-14 | 2002-06-04 | 123d | 260d | finish no earlier than 2003-03-14 | R1 | 2608h | 1173.6h | Rel6 |  | RInImp-IfIsMLCR | Li Xiao Qiang, SAMSUNG | TSG |  |  |  |
| 23 | 8.13 | FS for the analysis of OFDM for UTRAN enhancements | 265d | 2002-06-10 | 2003-06-13 |  |  |  |  |  | 195d | finish no earlier than 2003-06-13 | R1 | 2120h |  | Rel6 |  | RInImp-FSOFDM | Sarah Boumendil, Nortel | TSG |  |  |  |
| 24 | 8.14 | FS on Uplink Enhancements for Dedicated Transport Channels | 201d | 2002-09-06 | 2003-06-13 |  |  |  |  |  | 195d | finish no earlier than 2003-06-13 | R1 | 1608h |  | Rel6 |  | RInImp-FSUpDTrCh | Karri Ranta-aho, Nokia | TSG |  |  |  |
| 25 | 8.15 | FS on Analysis on Higher Chip Rates for UTRA TDD evolutions | 201d | 2002-09-06 A | 2003-06-13 | 10% | 180.9d |  |  |  | 195d | start no earlier than 2002-09-06 | R1 | 1608h | 160.8h | Rel6 |  | Rin-Imp-FSVHCRTDD | Tim Wilkinson, IPWireless | TSG |  |  |  |
| 26 | 9 | **RAN improvements** | 402d? | 2001-12-14 A | 2003-06-30 | 26% | 298.3d? | 2000-08-21 | 2003-06-30 | 746d | 219d |  | RP | 13424h | 3462.78h | NA |  | RANimp |  | TSG | Cesar |  |  |
| 27 | 9.1 | Beamforming Enhancements | 386d | 2001-12-14 A | 2003-06-06 | 50% | 193d | 2001-12-14 | 2002-12-03 | 253d | 200d | finish no earlier than 2003-06-06 | R1 | 3088h | 1544h | Rel6 |  | RANimp-BFE | Jussi Kähtävä, Nokia | TSG |  |  |  |
| 28 | 9.2 | RAB support enhancement | 206d | 2002-09-16 | 2003-06-30 |  |  | 2000-08-21 | 2003-06-30 | 746d | 184d | start no earlier than 2002-09-16 | R2 | 1648h |  | Rel6 | 624 | RANimp-RABSE | M. Israelsson, A. Krishnarajah, Ericsson | TSG |  | BaAS |  |
| 29 | 9.3 | Improvement of RRM across RNS and RNS/BSS | 218d | 2002-03-25 A | 2003-01-22 | 30% | 152.6d | 2002-03-25 | 2003-01-22 | 218d | 297d | finish no earlier than 2003-01-22 | R3 | 1744h | 523.2h | Rel6 |  | RANimp-RRM1 | Woonhee Hwang, Nokia |  |  |  |  |
| 30 | 9.4 | FS on the evolution of the UTRAN architecture | 200d | 2002-09-09 A | 2003-06-13 | 5% | 190d |  |  |  | 195d | start no earlier than 2002-09-09 | R3 | 1600h | 80h | Rel6 |  | RANimp-FSEvo | Woonhee Hwang, Nokia | TSG |  |  |  |
| 31 | 9.5 | FS for the Early Mobile Handling in UTRAN | 135d | 2002-09-09 A | 2003-03-14 | 45% | 74.25d |  |  |  | 260d | finish no earlier than 2003-03-14 | R2 | 1080h | 486h | Rel6 |  | RANimp-FSEarlyUE | Alan Law, Vodafone Ltd | TSG |  |  |  |
| 32 | 7.6 | FS of the improved access to UE measurement data for CRNC to support TDD RRM | 131d? | 2002-12-06 | 2003-06-06 |  |  |  |  |  | 235d | finish no earlier than 2003-06-06 | R3 | 1048h |  |  |  |  | Jim Miller, Interdigital |  |  |  |  |

Notes:
- 6: To be deleted at TSG#18 if no input.
- 7: To be deleted at TSG#18 if no input.
- 8: WID approved at CN#16 / 15/11/2003 CN4: target will be Cn#20
- 10: RP-020389
- 13: This is a building block without particular end date
- 14: Status report: RP-020429
- 18: The RInImp-UEAnTM FS was re-opened at TSG RAN#15 upon request from WG4
- 19: RP-020446
- 20: RP-020358
- 22: RP-020374
- 27: RP-020357
- 28: This is a building block without particular end date

| ID | WBS | Task | Duration | Start | Finish | Predecessors | Complete | Remaining | Baseline start | Baseline finish | Baseline duration | Total slack | Free slack | Constraint | Resources | Work | Actual work | Text1 | Text2 | Text4 | Text5 | Text6 | Text7 | Text8 | Text9 | Text3 |
| --- | --- | --- | --- | --- | --- | --- | --- | --- | --- | --- | --- | --- | --- | --- | --- | --- | --- | --- | --- | --- | --- | --- | --- | --- | --- | --- |
| 33 | 10 | **Emergency call enhancements** | 1062d | 2000-01-03 A | 2004-01-27 |  | 12% | 930.66d | 2000-01-03 | 2003-03-28 | 845d | 68d |  |  | N1 | 35312h | 4367.11h | EMC1 | CCaR | Mr Rouzbeh, Ericsson | EUSFARO@am1.ericsson.se | Rel6 | WG | Per | 1652 |  |
| 34 | 10.1 | **For IP & PS based calls** | 1062d | 2000-01-03 A | 2004-01-27 |  | 12% | 930.66d | 2000-01-03 | 2003-03-28 | 845d | 68d |  |  | N1 | 27496h | 3400.49h | EMC1-PS | CCaR | Mr Rouzbeh, Ericsson | EUSFARO@am1.ericsson.se | Rel6 |  |  | 1653 |  |
| 35 | 10.1.1 | Service Requirements for IP-based emergency calls | 205d | 2000-09-18 A | 2001-06-29 |  | 44% | 115d | 2000-09-18 | 2001-06-29 | 205d | 705d |  | start no earlier than 2000-09-18 | S1 | 1640h | 720h |  | CCaR |  |  |  |  |  | 1314 | 22.976 |
| 36 | 10.1.2 | SIP emergency calls and packet emergency calls signalling flowsl | 756d | 2000-10-17 A | 2003-09-09 |  | 21% | 597.24d | 2000-10-17 | 2003-03-28 | 639d | 133d |  | finish no earlier than 2003-09-09 | N1 | 6048h | 1270.08h |  | CCaR | Mr Rouzbeh, Ericsson | EUSFARO@am1.ericsson.se |  |  |  | 1315 | TS 24.228 |
| 37 | 10.1.3 | Stage 2 for emergency calls and packet emergency calls in general | 185d | 2002-08-12 A | 2003-04-25 |  | 35% | 120.25d | 2000-10-02 | 2002-12-06 | 570d | 33d | 0d | finish no earlier than 2003-04-25 | S2 | 1480h | 518h |  | CCaR |  |  |  |  |  | 1316 |  |
| 38 | 10.1.4 | Distinction of emergency call types to different emergency services | 197d | 2003-04-28 | 2004-01-27 | 37 |  |  | 2002-12-09 | 2003-03-28 | 80d | 33d |  | finish no earlier than 2003-09-09 | N1 | 1576h |  |  | CCaR |  |  |  |  |  | 1317 |  |
| 39 | 10.1.5 | Stage 3 for emergency calls and packet emergency calls in general | 802d | 2000-08-14 | 2003-09-09 |  |  |  | 2000-08-14 | 2003-03-28 | 685d | 133d |  | finish no earlier than 2003-09-09 | N1 | 6416h |  |  | CCaR | Rouzbeh Farhoumand, Ericsson | rouzbeh.farhoumand@ericsson.com |  |  |  | 1646 | TS 24.229 |
| 40 | 10.1.6 | Conformance Test Aspects - Emergency call enhancements | 195d | 2000-01-03 | 2000-09-29 |  |  |  | 2000-01-03 | 2000-09-29 | 195d | 900d |  |  | T1 | 1560h |  |  |  |  |  |  |  |  | 2224 |  |
| 41 | 10.1.7 | Testing Stage 3 for emergency calls and packet emergency calls in general | 195d | 2002-03-01 | 2002-11-28 |  |  |  | 2002-03-01 | 2002-11-28 | 195d | 336d |  | finish no earlier than 2002-11-28 | T1 | 1560h |  |  |  |  |  |  |  |  | 2225 |  |
| 42 | 11 | Terminal interfaces | 223d | 2001-05-14 A | 2002-03-20 A |  | 100% |  | 2001-05-14 | 2002-03-20 | 223d |  |  |  | T2 | 1784h | 1784h | TI | Ter |  |  | NA |  | Friedhelm | 1826 |  |
| 43 | 12 | **Location Services enhancements 2** | 845d? | 2000-08-28 A | 2003-11-21 |  | 11% | 749.95d? |  |  |  | 115d |  |  | S2 | 43408h | 5603.28h | LCS2 |  |  |  | Rel6 | TSG |  |  |  |
| 44 | 12.1 | Improvement on Le interface | 130d | 2002-06-21 | 2002-12-19 |  |  |  |  |  |  | 321d |  | finish no earlier than 2002-12-19 | S2 | 1040h |  |  |  |  |  |  | TSG |  |  |  |
| 45 | 12.2 | Enhanced support for user privacy and subscriber data handling | 405d | 2001-06-04 A | 2002-12-20 |  | 7% | 375d | 2001-06-04 | 2001-12-21 | 145d | 320d |  | start no earlier than 2001-06-04 | S2 | 3240h | 240h |  |  |  |  |  | TSG |  |  |  |
| 46 | 12.3 | Enhanced inter-GMLC interface | 145d | 2002-06-24 | 2003-01-10 |  |  |  | 2001-06-04 | 2001-12-21 | 145d | 305d |  | start no earlier than 2002-06-24 | S2 | 1160h |  |  |  |  |  |  | TSG |  |  |  |
| 47 | 12.4 | Support of the Presence Service Architecture | 90d | 2002-06-24 A | 2002-10-25 |  | 28% | 64.8d | 2002-01-14 | 2002-03-15 | 45d | 360d |  | finish no earlier than 2002-10-25 | S2 | 720h | 201.6h |  |  |  |  |  | TSG |  |  |  |
| 48 | 12.5 | New events for triggered location reports | 131d | 2002-06-21 | 2002-12-20 |  |  |  |  |  |  | 320d |  | finish no earlier than 2002-12-20 | S2 | 1048h |  |  |  |  |  |  | TSG |  |  |  |
| 49 | 12.6 | FS on applicability of GALILEO for LCS | 135d | 2002-09-16 | 2003-03-21 |  |  |  |  |  |  | 255d |  | finish no earlier than 2003-03-21 | S2 | 1080h |  |  |  |  |  |  |  |  |  |  |
| 50 | 12.7 | **UE positionning** | 741d | 2000-08-28 A | 2003-06-30 |  | 18% | 606.1d |  |  |  | 219d |  |  | RP | 13816h | 2515.32h | LCS2-UEpos |  |  |  | Rel6 | TSG |  |  |  |
| 51 | 12.7.1 | UE positioning enhancements - other methods | 741d | 2000-08-28 A | 2003-06-30 |  | 11% | 659.49d | 2000-08-28 | 2003-06-30 | 741d | 184d |  | finish no earlier than 2003-06-30 | R2 | 5928h | 652.08h | LCS2-UEpos-enh |  | M. Beckmann, Siemens |  |  | TSG |  | 2457 |  |
| 52 | 12.7.2 | FS on Enhancements to OTDOA Positioning using advanced blanking methods | 245d | 2002-07-01 A | 2003-06-06 |  | 40% | 147d |  |  |  | 200d |  | finish no earlier than 2003-06-06 | R2 | 1960h | 784h | LCS2-UEpos-FSBlank |  | David Bartlett, Cambridge Positioning Systems |  |  | TSG |  |  |  |
| 53 | 10.8 | **Uplink TDOA location determination for GSM/GPRS** | 266d | 2002-11-15 A | 2003-11-21 |  | 3% | 258.98d |  |  |  | 115d |  |  | GP | 5544h | 146.32h | UTDOA |  | Gross/Robinson, TruePosition, Inc. |  | Rel6 | TSG | Paolo |  |  |
| 54 | 10.8.1 | Addition of U-TDOA in the CS domain | 161d | 2002-11-15 A | 2003-06-27 |  | 7% | 149.73d |  |  |  | 185d |  | finish no earlier than 2003-06-27 | GP | 1288h | 90.16h | UTDOA-CS |  |  |  | Rel6 |  |  |  |  |
| 55 | 10.8.2 | Addition of U-TDOA in the PS domain | 266d | 2002-11-15 | 2003-11-21 |  |  |  |  |  |  | 80d |  | finish no earlier than 2003-11-21 | GP | 2128h |  | UTDOA-PS |  |  |  | Rel6 |  |  |  |  |
| 56 | 12.8 | **Open SMLC-SRNC Interface within the UTRAN to support UTRAN Rel4 positioning methods** | 565d? | 2001-01-15 A | 2003-03-14 |  | 15% | 479.51d? | 2001-01-15 | 2001-10-12 | 195d | 295d |  |  | R2 | 10600h | 1919.6h | LCS-Rel4Pos |  | Meik Kottkamp, Siemens |  | Rel6 | TSG |  | 2475 |  |
| 57 | 10.9.1 | RAN aspects | 565d? | 2001-01-15 | 2003-03-14 |  |  |  |  |  |  | 295d |  | start no earlier than 2001-01-15 | R2 | 4520h |  | LCS-Rel4Pos |  | Meik Kottkamp, Siemens |  |  | TSG |  |  |  |
| 58 | 12.8.1 | Stage 2 | 195d | 2001-01-15 A | 2001-10-12 |  | 59% | 80d | 2001-01-15 | 2001-10-12 | 195d | 630d |  | start no earlier than 2001-01-15 | S2 | 1560h | 920h |  |  | Kirk Burroughs, Qualcomm |  |  | WG |  | 2127 |  |

Notes:
- 36: No new spec will be presented, will be covered in CN1 spec24.228.
- 37: covered by TS 23.228
- 39: Potentially sub contracted to IETF / covered by TS 24.229
- 41: This task required more supporting companies
- 51: This is a building block without particular end date
- 53: Ongoing

| ID | WBS | Task | Duration | Start | Finish | Complete | Remaining | Baseline start | Baseline finish | Baseline duration | Total slack | Constraint | Resources | Work | Actual work | Text1 | Text2 | Text6 | Text8 | Text9 | Text4 | Text5 | Text7 | Text3 |
| --- | --- | --- | --- | --- | --- | --- | --- | --- | --- | --- | --- | --- | --- | --- | --- | --- | --- | --- | --- | --- | --- | --- | --- | --- |
| 59 | 13 | **(U)SIM toolkit enhancements** | 391d | 2002-03-20 A | 2003-09-17 | 25% | 292.05d | 2000-06-05 | 2003-09-26 | 865d | 162d |  | T3 | 10040h | 2540.78h | USAT1 | Ter | NA | Claus | 1800 |  |  |  |  |
| 60 | 13.1 | **UICC API** | 391d | 2002-03-20 A | 2003-09-17 | 25% | 292.05d | 2000-09-25 | 2002-09-27 | 525d | 162d |  | T3 | 6912h | 1749.19h | USAT1-API | Ter | NA |  | 1802 |  |  |  |  |
| 61 | 13.1.1 | Java API Test specification | 133d | 2002-03-20 A | 2002-09-20 | 90% | 13.3d | 2002-03-20 | 2002-09-20 | 133d | 385d | finish no earlier than 2002-09-20 | T3 | 1064h | 957.6h |  |  |  |  |  | Mario Pérez (Microelectrónica Española) |  |  |  |
| 62 | 13.1.2 | Java API Test specification (TS 43.019 Rel-5) | 340d | 2002-05-30 | 2003-09-17 |  |  |  |  |  | 127d | finish no earlier than 2003-09-17 | T3 | 2720h |  |  |  | Rel5 |  |  | Mario Pérez (Microelectrónica Española) |  |  |  |
| 63 | 14 | **Security enhancements** | 935d | 2000-02-21 A | 2003-09-19 | 32% | 637.44d | 2000-01-03 | 2002-12-06 | 765d | 160d |  | S3 | 31664h | 10907.8h | SEC1 |  | NA | Maurice |  | Peter Howard, Vodafone | Peter.Howard@vodafone.com | TSG |  |
| 64 | 14.1 | **Enhanced HE control of security (including positive authentication reporting)** | 573d | 2001-01-03 A | 2003-03-14 | 24% | 434.2d | 2001-01-03 | 2002-06-14 | 378d | 295d |  | S3 | 11296h | 3606.41h |  |  | Rel6 |  | 2026 | Peter Howard, Vodafone | Peter.Howard@vodafone.com |  |  |
| 65 | 14.1.1 | Stage 2 | 378d | 2001-01-03 | 2002-06-14 |  |  | 2001-01-03 | 2002-06-14 | 378d | 455d | finish no earlier than 2002-06-14 | S3 | 3024h |  |  |  |  |  | 2027 |  |  |  |  |
| 66 | 14.1.2 | FS on Network impacts | 71d | 2002-12-06 | 2003-03-14 |  |  | 2002-04-08 | 2002-06-07 | 45d | 260d | finish no earlier than 2003-03-14 | N4 | 568h |  |  |  |  |  | 2028 |  |  |  |  |
| 67 | 14.1.3 | **Network domain security** | 195d | 2002-06-17 A | 2003-03-14 | 80% | 39d |  |  |  | 295d |  | S3 | 3120h | 2496h | SEC1-NDS | Sec | Rel6 |  |  | Geir M. Køien, Telenor | Geir-myrdahl.koien@telenor.com | TSG |  |
| 68 | 14.1.3.1 | IP network layer security (NDS/IP) | 195d | 2002-06-17 A | 2003-03-14 | 80% | 39d |  |  |  | 260d | finish no earlier than 2003-03-14 | S3 | 1560h | 1248h | SEC1-NDS-IP |  | Rel6 |  |  |  |  | WG | TS 33.210 |
| 69 | 14.2 | **Rel-6 MAP application layer security** | 935d | 2000-02-21 A | 2003-09-19 | 38% | 578d | 2000-02-21 | 2002-12-06 | 730d | 160d |  | S3 | 12888h | 4920.87h | SEC1-MAPAL | Sec | Rel6 |  |  |  |  | TSG |  |
| 70 | 14.2.1 | Main aspects | 510d | 2000-02-21 A | 2002-06-07 | 50% | 255d | 2000-02-21 | 2002-06-07 | 510d | 460d | start no earlier than 2000-02-21 | S3 | 4080h | 2040h | SEC1-MAPAL | Sec |  |  | 1584 |  |  | WG |  |
| 71 | 14.2.2 | Security signalling flows for the Ze interface | 260d | 2002-09-23 A | 2003-09-19 | 15% | 221d | 2000-02-22 | 2002-12-06 | 729d | 125d | finish no earlier than 2002-12-06 | N4 | 2080h | 312h | SEC1-MAPAL | Sec |  |  | 2025 |  |  | TSG |  |
| 72 | 16 | **IMS Phase 2** | 864d? | 2000-08-28 A | 2003-12-18 | 35% | 557.88d? | 2000-08-28 | 2003-03-28 | 675d | 96d |  | S1 | 85952h | 33714h | IMS2 |  | Rel6 |  |  |  |  |  |  |
| 73 | 16.1 | Stage 2 of IMS Phase 2 | 205d | 2002-09-02 A | 2003-06-13 | 22% | 159.9d |  |  |  | 195d | finish no earlier than 2003-06-13 | S2 | 1640h | 360.8h |  |  | Rel6 |  |  |  |  |  |  |
| 74 | 16.2 | IMS Stage-3 Enhancements | 261d | 2002-09-20 A | 2003-09-19 | 2% | 255.78d |  |  |  | 125d | finish no earlier than 2003-09-19 | N1 | 2088h | 41.76h | IMS-CCR-E |  | Rel6 |  |  | Keith Drage, Lucent | drage@lucent.com |  |  |
| 75 | 13.3 | Identity portability in IMS | 261d? | 2002-09-20 | 2003-09-19 |  |  |  |  |  | 125d | finish no earlier than 2003-09-19 | N1 | 2088h |  |  |  |  |  |  |  |  |  |  |
| 76 | 13.4 | IMS Local services | 261d? | 2002-09-20 | 2003-09-19 |  |  |  |  |  | 125d | finish no earlier than 2003-09-19 | N1 | 2088h |  |  |  |  |  |  |  |  |  |  |
| 77 | 13.5 | IMS Group management (e.g. chat) | 261d? | 2002-09-20 | 2003-09-19 |  |  |  |  |  | 125d | finish no earlier than 2003-09-19 | N1 | 2088h |  |  |  |  |  |  |  |  |  |  |
| 78 | 13.6 | IMS Conferencing | 261d? | 2002-09-20 | 2003-09-19 |  |  |  |  |  | 125d | finish no earlier than 2003-09-19 | N1 | 2088h |  |  |  |  |  |  |  |  |  |  |
| 79 | 13.7 | PSS alignment to IMS | 261d? | 2002-09-20 | 2003-09-19 |  |  |  |  |  | 125d | finish no earlier than 2003-09-19 | N1 | 2088h |  |  |  |  |  |  |  |  |  |  |
| 80 | 13.8 | IMS Messaging | 261d? | 2002-09-20 | 2003-09-19 |  |  |  |  |  | 125d | finish no earlier than 2003-09-19 | N1 | 2088h |  |  |  |  |  |  |  |  |  |  |
| 81 | 13.9 | Additional SIP Capabilities support not covered by Rel-5 | 261d? | 2002-09-20 | 2003-09-19 |  |  |  |  |  | 125d | finish no earlier than 2003-09-19 | N1 | 2088h |  |  |  |  |  |  |  |  |  |  |
| 82 | 13.10 | Review additional SIP Capabilities against IMS | 261d? | 2002-09-20 | 2003-09-19 |  |  |  |  |  | 125d | finish no earlier than 2003-09-19 | N1 | 2088h |  |  |  |  |  |  |  |  |  |  |

Notes:
- 60: 8/3/2001: test spec is based on R99 core spec, so deleted from Workplan
- 63: Added BB UE authentication and rapporteur added.
- 64: Added by P-000575 without any dates. 18/10/00: Change of WI title, added hyperlink rapporteur new end date 03/01. New end date and correct Release to be decided S3#18
- 65: New end date and correct Release to be decided S3#18
- 66: 15/11/2002 CN4: Waiting for input from SA3!
- 67: WID approved for Rel-6 at SA#17
- 68: Should be complete after SA3#27
- 69: TO DELETE: REPLACED BY NDS-MAP and NDS-IP. TO BE DELETED, but replacement NDS-MAP was missing
- 70: ??
- 71: 17 May Requirements under analysis in CN4. End date not yet determined. / 02/08/2002 CN4: CN4 is waiting WID in CN4#17. Revised version of N4-020624 / 15/11/2003 CN4: The first draft will be present in C4#18 target CN#21
- 72: Not yet available: verbally approved at SA15, actual WID to be provided at SA16 by Lucent

| ID | WBS | Task | Duration | Start | Finish | Complete | Remaining | Baseline start | Baseline finish | Baseline duration | Total slack | Constraint | Resources | Work | Actual work | Text1 | Text2 | Text3 | Text4 | Text5 | Text6 | Text7 | Text9 |
| --- | --- | --- | --- | --- | --- | --- | --- | --- | --- | --- | --- | --- | --- | --- | --- | --- | --- | --- | --- | --- | --- | --- | --- |
| 83 | 16.5 | **Interworking between IMS and IP networks** | 675d | 2000-08-28 A | 2003-03-28 | 35% | 442.12d | 2000-08-28 | 2003-03-28 | 675d | 285d |  | N3 | 16200h | 5846h | IMS-CCR-IWIP | BaAS | 23.821, 29.061, 29.162 | Nigel Holland, BT | nigel.holland@bt.com | Rel6 | TSG | 2048 |
| 84 | 16.5.1 | Interworking for 3GPP_SIP and IETF_SIP | 675d | 2000-08-28 A | 2003-03-28 | 59% | 276.75d | 2000-08-28 | 2003-03-28 | 675d | 250d | finish no earlier than 2003-03-28 | N3 | 5400h | 3186h |  |  | New TR 2x.abc | Thomas Belling, Siemens |  |  |  |  |
| 85 | 16.5.2 | Interworking for IPv6 to IPv4 | 675d | 2000-08-28 A | 2003-03-28 | 10% | 607.5d | 2000-08-28 | 2003-03-28 | 675d | 250d | finish no earlier than 2003-03-28 | N3 | 5400h | 540h |  |  | 29.163 |  |  |  |  |  |
| 86 | 16.6 | **Interworking between IMS and CS networks** | 595d | 2000-08-28 A | 2002-12-06 | 60% | 238d | 2000-08-28 | 2002-12-06 | 595d | 365d |  | N3 | 11456h | 6873.6h | IMS-CCR-IWCS | CCaR | 29.163, 29.061, 24.228, and new CN4 specification | David Sanders, Vodafone | dave.sanders@vf.vodafone.co.uk | Rel6 | TSG | 1305 |
| 87 | 16.6.1 | ITU-T Q.1912.SIP (SIP to BICC / ISUP interworking) | 595d | 2000-08-28 A | 2002-12-06 | 60% | 238d | 2000-08-28 | 2002-12-06 | 595d | 330d | finish no earlier than 2002-12-06 | N3 | 4760h | 2856h |  |  |  |  |  |  |  |  |
| 88 | 16.6.2 | ITU-T dependency on Q.2150.3 (SCTP) | 595d | 2000-08-28 A | 2002-12-06 | 60% | 238d | 2000-08-28 | 2002-12-06 | 595d | 330d | finish no earlier than 2002-12-06 | N3 | 4760h | 2856h |  |  |  |  |  |  |  |  |
| 89 | 16.7 | **IMS Local services** | 325d | 2001-01-01 A | 2002-03-29 A | 100% |  | 2001-01-01 | 2002-03-29 | 325d |  |  | S2 | 5200h | 5200h |  |  | 23.228 |  |  | Rel6 |  |  |
| 90 | 16.7.1 | Stage 2 | 325d | 2001-01-01 A | 2002-03-29 A | 100% |  | 2001-01-01 | 2002-03-29 | 325d |  | start no earlier than 2001-01-01 | S2 | 2600h | 2600h |  |  |  |  |  |  |  |  |
| 91 | 16.8 | **Mm interface (CSCF to external IP multimedia network)** | 389d | 2001-03-14 A | 2002-09-09 | 71% | 112.81d | 2001-03-14 | 2003-03-21 | 528d | 429d |  | N3 | 6224h | 2209.52h |  |  |  |  |  | Rel6 |  |  |
| 92 | 16.8.1 | CN1 part | 389d | 2001-03-14 A | 2002-09-09 | 71% | 112.81d | 2001-03-14 | 2002-06-07 | 323d | 394d | finish no earlier than 2002-09-09 | N1 | 3112h | 2209.52h |  |  |  |  |  |  |  |  |
| 93 | 16.9 | **Mg interface (BGCF to MGCF - interworking with CS)** | 371d | 2001-04-09 A | 2002-09-09 A | 100% |  | 2001-04-09 | 2002-12-20 | 445d |  |  | N3 | 5936h | 5936h |  |  |  |  |  | Rel6 |  |  |
| 94 | 16.9.1 | Mg interface (BGCF to MGCF - interworking with CS) | 371d | 2001-04-09 A | 2002-09-09 A | 100% |  | 2001-04-09 | 2002-06-07 | 305d |  | finish no earlier than 2002-06-07 | N1 | 2968h | 2968h |  |  |  |  |  | Rel6 |  |  |
| 95 | 16.10 | Mn interface (IM-MGW to MGCF) enhancements | 200d | 2002-09-02 A | 2003-06-06 | 30% | 140d | 2002-06-03 | 2002-12-27 | 150d | 200d | finish no earlier than 2003-06-06 | N4 | 1600h | 480h | IMS-CCR-Mn |  |  | Peter Schmitt, Siemens |  | Rel6 |  |  |
| 96 | 13.17 | Mp (MRFC - MRFP) interface protocol definitions | 175d? | 2002-10-07 A | 2003-06-06 | 17% | 145.25d? |  |  |  | 200d | finish no earlier than 2003-06-06 | N4 | 1400h | 238h | IMS-CCR-Mp |  |  | David Sanders, Vodafone |  | Rel6 |  |  |
| 97 | 16.11 | **IMS Messaging** | 267d? | 2002-03-14 A | 2003-03-21 | 42% | 155.36d? | 2002-03-14 | 2003-03-17 | 263d | 290d |  | S1 | 9392h | 3131.41h | IMSM |  |  | Juha Kalliokulju (Nokia) | juha.kalliokulju@nokia.com | Rel6 | TSG |  |
| 98 | 16.11.1 | TR on support of messaging in the IMS | 193d | 2002-03-14 A | 2002-12-09 | 90% | 19.3d | 2002-03-14 | 2002-12-09 | 193d | 329d | finish no earlier than 2002-12-09 | S1 | 1544h | 1389.6h | IMSM-TR |  |  | Juha Kalliokulju (Nokia) | juha.kalliokulju@nokia.com |  | TSG |  |
| 99 | 13.18.2 | Stage 1 22.340 | 23d? | 2002-11-11 A | 2002-12-11 | 90% | 2.3d? |  |  |  | 327d | finish no earlier than 2002-12-11 | S1 | 184h | 165.6h | IMSM-TS |  | 22.340 | Juha Kalliokulju (Nokia) | juha.kalliokulju@nokia.com |  | TSG |  |
| 100 | 16.11.2 | **CRs to existing 22-series specifications** | 263d? | 2002-03-14 A | 2003-03-17 | 4% | 252.48d? | 2002-03-14 | 2003-03-17 | 263d | 294d |  | S1 | 4208h | 168.31h | IMSM-CR |  |  | Juha Kalliokulju (Nokia) | juha.kalliokulju@nokia.com |  | TSG |  |
| 101 | 13.18.3.1 | CRs to 22.140 & 22.228 | 263d? | 2002-03-14 A | 2003-03-17 | 4% | 252.48d? |  |  |  | 259d | finish no earlier than 2003-03-17 | S1 | 2104h | 84.16h | IMSM-CR |  | 22.140,22.228 | Juha Kalliokulju (Nokia) | juha.kalliokulju@nokia.com |  | TSG |  |
| 102 | 16.11.3 | Stage 2 | 165d | 2002-08-05 A | 2003-03-21 | 39% | 100.65d |  |  |  | 255d | finish no earlier than 2003-03-21 | S2 | 1320h | 514.8h |  |  |  |  |  |  |  |  |
| 103 | 16.12 | **IMS Group Management** | 193d | 2002-03-14 A | 2002-12-09 | 75% | 48.25d | 2002-03-14 | 2002-12-09 | 193d | 364d |  | S1 | 3088h | 2316h | IMSGM |  |  | Juha Kalliokulju (Nokia) | juha.kalliokulju@nokia.com | Rel6 | TSG |  |
| 104 | 16.12.1 | TS on IMS group management | 193d | 2002-03-14 A | 2002-12-09 | 75% | 48.25d | 2002-03-14 | 2002-12-09 | 193d | 329d | finish no earlier than 2002-12-09 | S1 | 1544h | 1158h |  |  |  | Juha Kalliokulju (Nokia) | juha.kalliokulju@nokia.com |  | TSG |  |
| 105 | 13.20 | Study of subscriber and operators relationship in IMS and related ISIM requirements for Rel 6” | 20d? | 2002-11-15 A | 2002-12-12 | 75% | 5d? |  |  |  | 326d | finish no earlier than 2002-12-12 | S1 | 160h | 120h |  |  |  | Juha Kalliokulju (Nokia) | juha.kalliokulju@nokia.com | Rel6 |  |  |
| 106 | 13.21 | Lawful Interception in the 3GPP Rel-6 architecture | 269d? | 2002-12-09 | 2003-12-18 |  |  |  |  |  | 61d | finish no earlier than 2003-12-18 | S3 | 2152h |  |  |  |  | Berthold Wilhelm |  |  |  |  |
| 107 | 16.4 | Radio optimisation impacts on PS domain architecture | 360d | 2001-12-10 A | 2003-04-25 | 47% | 190.8d | 2001-12-10 | 2002-06-14 | 135d | 265d | finish no earlier than 2003-04-25 | S2 | 2880h | 1353.6h |  |  |  |  |  | Rel6 | TSG |  |

Notes:
- 83: [DAB 14.02.02] - end date pushed back to March 2003
- 84: [DAB - 14.02.02] - Need for new TR underinvestigation by CN3
- 85: [DAB - 14.02.02] - Requirements still not clear from SA2
- 87: [DAB - 17.05.02] - estimated ITU delivery date pushed to Dec. 2002
- 88: [DAB - 17.05.02] - estimated ITU delivery date pushed to Dec. 2002
- 95: 17th May 2002, CN4; Will be handled in Rel-6 / 02/08/2002 CN4: WID approved at CN4#15 (N4-020997) / 01/09/2002 KK: WID approved at CN#17 (NP-020494) / 15/11/2002CN4: Target will be CN#20 (NP-020600)
- 96: 27/11/2002 KK: WID approved at CN#18 (NP-020601) / 27/11/2002CN4: Target will be CN#20

| ID | WBS | Task | Duration | Start | Finish | Complete | Remaining | Baseline start | Baseline finish | Baseline duration | Total slack | Constraint | Resources | Work | Actual work | Text1 | Text4 | Text5 | Text6 | Text2 | Text7 | Text8 | Text9 | Text3 |
| --- | --- | --- | --- | --- | --- | --- | --- | --- | --- | --- | --- | --- | --- | --- | --- | --- | --- | --- | --- | --- | --- | --- | --- | --- |
| 108 | 16.3 | **Interoperability and Commonality between IMS using different "IP-connectivity Networks"** | 257d | 2002-09-16 A | 2003-09-09 | 10% | 231.12d |  |  |  | 168d |  | N1 | 4864h | 489.72h | IMSCOOP | Keith Drage, Lucent | drage@lucent.com | Rel6 |  |  |  |  |  |
| 109 | 16.3.1 | Stage 2 | 114d | 2002-09-16 A | 2003-02-20 | 31% | 78.66d |  |  |  | 276d | finish no earlier than 2003-02-20 | S2 | 912h | 282.72h |  |  |  |  |  |  |  |  |  |
| 110 | 16.3.2 | Stage 3 | 237d | 2002-10-14 | 2003-09-09 |  |  |  |  |  | 133d | finish no earlier than 2003-09-09 | N1 | 1896h |  |  |  |  |  |  |  |  |  |  |
| 111 | 17 | **Support of Push Services** | 623d | 2001-01-03 A | 2003-05-23 | 44% | 350.01d | 2001-01-03 | 2002-06-14 | 378d | 245d |  | S1 | 9614.56h | 2439.84h | PUSH | Yoshinori Kitada, NTT Comware |  | Rel6 | CCaR | TSG | Alain | 1365 |  |
| 112 | 17.1 | Stage 1 | 378d | 2001-01-03 A | 2002-06-14 | 31% | 260.82d | 2001-01-03 | 2002-06-14 | 378d | 455d | finish no earlier than 2002-06-14 | S1 | 3024h | 937.44h |  |  |  |  |  |  |  |  |  |
| 113 | 17.2 | TR on feasibility study | 178d | 2001-01-03 A | 2001-09-07 A | 100% |  | 2001-01-03 | 2001-09-07 | 178d |  | finish no earlier than 2001-09-07 | S2 | 1424h | 1424h |  |  |  |  |  |  |  |  |  |
| 114 | 17.3 | Stage 2 | 140d | 2002-11-11 A | 2003-05-23 | 7% | 130.2d |  |  |  | 210d | finish no earlier than 2003-05-23 | S2 | 1120h | 78.4h |  |  |  |  |  |  |  |  |  |
| 115 | 18 | **Multimedia Messaging (MMS) enhancements** | 217d? | 2002-08-15 A | 2003-06-13 | 11% | 193.64d? |  |  |  | 230d |  | T2 | 9360h | 1481.71h | MMS6 | Josef Laumen, Siemens | Josef.Laumen@SAL.SIEMENS.DE | Rel6 | Mes | TSG |  |  |  |
| 116 | 18.1 | **Definition of service requirements** | 151d? | 2002-11-15 A | 2003-06-13 | 50% | 75.5d? |  |  |  | 230d |  | S1 | 2416h | 1208h |  | Josef Laumen, Siemens | Josef.Laumen@SAL.SIEMENS.DE |  |  |  |  |  | 22.140 |
| 117 | 17.1.1 | Definition of service requirements charging | 151d? | 2002-11-15 A | 2003-06-13 | 50% | 75.5d? |  |  |  | 195d | finish no earlier than 2003-06-13 | S1 | 1208h | 604h |  | Josef Laumen, Siemens | Josef.Laumen@SAL.SIEMENS.DE |  |  |  |  |  | 22.140 |
| 118 | 18.2 | Technical realization | 217d | 2002-08-15 A | 2003-06-13 | 5% | 206.15d |  |  |  | 195d | finish no earlier than 2003-06-13 | T2 | 1736h | 86.8h |  | Josef Laumen, Siemens | Josef.Laumen@SAL.SIEMENS.DE |  |  |  |  |  | 23.140 |
| 119 | 18.3 | OMA dependencies | 217d | 2002-08-15 | 2003-06-13 |  |  |  |  |  | 195d | finish no earlier than 2003-06-13 | T2 | 1736h |  |  |  |  |  |  |  |  |  |  |
| 120 | 18.4 | MMS formats and codecs | 217d | 2002-08-15 | 2003-06-13 |  |  |  |  |  | 195d | finish no earlier than 2003-06-13 | S4 | 1736h |  |  |  |  |  |  |  |  |  | 26.140 |
| 121 | 19 | **Rel-6 MExE enhancements** | 331d | 2002-03-08 A | 2003-06-13 | 95% | 16.68d | 2002-03-08 | 2003-07-07 | 347d | 230d |  | T2 | 7904h | 7505.79h | MEXE6 |  |  | Rel6 | Ter | TSG |  |  |  |
| 122 | 19.1 | MExE Rel-6 Improvements and Investigations | 331d | 2002-03-08 A | 2003-06-13 | 90% | 33.1d | 2002-03-08 | 2003-07-07 | 347d | 195d | finish no earlier than 2003-06-13 | T2 | 2648h | 2383.2h | MEXE6-ENHANC | Lars Brenk (TTPCom) | lsb_ttpcom@HOTMAIL.COM |  | Ter | TSG |  |  | 22.057, 23.057 |
| 123 | 19.2 | MExE Run-Time Independent Framework Feasibility Study | 326d | 2002-03-08 A | 2003-06-06 A | 100% |  | 2002-03-08 | 2003-06-06 | 326d |  | finish no earlier than 2003-06-06 | T2 | 2608h | 2608h | MEXE6-RTIF | Aaron Cohen (Intel) | Aaron.Cohen@intel.com |  | Ter | TSG |  |  | 22.857 |
| 124 | 21 | Subscription Management | 715d | 2000-12-29 A | 2003-09-25 | 30% | 500.5d | 2000-12-29 | 2002-12-20 | 516d | 121d | finish no earlier than 2003-09-25 | S5 | 5720h | 1716h | SM | Michael Eder (Nokia) | michael.eder@nokia.com | Rel6 |  | TSG | Adrian |  | 32.140, 32.141 |
| 125 | 22 | **Support of Presence Capability** | 578d | 2001-03-19 A | 2003-06-04 | 55% | 262.81d | 2001-03-19 | 2002-12-12 | 454d | 237d |  | S1 | 11792h | 6430.32h | PRESNC | Mark Cataldo, Motorola |  | Rel6 |  | TSG | Michael | 11004 |  |
| 126 | 22.1 | Stage 1 | 88d | 2001-03-19 A | 2001-07-18 | 95% | 4.4d | 2001-03-19 | 2001-07-18 | 88d | 692d | finish no earlier than 2001-07-18 | S1 | 704h | 668.8h |  |  |  |  |  |  |  | 11005 |  |
| 127 | 22.2 | Stage 2 | 268d | 2001-09-12 A | 2002-09-20 A | 100% |  | 2001-09-12 | 2002-09-20 | 268d |  | finish no earlier than 2002-09-20 | S2 | 2144h | 2144h |  |  |  |  |  | TSG |  |  |  |
| 128 | 22.3 | Stage 3 | 303d | 2002-04-08 A | 2003-06-04 | 40% | 181.8d | 2002-04-08 | 2002-09-20 | 120d | 202d | finish no earlier than 2003-06-04 | N1 | 2424h | 969.6h |  | Keith Drage, Lucent | drage@lucent.com |  |  |  |  |  |  |
| 129 | 22.4 | Security issues | 79d | 2002-08-26 A | 2002-12-12 | 20% | 63.2d | 2002-08-26 | 2002-12-12 | 79d | 326d | finish no earlier than 2002-12-12 | S3 | 632h | 126.4h |  |  |  |  |  |  |  |  |  |
| 130 | 22.5 | USIM issues | 79d | 2002-03-04 | 2002-06-20 |  |  | 2002-03-04 | 2002-06-20 | 79d | 451d | start no earlier than 2002-03-04 | T3 | 632h |  |  |  |  |  |  |  |  |  |  |
| 131 | 22.6 | UE issues | 79d | 2002-03-04 | 2002-06-20 |  |  | 2002-03-04 | 2002-06-20 | 79d | 451d | start no earlier than 2002-03-04 | T2 | 632h |  |  |  |  |  |  |  |  |  |  |
| 132 | 23 | Presence Service Enhancements | 263d | 2002-03-14 | 2003-03-17 |  |  | 2002-03-14 | 2003-03-17 | 263d | 259d | finish no earlier than 2003-03-17 | S1 | 2104h |  | PRES1 | Mark Cataldo (Openwave Systems) | mark.cataldo@openwave.com | Rel6 |  | TSG |  |  | 22.141 |

Notes:
- 111: AS: Changed from FS to actual support of Push
- 113: Stage 2 on hold, waiting for requirements.
- 129: LSs handled in SA3. WID approved SA#17 Contribution at S3#25 & following e-mail discussion.
- 132: SA1 to clarify why Presence and Presence enhancements are both be in same release

| ID | WBS | Task | Duration | Start | Finish | Complete | Remaining | Baseline start | Baseline finish | Baseline duration | Total slack | Constraint | Resources | Work | Actual work | Text6 | Text8 | Text1 | Text4 | Text5 | Text7 |
| --- | --- | --- | --- | --- | --- | --- | --- | --- | --- | --- | --- | --- | --- | --- | --- | --- | --- | --- | --- | --- | --- |
| 133 | 24 | **Emergency calls without UICC/SIM in netw. with IMS** | 292d | 2002-07-29 A | 2003-09-09 | 6% | 275.53d | 2002-03-18 | 2003-03-14 | 260d | 168d |  | S2 | 5096h | 287.45h | Rel6 | Alain |  |  |  |  |
| 134 | 24.1 | Stage 2 | 145d | 2002-10-07 A | 2003-04-25 | 17% | 120.35d | 2002-03-18 | 2002-06-28 | 75d | 230d | finish no earlier than 2003-04-25 | S2 | 1160h | 197.2h |  |  |  |  |  |  |
| 135 | 24.2 | Stage 3 work for CN1 | 292d | 2002-07-29 | 2003-09-09 |  |  | 2002-07-29 | 2003-03-14 | 165d | 133d | finish no earlier than 2003-09-09 | N1 | 2336h |  |  |  | EMC-NOSIM |  |  |  |
| 136 | 25 | **Enhanced A/Gb feasibility study** | 51d? | 2002-08-30 A | 2002-11-08 | 75% | 12.75d? | 2002-04-19 | 2002-06-28 | 51d | 385d |  | GP | 4080h | 3162h | TBD |  | AGbEnFS | J-L Carrizo, Vodafone | jose-luis.carrizo@vodafone.co.uk | TSG |
| 137 | 25.1 | **Feasibility study on A/Gb enhancements** | 51d? | 2002-08-30 A | 2002-11-08 | 75% | 12.75d? | 2002-04-19 | 2002-06-28 | 51d | 385d |  | G2 | 3672h | 2856h |  |  | AGbEnFS-FS |  |  | TSG |
| 138 | 25.1.1 | Requirements for the support of conversational services | 51d | 2002-08-30 A | 2002-11-08 A | 100% |  |  |  |  |  | finish no earlier than 2002-11-08 | GP | 408h | 408h |  |  |  |  |  |  |
| 139 | 23.1.2 | Identification of the different building blocks for the provision of conversational services on the existing A/Gb protocol stack | 51d? | 2002-08-30 A | 2002-11-08 A | 100% |  |  |  |  |  | finish no earlier than 2002-11-08 | GP | 408h | 408h |  |  |  |  |  |  |
| 140 | 23.1.3 | Outline of impact and feasibility of these building blocks and their different solutions | 51d? | 2002-08-30 A | 2002-11-08 A | 100% |  |  |  |  |  | finish no earlier than 2002-11-08 | GP | 408h | 408h |  |  |  |  |  |  |
| 141 | 25.1.2 | Identification of the different building blocks for the provision of conversational services on the existing A/Gb protocol stack | 51d | 2002-08-30 | 2002-11-08 |  |  |  |  |  | 350d | finish no earlier than 2002-11-08 | G2 | 408h |  |  |  |  |  |  |  |
| 142 | 25.1.3 | Outline of impact and feasibility of these building blocks and their different solutions | 51d | 2002-08-30 | 2002-11-08 |  |  |  |  |  | 350d | finish no earlier than 2002-11-08 | G2 | 408h |  |  |  |  |  |  |  |
| 143 | 25.1.4 | Impact on 3GPP architecture and requirement to co-ordinatge with other TSGs (CN, SA) | 51d | 2002-08-30 A | 2002-11-08 A | 100% |  |  |  |  |  | finish no earlier than 2002-11-08 | GP | 408h | 408h |  |  |  |  |  |  |
| 144 | 25.1.5 | Standardisation effort | 51d | 2002-08-30 A | 2002-11-08 A | 100% |  |  |  |  |  | finish no earlier than 2002-11-08 | GP | 408h | 408h |  |  |  |  |  |  |
| 145 | 25.1.6 | Dependency to other features | 51d | 2002-08-30 A | 2002-11-08 A | 100% |  |  |  |  |  | finish no earlier than 2002-11-08 | GP | 408h | 408h |  |  |  |  |  |  |
| 146 | 26 | **Flexible Layer One for GERAN** | 910d? | 2000-01-03 A | 2003-06-27 | 31% | 623.63d? | 2000-01-03 | 2002-06-28 | 650d | 220d |  | GP | 58255h | 16325.4h | TBD |  | FLOGER | Benoist Sébire | benoist.sebire@nokia.com |  |
| 147 | 26.1 | **Realisation of a Flexible Layer One** | 910d | 2000-01-03 A | 2003-06-27 | 40% | 546d | 2000-01-03 | 2002-06-28 | 650d | 220d |  | GP | 29488h | 11795.2h |  |  | FLOGER-Real | Benoist Sébire | benoist.sebire@nokia.com |  |
| 148 | 26.1.1 | Technical Report | 311d | 2002-04-19 A | 2003-06-27 | 40% | 186.6d | 2002-04-19 | 2002-06-28 | 51d | 185d | finish no earlier than 2003-06-27 | GP | 2488h | 995.2h |  |  |  |  |  |  |
| 149 | 26.1.2 | Architecture in 45.001 and 43.051 | 311d | 2002-04-19 A | 2003-06-27 | 40% | 186.6d | 2002-04-19 | 2002-06-28 | 51d | 185d | finish no earlier than 2003-06-27 | G1 | 2488h | 995.2h |  |  |  |  |  |  |
| 150 | 26.1.3 | Multiplexing in 45.002 | 311d | 2002-04-19 A | 2003-06-27 | 40% | 186.6d | 2002-04-19 | 2002-06-28 | 51d | 185d | finish no earlier than 2003-06-27 | G1 | 2488h | 995.2h |  |  |  |  |  |  |
| 151 | 26.1.4 | Channel Coding in 45.003 | 311d | 2002-04-19 A | 2003-06-27 | 40% | 186.6d | 2002-04-19 | 2002-06-28 | 51d | 185d | finish no earlier than 2003-06-27 | G1 | 2488h | 995.2h |  |  |  |  |  |  |
| 152 | 26.1.5 | Performance Requirements in 45.005 | 910d | 2000-01-03 A | 2003-06-27 | 40% | 546d | 2000-01-03 | 2002-06-28 | 650d | 185d | finish no earlier than 2003-06-27 | G1 | 7280h | 2912h |  |  |  |  |  |  |
| 153 | 26.1.6 | Radio subsystem link control in 45.008 | 311d | 2002-04-19 A | 2003-06-27 | 40% | 186.6d | 2002-04-19 | 2002-06-28 | 51d | 185d | finish no earlier than 2003-06-27 | G1 | 2488h | 995.2h |  |  |  |  |  |  |
| 154 | 26.1.7 | Requirements in 44.004 | 311d | 2002-04-19 A | 2003-06-27 | 40% | 186.6d | 2002-04-19 | 2002-06-28 | 51d | 185d | finish no earlier than 2003-06-27 | G2 | 2488h | 995.2h |  |  |  |  |  |  |
| 155 | 26.2 | **Signalling and protocol support for a Flexible Layer One** | 311d | 2002-04-19 A | 2003-06-27 | 30% | 217.7d | 2002-04-19 | 2002-06-28 | 51d | 220d |  | G2 | 7464h | 2239.2h |  |  | FLOGER-SigPro | Benoist Sébire | benoist.sebire@nokia.com |  |
| 156 | 26.2.1 | Modifications to RLC/MAC in 44.060 and 44.160 | 311d | 2002-04-19 A | 2003-06-27 | 30% | 217.7d | 2002-04-19 | 2002-06-28 | 51d | 185d | finish no earlier than 2003-06-27 | G2 | 2488h | 746.4h |  |  |  |  |  |  |
| 157 | 26.2.2 | Modifications to RRC in 44.118 and 44.018 | 311d | 2002-04-19 A | 2003-06-27 | 30% | 217.7d | 2002-04-19 | 2002-06-28 | 51d | 185d | finish no earlier than 2003-06-27 | G2 | 2488h | 746.4h |  |  |  |  |  |  |

Notes:
- 133: Per 30/5: This WID was approved in SA#11 as a feature. SA2 work on 23.221, 23.060 and 23.228 is targeted for TSG#13. The stage 3 work (mostly CN1?) is targeted for TSG#15 (March 2002)
- 136: Closed
- 146: Nokia, Ericsson, Siemens, Telia
- 147: Started
- 155: Started

| ID | WBS | Task | Duration | Start | Finish | Complete | Remaining | Baseline start | Baseline finish | Baseline duration | Total slack | Constraint | Resources | Work | Actual work | Text1 | Text4 | Text5 | Text3 | Text6 | Text8 | Text9 | Text7 |
| --- | --- | --- | --- | --- | --- | --- | --- | --- | --- | --- | --- | --- | --- | --- | --- | --- | --- | --- | --- | --- | --- | --- | --- |
| 158 | 26.3 | **Security for a Flexible Layer One** | 256d | 2002-04-19 | 2003-04-11 |  |  | 2002-04-19 | 2002-06-28 | 51d | 275d |  | S3, G2 | 4063.04h |  | FLOGER-SecFLO | Benoist Sébire | benoist.sebire@nokia.com |  |  |  |  |  |
| 159 | 26.3.1 | Ciphering in 44.160,44.118, 44.060 and 44.018 | 256d | 2002-04-19 | 2003-04-11 |  |  | 2002-04-19 | 2002-06-28 | 51d | 240d | finish no earlier than 2003-04-11 | S3, G2 | 2048h |  |  |  |  |  |  |  |  |  |
| 160 | 26.4 | **GERAN MS Conformance test for the Flexible Layer One** | 155.5d | 2002-11-22 | 2003-06-27 |  |  | 2002-04-19 | 2002-06-28 | 51d | 220d |  | G4; G5 | 4976h |  | FLOGER-Msconf | Benoist Sébire | benoist.sebire@nokia.com |  |  |  |  |  |
| 161 | 26.4.1 | MS Test in 51.010 | 155.5d | 2002-11-22 | 2003-06-27 |  |  | 2002-04-19 | 2002-06-28 | 51d | 185d | finish no earlier than 2003-06-27 | G4; G5 | 2488h |  |  |  |  |  |  |  |  |  |
| 162 | 24.5 | GERAN BTS Conformance test for the Flexible Layer One | 1d? | 2000-01-03 | 2000-01-03 |  |  |  |  |  | 1129d |  | G3 | 8h |  | FLOGER-BTSconf | Benoist Sébire | benoist.sebire@nokia.com |  |  |  |  |  |
| 163 | 26.5 | **GERAN BTS Conformance test for the Flexible Layer One** | 311d | 2002-04-19 | 2003-06-27 |  |  | 2002-04-19 | 2002-06-28 | 51d | 220d |  | G3 | 4976h |  | FLOGER-BTSconf | Benoist Sébire | benoist.sebire@nokia.com |  |  |  |  |  |
| 164 | 26.5.1 | BTS Test in 51.021 | 311d | 2002-04-19 | 2003-06-27 |  |  |  |  |  | 185d | finish no earlier than 2003-06-27 | G3 | 2488h |  |  |  |  |  |  |  |  |  |
| 165 | 27 | Uplink TDOA feasibility study | 151d | 2001-11-30 A | 2002-06-28 A | 100% |  | 2001-11-30 | 2002-06-28 | 151d |  | finish no earlier than 2002-06-28 | GP | 1208h | 1208h | TDOAF | Bob Gross, TruePosition, Inc. | rlgross@trueposition.com | 45.811 | Rel6 | Paolo |  |  |
| 166 | 28 | **Multimedia Broadcast and Multicast Service** | 608d | 2001-05-11 A | 2003-09-09 | 17% | 504.12d | 2001-05-11 | 2003-09-30 | 623d | 168d |  | S1 | 41337.6h | 6755.54h | MBMS |  |  |  | Rel6 | Michael |  |  |
| 167 | 28.1 | Stage 1 | 232d | 2001-05-11 A | 2002-04-01 | 85% | 34.8d | 2001-05-11 | 2002-04-01 | 232d | 544d | finish no earlier than 2002-04-01 | S1 | 1856h | 1577.6h |  |  |  | 22.101 |  |  | 11003 |  |
| 168 | 28.2 | **Stage 2** | 445d | 2001-09-24 A | 2003-06-06 | 67% | 147.44d | 2001-08-31 | 2002-09-20 | 276d | 235d |  | S2 | 7160h | 3732h |  |  |  |  |  |  |  | TSG |
| 169 | 28.2.1 | TR on Architectural Study | 240d | 2001-09-24 A | 2002-08-23 A | 100% |  |  |  |  |  | finish no earlier than 2002-08-23 | S2 | 1920h | 1920h |  |  |  |  |  |  |  |  |
| 170 | 28.2.2 | Stage 2 Specification Work | 210d | 2002-08-19 A | 2003-06-06 | 29% | 149.1d |  |  |  | 200d | finish no earlier than 2003-06-06 | S2 | 1680h | 487.2h |  |  |  |  |  |  |  |  |
| 171 | 28.3 | Introduction of MBMS in RAN | 379d | 2002-01-01 A | 2003-06-13 | 15% | 322.15d | 2002-01-01 | 2003-09-30 | 456d | 195d | finish no earlier than 2003-06-13 | R2 | 3032h | 454.8h | MBMS-RAN | Dimitris Koulakiotis, Nokia |  |  |  |  | 2481 | TSG |
| 172 | 28.4 | Support of the MBMS in CN protocols | 321d | 2002-06-18 A | 2003-09-09 | 2% | 314.58d |  |  |  | 133d | finish no earlier than 2003-09-09 | N1 | 2568h | 51.36h |  |  |  |  |  |  |  | TSG |
| 173 | 28.5 | Security Aspects of Multimedia Broadcast/Multicast Service (MBMS) | 175d | 2002-07-01 A | 2003-02-28 | 20% | 140d |  |  |  | 270d | finish no earlier than 2003-02-28 | S3 | 1400h | 280h | MBMS | Escott, Adrian, Hutchison 3G UK | adrian.escott@hutchison3g.com |  |  |  |  | TSG |
| 174 | 28.6 | **Support of MBMS in GERAN** | 216d | 2002-08-30 A | 2003-06-27 | 3% | 209.13d |  |  |  | 220d |  | GP | 20736h | 659.78h | MBMS-GERAN |  |  |  | Rel6 |  |  | TSG |
| 175 | 28.6.1 | Impact on the logical and physical channels | 216d | 2002-08-30 A | 2003-06-27 | 5% | 205.2d |  |  |  | 185d | finish no earlier than 2003-06-27 | GP | 1728h | 86.4h |  |  |  |  |  |  |  |  |
| 176 | 28.6.2 | Simultaneous support of MBMS services | 216d | 2002-08-30 | 2003-06-27 |  |  |  |  |  | 185d | finish no earlier than 2003-06-27 | G1 | 1728h |  |  |  |  |  |  |  |  |  |
| 177 | 28.6.3 | Simultaneous support of MBMS and non-MBMS services | 216d | 2002-08-30 | 2003-06-27 |  |  |  |  |  | 185d | finish no earlier than 2003-06-27 | G1 | 1728h |  |  |  |  |  |  |  |  |  |
| 178 | 28.6.4 | Re-synchronisation at cell change | 216d | 2002-08-30 | 2003-06-27 |  |  |  |  |  | 185d | finish no earlier than 2003-06-27 | G2 | 1728h |  |  |  |  |  |  |  |  |  |
| 179 | 28.6.5 | Decision making process between point-to-point or pont-to-multipoint configurations | 216d | 2002-08-30 A | 2003-06-27 | 5% | 205.2d |  |  |  | 185d | finish no earlier than 2003-06-27 | GP | 1728h | 86.4h |  |  |  |  |  |  |  |  |
| 180 | 28.6.6 | MBMS channel allocations procedures to multiple MSs | 216d | 2002-08-30 A | 2003-06-27 | 5% | 205.2d |  |  |  | 185d | finish no earlier than 2003-06-27 | GP | 1728h | 86.4h |  |  |  |  |  |  |  |  |
| 181 | 28.6.7 | Changes to the Gb interface | 216d | 2002-08-30 A | 2003-06-27 | 5% | 205.2d |  |  |  | 185d | finish no earlier than 2003-06-27 | GP | 1728h | 86.4h |  |  |  |  |  |  |  |  |
| 182 | 28.6.8 | GERAN specific changes to the Iu-ps interface | 216d | 2002-08-30 A | 2003-06-27 | 5% | 205.2d |  |  |  | 185d | finish no earlier than 2003-06-27 | GP | 1728h | 86.4h |  |  |  |  |  |  |  |  |
| 183 | 28.6.9 | Interaction between MBMS and Iu-flex | 216d | 2002-08-30 A | 2003-06-27 | 5% | 205.2d |  |  |  | 185d | finish no earlier than 2003-06-27 | GP | 1728h | 86.4h |  |  |  |  |  |  |  |  |
| 184 | 28.6.10 | Security aspects | 216d | 2002-08-30 A | 2003-06-27 | 5% | 205.2d |  |  |  | 185d | finish no earlier than 2003-06-27 | GP | 1728h | 86.4h |  |  |  |  |  |  |  |  |
| 185 | 28.6.11 | MS conformance tests | 216d | 2002-08-30 | 2003-06-27 |  |  |  |  |  | 185d | finish no earlier than 2003-06-27 | G5 | 1728h |  |  |  |  |  |  |  |  |  |

Notes:
- 158: Started
- 160: Not started
- 162: Not started
- 166: Title renamed at SA#13
- 167: This may or may not be a separate stage 1. In the meantime, CRs are proposed for 22.101
- 173: WID approved SA#17

| ID | WBS | Task | Duration | Start | Finish | Complete | Remaining | Baseline start | Baseline finish | Baseline duration | Total slack | Constraint | Resources | Work | Actual work | Text1 | Text6 | Text7 | Text8 | Text3 | Text4 | Text5 |
| --- | --- | --- | --- | --- | --- | --- | --- | --- | --- | --- | --- | --- | --- | --- | --- | --- | --- | --- | --- | --- | --- | --- |
| 186 | 29 | **Speech Recognition and Speech Enabled Services** | 440d? | 2001-10-08 A | 2003-06-13 | 15% | 375.13d? | 2001-10-08 | 2003-03-14 | 375d | 230d |  | S1 | 8512h | 1254.97h | SRSES | Rel6 | TSG | Michael |  |  |  |
| 187 | 29.1 | Speech Enabled Services Based on Distributed Speech Recognition (DSR) | 115d | 2001-10-08 A | 2002-03-15 | 80% | 23d | 2001-10-08 | 2002-03-15 | 115d | 520d | finish no earlier than 2002-03-15 | S1 | 920h | 736h | DSR |  | TSG |  | 22.941, 23.207 | D Williams, QUALCOMM, Inc. | Dwilliams@qualcomm.com |
| 188 | 29.2 | Stage 2 of DSR | 152d | 2002-08-05 | 2003-03-04 |  |  | 2002-04-22 | 2002-11-19 | 152d | 268d | finish no earlier than 2003-03-04 | S2 | 1216h |  |  |  |  |  |  |  |  |
| 189 | 29.3 | SDP protocols extension to include DSR | 183d | 2002-09-23 | 2003-06-04 |  |  | 2002-09-23 | 2003-03-14 | 125d | 202d | finish no earlier than 2003-06-04 | N1 | 1464h |  |  |  |  |  |  |  |  |
| 190 | 27.4 | Codec Work to Support Speech Recognition Framework for Automated Voice Services | 174d? | 2002-10-15 | 2003-06-13 |  |  |  |  |  | 195d | finish no earlier than 2003-06-13 | S4 | 1392h |  | SRSES-Codec |  | WG |  |  | David Pearce, Motorola |  |
| 191 | 30 | **Generic User Profile** | 437d | 2001-10-08 A | 2003-06-10 | 33% | 294.55d | 2001-10-08 | 2003-06-10 | 437d | 233d |  | S1 | 18143.8h | 5914.4h | GUP | Rel6 | TSG | Michael |  |  |  |
| 192 | 30.1 | Stage 1 - Requirements | 306d | 2001-10-08 A | 2002-12-09 | 65% | 107.1d | 2001-10-08 | 2002-12-09 | 306d | 329d | finish no earlier than 2002-12-09 | S1 | 2448h | 1591.2h |  |  |  |  | 22.240 | Paul Amery (Orange) | paul.amery@orange.co.uk |
| 193 | 30.2 | Stage 2 - Data description framework | 372d | 2001-10-08 A | 2003-03-11 | 40% | 223.2d | 2001-10-08 | 2003-03-11 | 372d | 263d | finish no earlier than 2003-03-11 | T2 | 2976h | 1190.4h |  |  | WG |  | 23.241 |  |  |
| 194 | 30.3 | Stage 2 - Architecture | 355d | 2002-01-28 A | 2003-06-06 | 58% | 149.1d | 2002-01-28 | 2003-01-03 | 245d | 200d | finish no earlier than 2003-06-06 | S2 | 2840h | 1647.2h |  |  |  |  | 23.240 | Nacho Uzquiano (Telefonica) | uzquiano_ji@tsm.es |
| 195 | 30.4 | Stage 3 - Common objects | 437d | 2001-10-08 A | 2003-06-10 | 5% | 415.15d | 2001-10-08 | 2003-06-10 | 437d | 198d | finish no earlier than 2003-06-10 | T2 | 3496h | 174.8h |  |  | WG |  | 24.241 |  |  |
| 196 | 30.5 | Stage 3 - Network | 146.98d | 2002-11-18 | 2003-06-10 |  |  | 2002-05-06 | 2002-12-30 | 170d | 198d | finish no earlier than 2003-06-10 | N4 | 1175.84h |  |  |  |  |  | 29.240 |  |  |
| 197 | 30.6 | Security Aspects | 214d | 2002-07-16 A | 2003-05-09 | 10% | 192.6d |  |  |  | 220d | finish no earlier than 2003-05-09 | S3 | 1712h | 171.2h |  |  | WG |  | 33.102, 33.203, 33.210 | Owen, Bradley | bvowen@lucent.com |
| 198 | 31 | **Digital Rights Management** | 380d? | 2001-10-08 A | 2003-03-21 | 30% | 267.7d? | 2001-10-08 | 2003-03-03 | 366d | 290d |  | S1 | 8688h | 2567.64h | DRM | Rel6 | TSG | Michael |  |  |  |
| 199 | 31.1 | Requirements | 179d | 2001-10-08 A | 2002-06-13 | 75% | 44.75d | 2001-10-08 | 2002-06-13 | 179d | 456d | finish no earlier than 2002-06-13 | S1 | 1432h | 1074h |  |  |  |  |  | Nicholas Wood, Openwave Systems | nicholas.wood@openwave.com |
| 200 | 29.2 | Monitoring of Stages 2 and 3 progress (actual work to be done by OMA) | 155d? | 2002-08-19 | 2003-03-21 |  |  |  |  |  | 255d | start no earlier than 2002-08-19 | S1 | 1240h |  |  |  |  |  |  |  |  |
| 201 | 31.3 | Security | 186d | 2002-06-17 A | 2003-03-03 | 40% | 111.6d | 2002-06-17 | 2003-03-03 | 186d | 269d | finish no earlier than 2003-03-03 | S3 | 1488h | 595.2h |  |  |  |  |  |  |  |
| 202 | 31.4 | Codec Aspects | 186d | 2002-06-17 | 2003-03-03 |  |  | 2002-06-17 | 2003-03-03 | 186d | 269d | finish no earlier than 2003-03-03 | S4 | 1488h |  |  |  |  |  |  |  |  |
| 203 | 32 | **FS on WLAN-UMTS Interworking** | 840d? | 2000-01-03 A | 2003-03-21 | 35% | 541.85d? | 2000-01-03 | 2002-12-25 | 778d | 290d |  | S1 | 19656h | 8184.43h | WLAN | Rel6 | TSG | Michael |  | Fredric Paint, Telenor | frederic.paint@telenor.com |
| 204 | 32.1 | **Technical Report** | 616d? | 2000-01-03 A | 2002-05-13 | 25% | 462d? | 2000-01-03 | 2002-05-13 | 616d | 514d |  | S1 | 9856h | 4188.8h | WLAN-TR |  |  |  | 22.934, 22.101, 22.105 | Fredric Paint, Telenor | frederic.paint@telenor.com |
| 205 | 30.1.1 | CRs to implement WLAN | 616d? | 2000-01-03 A | 2002-05-13 | 25% | 462d? |  |  |  | 479d | finish no earlier than 2002-05-13 | S1 | 4928h | 1232h | WLAN-CR |  |  |  | 22.934, 22.101, 22.105 | Fredric Paint, Telenor | frederic.paint@telenor.com |
| 206 | 32.2 | WLAN Interworking – Architecture Definition | 260d | 2002-03-25 A | 2003-03-21 | 63% | 96.2d | 2002-03-25 | 2002-12-25 | 198d | 255d | finish no earlier than 2003-03-21 | S2 | 2080h | 1310.4h |  |  | TSG |  |  |  |  |
| 207 | 32.3 | Security | 125d | 2002-09-30 A | 2003-03-21 | 30% | 87.5d |  |  |  | 255d | finish no earlier than 2003-03-21 | S3 | 1000h | 300h |  |  | TSG |  | 21.133, 33.106, 33.107, 33.108, 33.200, 33.203, 33.210 | Lopez-Soria, Luis, Ericsson | luis.lopez-soria@ece.ericsson.se |
| 208 | 33 | **Priority Service** | 208d | 2002-05-30 A | 2003-03-17 | 80% | 41.45d | 2002-05-30 | 2002-06-14 | 12d | 294d |  | S1 | 3248h | 2600.73h | PRIOR | Rel6 |  |  |  |  |  |
| 209 | 33.1 | Feasibility Study | 1d | 2002-06-14 A | 2002-06-14 | 95% | 0.05d | 2002-06-14 | 2002-06-14 | 1d | 490d | finish no earlier than 2002-06-14 | S1 | 8h | 7.6h | PRIOR-FS |  |  | Michael | 22.950 | Biplab K. Pramanik, Telcordia Technologies | bpramani@telcordia.com |
| 210 | 33.2 | Stage 1 - Requirements | 208d | 2002-05-30 A | 2003-03-17 | 80% | 41.6d | 2002-05-30 | 2002-05-30 | 1d | 294d | finish no earlier than 2003-03-17 | S1 | 1664h | 1331.2h | PRIOR-SR |  |  | Michael |  | James J. Garrahan, Telcordia Technologies | bpramani@telcordia.com |

Notes:
- 196: 17 May no activity in CN4 / 02/08/2002 CN4: No activity in CN4
- 197: WID approved SA#17. SA WG3 progress slow, depends on progress in other groups.
- 198: Foreseen start and completion dates introduced by MCC (no indication at all on the WID)
- 201: SA3 acknowledge role in WI at SA3#20. Active contribution S3#24, S3#25. S3 WID approved SA#17
- 207: Active contribution S3#24, S3#25. WID approved SA#17

| ID | WBS | Task | Duration | Start | Finish | Predecessors | Complete | Remaining | Baseline start | Baseline finish | Baseline duration | Total slack | Constraint | Resources | Work | Actual work | Text1 | Text6 | Text8 | Text3 | Text7 | Text4 | Text5 | Text2 | Text9 |
| --- | --- | --- | --- | --- | --- | --- | --- | --- | --- | --- | --- | --- | --- | --- | --- | --- | --- | --- | --- | --- | --- | --- | --- | --- | --- |
| 211 | 34 | **Network Sharing** | 153d | 2001-11-14 A | 2002-06-14 |  | 75% | 38.25d | 2001-11-14 | 2002-06-14 | 153d | 490d |  | S1 | 2432h | 1824h | NTShar | Rel6 | Michael |  |  |  |  |  |  |
| 212 | 34.1 | Technical Report | 153d | 2001-11-14 A | 2002-06-14 |  | 75% | 38.25d | 2001-11-14 | 2002-06-14 | 153d | 490d | start no earlier than 2001-11-14 | S1 | 1224h | 918h | NTShar-TR |  | Michael | 22.951 |  |  |  |  |  |
| 213 | 35 | **QoS Improvements** | 245d | 2002-07-15 A | 2003-06-20 |  | 35% | 159.25d | 2002-04-22 | 2002-08-19 | 86d | 225d |  | S2 | 3920h | 1372h | QoS1 | NA |  |  | TSG |  |  |  |  |
| 214 | 35.1 | FS on Dynamic Policy control enhancements for end-to-end QoS | 245d | 2002-07-15 A | 2003-06-20 |  | 35% | 159.25d | 2002-04-22 | 2002-08-19 | 86d | 190d | finish no earlier than 2003-06-20 | S2 | 1960h | 686h | QoS1 | Rel6 |  |  | TSG |  |  |  |  |
| 215 | 36 | **Support for subscriber certificates** | 189d | 2002-02-25 A | 2002-11-14 |  | 49% | 97.2d | 2002-02-25 | 2002-09-12 | 144d | 381d |  | S3 | 2856h | 1387.2h | SEC1-SC | Rel6 | Maurice | 33.102 | TSG | Valtteri Niemi, Nokia | valtteri.niemi@nokia.com |  |  |
| 216 | 36.1 | Stage 1 | 144d | 2002-02-25 A | 2002-09-12 |  | 40% | 86.4d |  |  |  | 391d | finish no earlier than 2002-09-12 | S3 | 1152h | 460.8h |  |  |  |  |  |  |  |  |  |
| 217 | 36.2 | Architecture review (name changed from "Stage2") | 24d | 2002-10-14 A | 2002-11-14 A |  | 100% |  |  |  |  |  | finish no earlier than 2002-11-14 | S2 | 192h | 192h |  |  |  |  |  |  |  |  |  |
| 218 | 38 | **Rel-6 OSA enhancements** | 899d? | 2000-07-11 A | 2003-12-19 |  | 38% | 556.14d? | 2002-03-14 | 2002-12-20 | 202d | 95d |  | S1 | 44913.6h | 18866.2h | OSA3 | Rel6 | Adrian | 22.127, 29.198, 29.998 | TSG | Chelo ABARCA (Alcatel) | Chelo.Abarca@alcatel.fr |  |  |
| 219 | 38.1 | Support of a Generic Network Interface Function (Stage 1) | 212.1d | 2002-02-27 A | 2003-01-06 A |  | 100% |  | 2002-03-14 | 2002-12-20 | 202d |  | finish no earlier than 2003-01-06 | S1 | 1696.79h | 1696.79h |  |  |  | 22.127 | TSG |  |  |  |  |
| 220 | 38.2 | Support of a Generic Network Interface Function (Stage 3) | 462d | 2002-02-14 A | 2003-12-19 |  | 15% | 392.7d | 2002-03-14 | 2002-12-20 | 202d | 95d | finish no earlier than 2003-12-19 | N5 | 3696h | 554.4h |  |  |  | 29.198, 29.998 | TSG | Chelo ABARCA (Alcatel) | Chelo.Abarca@alcatel.fr |  |  |
| 221 | 38.11 | User Data Management / User data security management (Stage 1) | 212.1d | 2002-02-27 A | 2003-01-06 A |  | 100% |  | 2002-03-14 | 2002-12-20 | 202d |  | finish no earlier than 2003-01-06 | S1 | 1696.79h | 1696.79h |  |  |  | 22.127 | TSG |  |  |  |  |
| 222 | 38.12 | User Data Management / User data security management (Stage 3) | 462d | 2002-03-14 A | 2003-12-19 |  | 15% | 392.7d |  |  |  | 95d | finish no earlier than 2003-12-19 | N5 | 3696h | 554.4h |  |  |  | 29.198, 29.998 | TSG | Chelo ABARCA (Alcatel) | Chelo.Abarca@alcatel.fr |  |  |
| 223 | 37.1.2 | Access to User Profile | 145d | 2001-06-01 A | 2001-12-20 |  | 90% | 14.5d | 2001-06-01 | 2001-12-20 | 145d | 616d | finish no earlier than 2001-12-20 | S1 | 1160h | 1044h | OSA1-UP |  |  |  | TSG |  |  |  |  |
| 224 | 35.6 | Retrieval of Visited Network capabilities | 297d? | 2002-10-31 A | 2003-12-19 |  | 15% | 252.45d? |  |  |  | 95d | finish no earlier than 2003-12-19 | N5 | 2376h | 356.4h |  |  |  | 29.198, 29.998 | TSG | Chelo ABARCA (Alcatel) | Chelo.Abarca@alcatel.fr |  |  |
| 225 | 35.7 | Access to IP Session information | 297d? | 2002-10-31 A | 2003-12-19 |  | 15% | 252.45d? |  |  |  | 95d | finish no earlier than 2003-12-19 | N5 | 2376h | 356.4h |  |  |  | 29.198, 29.998 | TSG | Chelo ABARCA (Alcatel) | Chelo.Abarca@alcatel.fr |  |  |
| 226 | 35.8 | Multi Media Messaging function | 297d? | 2002-10-31 A | 2003-12-19 |  | 15% | 252.45d? |  |  |  | 95d | finish no earlier than 2003-12-19 | N5 | 2376h | 356.4h |  |  |  | 29.198, 29.998 | TSG | Chelo ABARCA (Alcatel) | Chelo.Abarca@alcatel.fr |  |  |
| 227 | 35.9 | Enhanced user privacy in LCS | 297d? | 2002-10-31 A | 2003-12-19 |  | 15% | 252.45d? |  |  |  | 95d | finish no earlier than 2003-12-19 | N5 | 2376h | 356.4h |  |  |  | 29.198, 29.998 | TSG | Chelo ABARCA (Alcatel) | Chelo.Abarca@alcatel.fr |  |  |
| 228 | 35.10 | Policy management extensions | 297d? | 2002-10-31 A | 2003-12-19 |  | 15% | 252.45d? |  |  |  | 95d | finish no earlier than 2003-12-19 | N5 | 2376h | 356.4h |  |  |  | 29.198, 29.998 | TSG | Chelo ABARCA (Alcatel) | Chelo.Abarca@alcatel.fr |  |  |
| 229 | 35.11 | Presence and Availability Management (from the PRESNC WI) | 297d? | 2002-10-31 A | 2003-12-19 |  | 15% | 252.45d? |  |  |  | 95d | finish no earlier than 2003-12-19 | N5 | 2376h | 356.4h |  |  |  | 29.198, 29.998 | TSG | Chelo ABARCA (Alcatel) | Chelo.Abarca@alcatel.fr |  |  |
| 230 | 35.12 | Information Services | 297d? | 2002-10-31 A | 2003-12-19 |  | 15% | 252.45d? |  |  |  | 95d | finish no earlier than 2003-12-19 | N5 | 2376h | 356.4h |  |  |  | 29.198, 29.998 | TSG | Chelo ABARCA (Alcatel) | Chelo.Abarca@alcatel.fr |  |  |
| 231 | 35.13 | Information Transfer | 297d? | 2002-10-31 A | 2003-12-19 |  | 15% | 252.45d? |  |  |  | 95d | finish no earlier than 2003-12-19 | N5 | 2376h | 356.4h |  |  |  | 29.198, 29.998 | TSG | Chelo ABARCA (Alcatel) | Chelo.Abarca@alcatel.fr |  |  |
| 232 | 38.13 | Security | 202d | 2002-03-14 A | 2002-12-20 A |  | 100% |  | 2002-03-14 | 2002-12-20 | 202d |  | finish no earlier than 2002-12-20 | S3 | 1616h | 1616h |  |  |  |  | TSG |  |  |  |  |
| 233 | 38.14 | **Retrieval of Terminal capabilities** | 634d | 2000-07-11 A | 2002-12-13 |  | 86% | 88.34d | 2000-07-11 | 2002-12-13 | 634d | 360d |  | S2 | 8648h | 7443.06h | OSA1-TC |  |  |  | TSG |  |  | Ser | 1433 |
| 234 | 38.14.1 | Stage 1 | 132d | 2000-07-11 A | 2001-01-10 A |  | 100% |  | 2000-07-11 | 2001-01-10 | 132d |  | finish no earlier than 2001-01-10 | S1 | 1056h | 1056h |  |  |  | 22.127 | TSG | Jörg Swetina, SIEMENS AG |  | Ser | 1434 |
| 235 | 38.14.2 | Stages 2 and 3 | 321d | 2001-09-21 A | 2002-12-13 A | 234 | 100% |  | 2001-09-21 | 2002-12-13 | 321d |  | finish no earlier than 2002-12-13 | N5 | 2568h | 2568h |  |  |  | 29.198, 29.998 | TSG | Ard-Jan MOERDIJK (Ericsson) | Ard.Jan.Moerdijk@eln.ericsson.se | Ser | 1436 |
| 236 | 38.14.3 | Provisionning of the terminal capabilities | 175d | 2001-04-02 A | 2001-11-30 |  | 50% | 87.5d | 2001-04-02 | 2001-11-30 | 175d | 630d | finish no earlier than 2001-11-30 | T2 | 1400h | 700h |  |  |  | 23.057 | TSG |  |  |  | 2122 |

Notes:
- 215: Approved at SA#14. This may require BBs from CN1, CN4, SA5 and T3
- 216: Contribution received S3#24, S3#25
- 218: TSG approval target 9/03->12/03. New Rapp.
- 220: TSG approval target 9/03->12/03. New Rapp.
- 222: TSG approval target 9/03->12/03. New Rapp.
- 224: TSG approval target 9/03->12/03. New Rapp.
- 225: TSG approval target 9/03->12/03. New Rapp.
- 226: TSG approval target 9/03->12/03. New Rapp.
- 227: TSG approval target 9/03->12/03. New Rapp.
- 228: TSG approval target 9/03->12/03. New Rapp.
- 229: TSG approval target 9/03->12/03. New Rapp.
- 230: TSG approval target 9/03->12/03. New Rapp.
- 231: TSG approval target 9/03->12/03. New Rapp.
- 232: Contribution at S3#25
- 236: According to T2 SWG1 M. Cataldo this is automatically supported by the MExE support of UAProf therefore 100% complete

| ID | WBS | Task | Duration | Start | Finish | Complete | Remaining | Total slack | Constraint | Resources | Work | Actual work | Text1 | Text6 | Text7 | Text4 | Text5 | Text3 | Text8 |
| --- | --- | --- | --- | --- | --- | --- | --- | --- | --- | --- | --- | --- | --- | --- | --- | --- | --- | --- | --- |
| 237 | 36 | **Handling of early UEs** | 115d? | 2002-10-07 A | 2003-03-14 | 30% | 80.5d? | 295d |  | S2 | 1720h | 516h | LATE_UE | Rel6 | WG |  |  |  |  |
| 238 | 36.1 | Feasibility Study | 50d? | 2002-10-07 A | 2002-12-13 | 60% | 20d? | 360d | finish no earlier than 2002-12-13 | S2 | 400h | 240h |  |  | WG |  |  |  |  |
| 239 | 36.2 | Stage 2 | 50d? | 2003-01-06 | 2003-03-14 |  |  | 295d | finish no earlier than 2003-03-14 | S2 | 400h |  |  |  | WG |  |  |  |  |
| 240 | 39 | **Addition of frequency bands to GSM** | 386d | 2002-06-28 A | 2003-12-19 | 6% | 361.64d | 95d |  | GP | 9680h | 610.87h | TAPS | Rel6 |  | Torben Themsen |  |  |  |
| 241 | 39.1 | **Addition of frequency bands to GSM – Changes to core specs** | 26d | 2002-11-15 A | 2002-12-20 A | 100% |  |  |  | G1 | 416h | 416h | TAPS-Specs | Rel6 | TSG | Torben Themsen |  |  |  |
| 242 | 39.1.1 | Changes to core specs | 26d | 2002-11-15 A | 2002-12-20 A | 100% |  |  | finish no earlier than 2002-12-20 | G1 | 208h | 208h |  |  |  |  |  |  |  |
| 243 | 39.2 | **Addition of frequency bands to GSM – Changes for conformance tests** | 386d | 2002-06-28 | 2003-12-19 |  |  | 95d |  | G4 | 6176h |  | TAPS-Conf |  |  | Torben Themsen |  |  |  |
| 244 | 39.2.1 | 51.010-1 Add testing | 386d | 2002-06-28 | 2003-12-19 |  |  | 95d | finish no earlier than 2003-12-19 | G4 | 3088h |  |  |  |  |  |  |  |  |
| 245 | 40 | **Seamless support of streaming services in A/Gb mode** | 1035d? | 2000-01-03 A | 2003-12-19 | 55% | 468.91d? | 95d |  | GP | 34008h | 14708.1h | SSStrea | Rel6 |  | José Luis Carrizo Martínez, Vodafone |  |  |  |
| 246 | 40.1 | **Identification of requirements for streaming** | 1d? | 2003-06-27 A | 2003-06-27 | 40% | 0.6d? | 220d |  | G1 | 16h | 11.2h |  |  |  |  |  |  |  |
| 247 | 38.1.1 | Requirements | 1d? | 2003-06-27 A | 2003-06-27 | 40% | 0.6d? | 220d | start no earlier than 2003-06-27 | G1 | 8h | 3.2h |  |  |  |  |  |  |  |
| 248 | 40.2 | **Performance study of cell change mechanisms** | 910d? | 2000-01-03 A | 2003-06-27 | 60% | 364d? | 220d |  | G1 | 29120h | 13196.8h |  |  |  |  |  |  |  |
| 249 | 38.2.1 | Performance of NACC | 910d? | 2000-01-03 A | 2003-06-27 | 60% | 364d? | 220d | finish no earlier than 2003-06-27 | G1 | 7280h | 4368h |  |  |  |  |  |  |  |
| 250 | 38.2.2 | Performance of cell change in DTM for the PS domain | 910d? | 2000-01-03 A | 2003-06-27 | 60% | 364d? | 220d | finish no earlier than 2003-06-27 | G1 | 7280h | 4368h |  |  |  |  |  |  |  |
| 251 | 38.2.3 | Handover | 910d? | 2000-01-03 A | 2003-06-27 | 60% | 364d? | 220d | finish no earlier than 2003-06-27 | G1 | 7280h | 4368h |  |  |  |  |  |  |  |
| 252 | 40.3 | **Reduction of service interruption times and packet loss during mobility procedures** | 1d? | 2003-06-27 A | 2003-06-27 | 20% | 0.8d? | 220d |  | G2 | 40h | 8h |  |  |  |  |  |  |  |
| 253 | 38.3.1 | Optimisations of existing mechanisms/procedures | 1d? | 2003-06-27 A | 2003-06-27 | 20% | 0.8d? | 220d | start no earlier than 2003-06-27 | G2 | 8h | 1.6h |  |  |  |  |  |  |  |
| 254 | 38.3.2 | Inter-system NACC | 1d? | 2003-06-27 A | 2003-06-27 | 20% | 0.8d? | 220d | start no earlier than 2003-06-27 | G2 | 8h | 1.6h |  |  |  |  |  |  |  |
| 255 | 38.3.3 | PS Handover (within GERAN and between GERAN and UTRAN) | 1d? | 2003-06-27 A | 2003-06-27 | 20% | 0.8d? | 220d | start no earlier than 2003-06-27 | G2 | 8h | 1.6h |  |  |  |  |  |  |  |
| 256 | 38.3.4 | Dependency to other features | 1d? | 2003-06-27 A | 2003-06-27 | 20% | 0.8d? | 220d | start no earlier than 2003-06-27 | G2 | 8h | 1.6h |  |  |  |  |  |  |  |
| 257 | 40.5 | **MS conformance testing** | 1d? | 2003-12-19 | 2003-12-19 |  |  | 95d |  | G4 | 16h |  |  |  |  |  |  |  |  |
| 258 | 38.4.1 | MS conformance tests | 1d? | 2003-12-19 | 2003-12-19 |  |  | 95d | start no earlier than 2003-12-19 | G4 | 8h |  |  |  |  |  |  |  |  |
| 259 | 38.5 | GERAN A/Gb mode security enhancements | 261d? | 2002-12-09 | 2003-12-08 |  |  | 104d | finish no earlier than 2003-12-08 | S3 | 2088h |  |  |  |  | Peter Howard, Vodafone | peter.howard@vodafone.com |  |  |
| 260 | 41 | Performance characterisation of default codecs for PS conversational multimedia application | 203d | 2002-09-11 A | 2003-06-20 | 5% | 192.85d | 225d | finish no earlier than 2003-06-20 | S4 | 1624h | 81.2h | CODCAR | Rel6 | TSG | Pasi Ojala (Nokia) |  | TR 26.9yz |  |
| 261 | 42 | Study of Feature Interactions Requirements | 82d | 2002-11-08 A | 2003-03-03 | 15% | 69.7d | 304d | start no earlier than 2002-11-08 | S1 | 656h | 98.4h | FINTER | Rel6 |  |  |  | TR 21.xyz | Michael |
| 262 | 43 | Study on Privacy Capability | 82d | 2002-11-08 A | 2003-03-03 | 15% | 69.7d | 304d | start no earlier than 2002-11-08 | S1 | 656h | 98.4h | PrivCap | Rel6 |  | Liz Daniel, Lucent |  | TR 21.xyz | Michael |

Notes:
- 241: Ready
- 243: Not started
- 246: Started
- 248: Started
- 252: Started
- 257: Not started

| ID | WBS | Task | Duration | Start | Finish | Complete | Remaining | Baseline start | Baseline finish | Baseline duration | Total slack | Constraint | Resources | Work | Actual work | Text1 | Text3 | Text4 | Text5 | Text6 | Text7 | Text2 | Text9 | Text8 |
| --- | --- | --- | --- | --- | --- | --- | --- | --- | --- | --- | --- | --- | --- | --- | --- | --- | --- | --- | --- | --- | --- | --- | --- | --- |
| 263 | 44 | **Rel-6 OAM&P** | 337d? | 2002-06-12 A | 2003-09-25 | 15% | 285.34d? |  |  |  | 156d |  | S5 | 20808h | 3000.51h | OAM | 32-series | Michael TRUSS (Motorola) | Michael.Truss@MOTOROLA.COM | Rel6 | TSG |  |  |  |
| 264 | 44.1 | Rel6 Principles, high level Requirements and Architecture | 271d | 2002-09-12 A | 2003-09-25 | 10% | 243.9d |  |  |  | 156d | finish no earlier than 2003-09-25 | S5 | 2168h | 216.8h | OAM-AR | 32.101, 32.102 | Michael TRUSS (Motorola) | Michael.Truss@MOTOROLA.COM |  | TSG | BCaM |  |  |
| 265 | 44.2 | Rel6 Performance Management | 271d | 2002-09-12 A | 2003-09-25 | 15% | 230.35d |  |  |  | 156d | finish no earlier than 2003-09-25 | S5 | 2168h | 325.2h | OAM-PM | 32.41x, 52.402 | Christian TOCHE (Nortel Networks) | toche@NORTELNETWORKS.COM |  | TSG | BCaM |  |  |
| 266 | 44.3 | **Rel6 User Equipment Management** | 301d? | 2002-08-01 A | 2003-09-25 | 7% | 281.11d? |  |  |  | 156d |  | S5 | 8912h | 588.85h | OAM-UEM | 32.150, 27.150 (T2), 32.802 | John Mudge (Vodafone) | john.mudge@vf.vodafone.co.uk |  | TSG |  |  |  |
| 267 | 42.3.1 | UEM requirements and architecture; Stages 1 and 2 | 271d? | 2002-09-12 A | 2003-09-25 | 10% | 243.9d? |  |  |  | 156d | finish no earlier than 2003-09-25 | S5 | 2168h | 216.8h |  | 32.150 (SA5) | John Mudge (Vodafone) | john.mudge@vf.vodafone.co.uk |  | TSG |  |  |  |
| 268 | 42.3.2 | UEM protocol specification; Stage 3 | 271d? | 2002-09-12 A | 2003-09-25 | 5% | 257.45d? |  |  |  | 156d | finish no earlier than 2003-09-25 | T2 | 2168h | 108.4h |  | 27.150 (T2) |  |  |  | TSG |  |  |  |
| 269 | 42.3.3 | Release 6 User Equipment Management: Security aspects | 301d? | 2002-08-01 A | 2003-09-25 | 5% | 285.95d? |  |  |  | 156d | finish no earlier than 2003-09-25 | S3 | 2408h | 120.4h | OAM-UEM-SEC |  | Peter Howard (Vodafone) | peter.howard@vodafone.com |  | TSG |  |  |  |
| 270 | 44.4 | Rel6 Network Infrastructure Management | 271d | 2002-09-12 A | 2003-09-25 | 5% | 257.45d |  |  |  | 156d | finish no earlier than 2003-09-25 | S5 | 2168h | 108.4h | OAM-NIM | 32.6xy, 32.3xy | Thomas TOVINGER (Ericsson) | Thomas.Tovinger@emw.ericsson.se |  | TSG |  |  |  |
| 271 | 44.5 | Rel6 Trace Management | 337d | 2002-06-12 A | 2003-09-25 | 50% | 168.5d |  |  |  | 156d | finish no earlier than 2003-09-25 | S5 | 2696h | 1348h | OEM-Trace | 32.42x, 52.008 | Christian TOCHE (Nortel Networks) | toche@NORTELNETWORKS.COM |  | TSG |  |  |  |
| 272 | 43 | **Charging Management** | 226d? | 2002-11-14 A | 2003-09-25 | 4% | 216.87d? |  |  |  | 156d |  | S5 | 8344h | 337.03h | CH | 32.2xy | Karl-Heinz NENNER (T-Mobile) | karl-heinz.nenner@t-mobile.de | Rel6 | TSG |  |  |  |
| 273 | 43.1 | Charging Management for Bearer level | 220d? | 2002-11-22 A | 2003-09-25 | 5% | 209d? |  |  |  | 156d | finish no earlier than 2003-09-25 | S5 | 1760h | 88h | CH-BC |  | Benni ALEXANDER (Nokia) |  |  | TSG |  |  |  |
| 274 | 43.2 | Charging Management for the IMS | 220d? | 2002-11-22 A | 2003-09-25 | 5% | 209d? |  |  |  | 156d | finish no earlier than 2003-09-25 | S5 | 1760h | 88h | CH-IC |  | Ariel SHARON (Lucent) |  |  | TSG |  |  |  |
| 275 | 43.3 | Charging Management for the Service domain | 220d? | 2002-11-22 A | 2003-09-25 | 5% | 209d? |  |  |  | 156d | finish no earlier than 2003-09-25 | S5 | 1760h | 88h | CH-SC |  | Gerald GÖRMER (Siemens) |  |  | TSG |  |  |  |
| 276 | 43.4 | Overall architectural aspects of IP flow based bearer level charging | 157d? | 2002-11-14 | 2003-06-20 |  |  |  |  |  | 225d | finish no earlier than 2003-06-20 | S2 | 1256h |  |  |  |  |  |  |  |  |  |  |
| 277 | 44 | **Rel-6 USIM toolkit enhancements** | 525d | 2000-09-25 A | 2002-09-27 | 80% | 106.64d |  |  |  | 415d |  | T3 | 14160h | 8886.88h |  |  |  |  | NA |  |  |  |  |
| 278 | 44.1 | **C SIM API** | 525d | 2000-09-25 A | 2002-09-27 | 80% | 106.64d | 2000-09-25 | 2002-09-27 | 525d | 415d |  | T3 | 9960.02h | 7936.88h | USAT1-API-MULTOS |  |  |  | Rel6 | TSG | Ter | 2031 |  |
| 279 | 44.1.1 | Specification | 525d | 2000-09-25 A | 2002-09-27 A | 100% |  | 2000-09-25 | 2002-09-27 | 525d |  | finish no earlier than 2002-09-27 | T3 | 4200h | 4200h |  |  | Neil Livingston – Aspects Software |  |  | TSG | Ter | 2032 |  |
| 280 | 44.1.2 | Test specification | 195d | 2001-01-01 A | 2001-09-28 | 25% | 146.25d | 2001-01-01 | 2001-09-28 | 195d | 675d | finish no earlier than 2001-09-28 | T3 | 1560h | 390h |  |  | Neil Livingston – Aspects Software |  |  | TSG | Ter | 2033 |  |
| 281 | 45 | ----- Rel-4 features listed below ----- | 1d | 2000-01-03 | 2000-01-03 |  |  | 2000-01-03 | 2000-01-03 | 1d | 1129d |  |  |  |  |  |  |  |  | Rel4 |  |  |  |  |
| 282 | 15 | **Miscelleneous UE Conformance Testing Activities** | 501d | 2001-04-02 A | 2003-03-03 | 52% | 242.76d | 2001-04-02 | 2003-03-03 | 501d | 304d |  | T1 | 19080h | 9834.7h | MISTST1 |  |  |  | NA |  |  | 1861 | Lidia |
| 283 | 15.1 | Optimisation of Test Time, RF Aspects (FDD) | 376d | 2001-09-24 A | 2003-03-03 | 70% | 112.8d | 2001-09-24 | 2003-03-03 | 376d | 304d | finish no earlier than 2003-03-03 | T1 | 3008h | 2105.6h | MISTST1-OpFDD | 34.121 |  |  | Rel Indep | TSG |  | 1862 |  |
| 284 | 15.2 | Optimisation of Test Time, RF Aspects (TDD) | 376d | 2001-09-24 A | 2003-03-03 | 70% | 112.8d | 2001-09-24 | 2003-03-03 | 376d | 304d | finish no earlier than 2003-03-03 | T1 | 3008h | 2105.6h | MISTST1-OpTDD | 34.122 |  |  | Rel Indep | TSG |  | 1863 |  |
| 285 | 15.3 | Extensions to R99 Test cases | 87.2w | 2001-04-02 A | 2002-12-02 | 60% | 34.88w | 2001-04-02 | 2002-12-02 | 87.2w | 369d | finish no earlier than 2002-12-02 | T1 | 3488h | 2092.8h | MISTST1-Ext | 34.123 pts 1,2 |  |  |  | TSG |  | 1907 |  |
| 286 | 15.4 | Extension to R99 Test cases - TTCN | 177d | 2002-06-28 A | 2003-03-03 | 30% | 123.9d | 2002-06-28 | 2003-03-03 | 177d | 304d | finish no earlier than 2003-03-03 | T1 | 1416h | 424.8h |  |  |  |  |  | TSG |  |  |  |
| 287 | 15.5 | Creation of R99 TCs for TDD - prose | 260d | 2001-10-01 A | 2002-09-27 | 50% | 130d | 2001-10-01 | 2002-09-27 | 260d | 415d | finish no earlier than 2002-09-27 | T1 | 2080h | 1040h | MISTST1-TDD | 34.123-1 |  |  |  | TSG |  |  |  |
| 288 | 15.6 | Creation of R99 TCs for TDD - TTCN | 130d | 2002-09-03 | 2003-03-03 |  |  | 2002-09-03 | 2003-03-03 | 130d | 304d | finish no earlier than 2003-03-03 | T1 | 1040h |  |  |  |  |  |  | TSG |  |  |  |
| 289 | 15.7 | Review all other work items for impact on new or exiting 34 series specs. | 25.8w | 2002-07-02 | 2002-12-27 |  |  | 2002-07-02 | 2002-12-27 | 25.8w | 350d | finish no earlier than 2002-12-27 | T1 | 1032h |  | MISTST1 | 34.121,122,123,125 |  |  |  |  |  | 1908 |  |

Notes:
- 267: created 25/11/02
- 268: created 25/11/02
- 269: created 15/01/03
- 270: Changed WID
- 272: Changed WID
- 273: Changed WID
- 274: Changed WID
- 275: Changed WID
- 279: 30/12/2000: completion amount updated
- 283: It is believed that the current R99 test spec. can be optimised for faster overall test times
- 284: It is believed that the current R99 test spec. can be optimised for faster overall test times
- 285: Further test coverage of the R99 specification to cover supplementry services
- 289: Can't start until most core specs are stable

| ID | WBS | Task | Duration | Start | Finish | Predecessors | Complete | Remaining | Baseline start | Baseline finish | Baseline duration | Total slack | Constraint | Resources | Work | Actual work | Text1 | Text6 | Text7 | Text8 | Text9 | Text2 | Text3 | Text4 | Text5 |
| --- | --- | --- | --- | --- | --- | --- | --- | --- | --- | --- | --- | --- | --- | --- | --- | --- | --- | --- | --- | --- | --- | --- | --- | --- | --- |
| 290 | 46 | **Facsimile** | 89d | 2000-02-22 A | 2000-06-23 A |  | 100% |  | 2000-02-22 | 2000-06-23 | 89d |  |  | S1 | 4376h | 4376h | FAX | Rel4 | TSG | Alain | 1340 |  |  |  |  |
| 291 | 46.1 | **Real Time Fax** | 89d | 2000-02-22 A | 2000-06-23 A |  | 100% |  | 2000-02-22 | 2000-06-23 | 89d |  |  | S2 | 3664h | 3664h | FAX-RT |  |  |  | 1341 | CCaR |  |  |  |
| 292 | 46.1.1 | Terminal capabilities, AT commands | 89d | 2000-02-22 A | 2000-06-23 A |  | 100% |  | 2000-02-22 | 2000-06-23 | 89d |  | finish no earlier than 2000-06-23 | T2 | 712h | 712h |  |  |  |  | 1808 | CCaR | 21.904, 27.007 |  |  |
| 293 | 46.1.2 | Signalling aspects (e.g. ICM) | 89d | 2000-02-22 A | 2000-06-23 A |  | 100% |  | 2000-02-22 | 2000-06-23 | 89d |  | start no earlier than 2000-02-22 | N1 | 712h | 712h |  |  |  |  | 1343 | CCaR |  |  |  |
| 294 | 46.1.3 | Service provision | 89d | 2000-02-22 A | 2000-06-23 A |  | 100% |  | 2000-02-22 | 2000-06-23 | 89d |  | finish no earlier than 2000-06-23 | N3 | 712h | 712h |  |  |  |  | 1648 | CCaR | 23.146 |  |  |
| 295 | 46.1.4 | Review whether service/stage 1 aspects need to be aligned | 51d | 2000-04-14 A | 2000-06-23 A |  | 100% |  | 2000-04-14 | 2000-06-23 | 51d |  | finish no earlier than 2000-12-14 | S1 | 408h | 408h |  |  |  |  | 1345 | CCaR |  |  |  |
| 296 | 46.1.5 | Review whether architecture/stage 2 aspects need to be aligned | 51d | 2000-04-14 A | 2000-06-23 A |  | 100% |  | 2000-04-14 | 2000-06-23 | 51d |  | finish no earlier than 2000-12-14 | S2 | 408h | 408h |  |  |  |  | 1346 | CCaR |  |  |  |
| 297 | 47 | Transparent End-to-End PS mobile streaming application | 253d | 2000-04-03 A | 2001-03-21 A |  | 100% |  | 2000-04-03 | 2001-03-21 | 253d |  | finish no earlier than 2000-12-29 | S4 | 2024h | 2024h | PSTREAM | Rel4 | TSG | Paolo | 1539 |  | 26.233, 26.234 |  |  |
| 298 | 48 | **Multimedia Messaging** | 277d | 2000-02-22 A | 2001-03-14 |  | 99% | 0d | 2000-02-22 | 2001-03-14 | 277d | 0d |  | T2 | 12208h | 10661.6h | MMS | Rel4 | TSG | Friedhelm | 1818 | Mes | 22.140, 23.140 | Josef Laumen, Siemens | Josef.Laumen@SAL.SIEMENS.DE |
| 299 | 48.1 | Definition of service requirements | 72d | 2000-02-22 A | 2000-05-31 A |  | 100% |  | 2000-02-22 | 2000-05-31 | 72d |  | start no earlier than 2000-02-22 | S1 | 576h | 576h | MMS |  |  |  | 136 | Mes |  |  |  |
| 300 | 48.2 | Review of definition of service requirements | 205d | 2000-06-01 A | 2001-03-14 A | 299 | 100% |  | 2000-06-01 | 2001-03-14 | 205d |  | finish no earlier than 2000-09-08 | T2 | 1640h | 1640h |  |  | TSG |  | 1819 | Mes | 22.140, 23.140 | Josef Laumen, Siemens |  |
| 301 | 48.3 | **Technical Realisation** | 243d | 2000-04-10 A | 2001-03-14 A |  | 100% |  | 2000-04-10 | 2001-03-14 | 243d |  |  | T2 | 7776h | 7776h |  |  | TSG |  | 1820 | Mes | 22.140, 23.140 | Josef Laumen, Siemens | Josef.Laumen@SAL.SIEMENS.DE |
| 302 | 48.3.1 | Review of definition of reference Achitecture model | 243d | 2000-04-10 A | 2001-03-14 A |  | 100% |  | 2000-04-10 | 2001-03-14 | 243d |  | finish no earlier than 2001-03-14 | T2 | 1944h | 1944h |  |  | TSG |  | 1821 | Mes | 22.140, 23.140 | Josef Laumen, Siemens | Josef.Laumen@SAL.SIEMENS.DE |
| 303 | 48.3.2 | "Fulfill Requirements of Stage 1" | 243d | 2000-04-10 A | 2001-03-14 A |  | 100% |  | 2000-04-10 | 2001-03-14 | 243d |  | finish no earlier than 2001-03-14 | T2 | 1944h | 1944h |  |  | TSG |  | 1822 | Mes | 22.140, 23.140 | Josef Laumen, Siemens | Josef.Laumen@SAL.SIEMENS.DE |
| 304 | 48.3.3 | Definition of MMS primitives in Stage 2 | 243d | 2000-04-10 A | 2001-03-14 A |  | 100% |  | 2000-04-10 | 2001-03-14 | 243d |  | finish no earlier than 2001-03-14 | T2 | 1944h | 1944h |  |  | TSG |  | 1823 | Mes | 22.140, 23.140 | Josef Laumen, Siemens | Josef.Laumen@SAL.SIEMENS.DE |
| 305 | 49 | **Transcoder-Free Operation** | 325d | 2000-01-03 A | 2001-03-30 |  | 99% | 0d | 2000-01-03 | 2001-03-30 | 325d | 0d |  | N4 | 13040h | 10440h | TrFO | Rel4 |  | Kimmo | 1541 | Cod |  |  |  |
| 306 | 49.1 | **OoBTC solution** | 325d | 2000-01-03 A | 2001-03-30 A |  | 100% |  | 2000-01-03 | 2001-03-30 | 325d |  |  | N4 | 8440h | 8440h | TRFO-OOBTC |  | WG |  | 112 | Cod |  | Tosshiyuki Tamura, NEC | tamurato@elsf.ncos.nec.co.jp |
| 307 | 49.1.1 | implementation in UTRAN | 145d | 2000-09-11 A | 2001-03-30 A |  | 100% |  | 2000-09-11 | 2001-03-30 | 145d |  | finish no earlier than 2001-03-30 | R3 | 1160h | 1160h | TRFO-OOBTC-UTRAN |  | TSG |  | 1512 |  | 25.401, 25.410, 25.413, 25.415, 23.153 | Alexander Vesely, Siemens | alexander.vesely@SIEMENS.AT |
| 308 | 49.1.2 | Impact on architecture, Principles and Terminology | 210d | 2000-01-03 A | 2000-10-20 A |  | 100% |  | 2000-01-03 | 2000-10-20 | 210d |  | finish no earlier than 2000-10-20 | S2 | 1680h | 1680h |  |  |  |  | 896 | Cod |  |  |  |
| 309 | 49.1.3 | Codec Negotiation between UE and MSC | 125d | 2000-08-14 A | 2001-02-02 A |  | 100% |  | 2000-08-14 | 2001-02-02 | 125d |  | finish no earlier than 2001-02-02 | N1 | 1000h | 1000h |  |  | TSG |  | 1657 | Cod | 24.008, 23.009, 23.108, (29.002) | Andrew Howell / Motorola |  |
| 310 | 49.1.4 | Codec Negotiation inter MSC | 125d | 2000-07-03 A | 2000-12-22 A |  | 100% |  | 2000-07-03 | 2000-12-22 | 125d |  | finish no earlier than 2000-12-22 | N4 | 1000h | 1000h |  |  |  |  | 115 | Cod |  |  |  |
| 311 | 49.1.5 | Bearer establishment inter MSC | 125d | 2000-07-03 A | 2000-12-22 A |  | 100% |  | 2000-07-03 | 2000-12-22 | 125d |  | finish no earlier than 2000-12-22 | N4 | 1000h | 1000h |  |  | TSG |  | 894 | Cod | 23.153 |  |  |
| 312 | 49.2 | **Speech Transcoder: Location and Control at the UMTS Core Network Border** | 125d | 2000-04-10 A | 2000-09-29 A |  | 100% |  | 2000-04-10 | 2000-09-29 | 125d |  |  | S2 | 2000h | 2000h | TRFO-STLC |  | WG |  | 905 | Cod |  |  |  |
| 313 | 49.2.1 | Transcoder at Edge | 125d | 2000-04-10 A | 2000-09-29 A |  | 100% |  | 2000-04-10 | 2000-09-29 | 125d |  | finish no earlier than 2000-09-29 | NP | 1000h | 1000h |  |  |  |  | 124 | Cod |  |  |  |

Notes:
- 291: postponed from R99 to R00, SP-000169
- 303: e.g. minimum set of media formats, media format conversion, personalization of MMS.
- 305: Lead given to CN4 from CN / [DAB 28/11/00]
- 307: moved according to NP-000575
- 308: e.g. study cascading TrFO/TFO/TrFO
- 309: the link to NP-000085has been deleted because refering to a R99 status sheet / One common set of codec negotiation procedures will be specified as in ID1656.
- 310: Bearer establishment inter MSC. TS 23.153 R99 part complete. capabilities moved to annex + list of open issues
- 311: Bearer establishment inter MSC. TS 23.153 R99 part complete. capabilities moved to annex. / See NP-000127 / Open issues: / Handling of Conference Calls; / Handling of Multi Party Supplementary Services; / Handling of Handover UMTS to GSM; / Handling of Sending a ...
- 312: WI description and Tdoc S2-99352 / Speech Transcoder: Location and Control at the UMTS Core Network Border
- 313: WI description and Tdoc S2-99352...

| ID | WBS | Task | Type | Duration | Start | Finish | Complete | Remaining | Baseline start | Baseline finish | Baseline duration | Total slack | Constraint | Resources | Work | Actual work | Text1 | Text6 | Text7 | Text8 | Text9 | Text4 | Text2 |
| --- | --- | --- | --- | --- | --- | --- | --- | --- | --- | --- | --- | --- | --- | --- | --- | --- | --- | --- | --- | --- | --- | --- | --- |
| 314 | 50 | **GERAN improvements 1 (Gb over IP)** |  | 225d | 2000-05-09 A | 2001-03-19 A | 100% |  | 2000-05-09 | 2001-03-19 | 225d |  |  | GP | 6472h | 6472h | GEIMP1 | Rel4 | TSG | Paolo | 2310 |  |  |
| 315 | 50.1 | **Gb over IP (Ip-fication of Gb)** |  | 225d | 2000-05-09 A | 2001-03-19 A | 100% |  | 2000-05-09 | 2001-03-19 | 225d |  |  | GP | 4672h | 4672h | GbIP |  | TSG | Paolo | 2311 |  |  |
| 316 | 50.1.1 | Concept |  | 134d | 2000-05-09 A | 2000-11-10 A | 100% |  | 2000-05-09 | 2000-11-10 | 134d |  |  | GP | 1072h | 1072h |  |  | TSG |  | 2312 |  |  |
| 317 | 50.1.2 | Changes to 08.16, 08.18 |  | 225d | 2000-05-09 A | 2001-03-19 A | 100% |  | 2000-05-09 | 2001-03-19 | 225d |  |  | GP | 1800h | 1800h |  |  | TSG |  | 2313 |  |  |
| 318 | 51 | **GERAN improvements 2 (NACC)** |  | 815d | 2000-11-06 A | 2003-12-19 | 80% | 159.32d | 2000-11-06 | 2002-06-28 | 430d | 95d |  | GP | 24616h | 13616h | GEIMP2 | Rel4 | TSG | Paolo | 2314 |  |  |
| 319 | 51.1 | **Gb enhancements** |  | 155d | 2000-11-06 A | 2001-06-08 A | 100% |  | 2000-11-06 | 2001-06-08 | 155d |  |  | GP | 7440h | 7440h | Gben |  | TSG | Paolo | 2315 |  |  |
| 320 | 51.1.1 | **Intra BSC NACC (Network Assisted Cell Change)** |  | 155d | 2000-11-06 A | 2001-06-08 A | 100% |  | 2000-11-06 | 2001-06-08 | 155d |  |  | GP | 6200h | 6200h |  |  | TSG |  | 2316 |  |  |
| 321 | 51.1.1.1 | Concept |  | 155d | 2000-11-06 A | 2001-06-08 A | 100% |  | 2000-11-06 | 2001-06-08 | 155d |  | finish no earlier than 2001-06-08 | GP | 1240h | 1240h |  |  | TSG |  | 2420 |  |  |
| 322 | 51.1.1.2 | Changes in 03.64 |  | 155d | 2000-11-06 A | 2001-06-08 A | 100% |  | 2000-11-06 | 2001-06-08 | 155d |  | finish no earlier than 2001-06-08 | GP | 1240h | 1240h |  |  | TSG |  | 2317 |  |  |
| 323 | 51.1.1.3 | Changes in 04.60 |  | 155d | 2000-11-06 A | 2001-06-08 A | 100% |  | 2000-11-06 | 2001-06-08 | 155d |  | finish no earlier than 2001-06-08 | GP | 1240h | 1240h |  |  | TSG |  | 2318 |  |  |
| 324 | 51.1.1.4 | Changes in 44.008 |  | 155d | 2000-11-06 A | 2001-06-08 A | 100% |  | 2000-11-06 | 2001-06-08 | 155d |  | finish no earlier than 2001-06-08 | GP | 1240h | 1240h |  |  | TSG |  | 2319 |  |  |
| 325 | 51.2 | Start Testing | milestone | 0d | 2001-06-04 | 2001-06-04 |  |  | 2001-06-04 | 2001-06-04 | 0d | 760d | start no earlier than 2001-06-04 |  |  |  |  |  |  |  |  |  |  |
| 326 | 51.3 | **MS conformance test for Intra BSC NACC** |  | 536d | 2001-11-30 A | 2003-12-19 | 50% | 268d | 2001-11-30 | 2002-06-28 | 151d | 95d |  | GP | 10656h | 5328h | GEIMP2-Msconf |  |  |  |  |  |  |
| 327 | 51.3.1 | Changes in 51.010 |  | 398d | 2001-11-30 A | 2003-12-19 | 50% | 199d | 2001-11-30 | 2002-06-28 | 151d | 95d | finish no earlier than 2003-12-19 | G5; G4 | 6368h | 3184h |  |  |  |  |  |  |  |
| 328 | 52 | **GERAN improvements 4 (Delayed TBF)** |  | 105d | 2001-01-15 A | 2001-06-08 A | 100% |  | 2001-01-15 | 2001-06-08 | 105d |  |  | GP | 3960h | 3960h | GEIMP4 | Rel4 | TSG | Paolo | 2324 |  |  |
| 329 | 52.1 | **Gb enhancements 2** |  | 105d | 2001-01-15 A | 2001-06-08 A | 100% |  | 2001-01-15 | 2001-06-08 | 105d |  |  | GP | 3120h | 3120h | GEIMP4-Gben2 |  | TSG |  | 2325 |  |  |
| 330 | 52.1.1 | stage 2 |  | 105d | 2001-01-15 A | 2001-06-08 A | 100% |  | 2001-01-15 | 2001-06-08 | 105d |  | finish no earlier than 2001-06-08 | GP | 840h | 840h |  |  |  |  | 2429 |  |  |
| 331 | 52.1.2 | **Stage 3 (changes in 44.060)** |  | 60d | 2001-01-15 A | 2001-04-06 A | 100% |  | 2001-01-15 | 2001-04-06 | 60d |  |  | G2 | 1440h | 1440h |  |  | TSG |  | 2421 |  |  |
| 332 | 52.1.2.1 | Definition of enhanced countdown procedure |  | 60d | 2001-01-15 A | 2001-04-06 A | 100% |  | 2001-01-15 | 2001-04-06 | 60d |  | finish no earlier than 2001-04-06 | G2 | 480h | 480h |  |  | TSG |  | 2327 |  |  |
| 333 | 52.1.2.2 | Definition of enhanced TBF release procedure |  | 60d | 2001-01-15 A | 2001-04-06 A | 100% |  | 2001-01-15 | 2001-04-06 | 60d |  | finish no earlier than 2001-04-06 | G2 | 480h | 480h |  |  | TSG |  | 2328 |  |  |
| 334 | 52.1.2.3 | Definition of USF=FREE type polling mechanism on PDCH |  | 60d | 2001-01-15 A | 2001-04-06 A | 100% |  | 2001-01-15 | 2001-04-06 | 60d |  | finish no earlier than 2001-04-06 | G2 | 480h | 480h |  |  | TSG |  | 2329 |  |  |
| 335 | 53 | **Low Chip Rate TDD option** |  | 832d | 2000-07-19 A | 2003-09-25 | 78% | 182d | 2000-07-19 | 2003-12-01 | 879d | 156d |  | R1 | 23504h | 18396.9h | LCRTDD | Rel4 | TSG | Tsukasa | 1222 | G. Yang, CWTS |  |
| 336 | 53.1 | Physical layer |  | 183d | 2000-07-19 A | 2001-03-30 A | 100% |  | 2000-07-19 | 2001-03-30 | 183d |  | finish no earlier than 2001-03-30 | R1 | 1464h | 1464h | LCRTDD-Phys |  | TSG |  | 1223 | G. Yang, CWTS |  |
| 337 | 53.2 | Layer 2 and layer 3 protocol aspects |  | 183d | 2000-07-19 A | 2001-03-30 A | 100% |  | 2000-07-19 | 2001-03-30 | 183d |  | finish no earlier than 2001-03-30 | R2 | 1464h | 1464h | LCRTDD-L23 |  | TSG |  | 1224 | Y. Liu, CWTS | BaAS |
| 338 | 53.3 | RF radio transmission/reception, system performance requirements and conformance testing |  | 165d | 2000-08-14 A | 2001-03-30 A | 100% |  | 2000-08-14 | 2001-03-30 | 165d |  | finish no earlier than 2001-03-30 | R4 | 1320h | 1320h | LCRTDD-RF |  | TSG |  | 1225 | D. Zhang, CWTS | BaAS |
| 339 | 53.4 | UE radio access capability |  | 165d | 2000-08-14 A | 2001-03-30 A | 100% |  | 2000-08-14 | 2001-03-30 | 165d |  | finish no earlier than 2001-03-30 | R2 | 1320h | 1320h | LCRTDD-UErac |  | TSG |  | 1227 | Y. Liu, CWTS | BaAS |
| 340 | 53.5 | Iub/Iur protocol aspects |  | 165d | 2000-08-14 A | 2001-03-30 A | 100% |  | 2000-08-14 | 2001-03-30 | 165d |  | finish no earlier than 2001-03-30 | R3 | 1320h | 1320h | LCRTDD-IubIur |  | TSG |  | 1228 | Y. Liu, CWTS | BaAS |

Notes:
- 326: Started

| ID | WBS | Task | Type | Duration | Start | Finish | Predecessors | Complete | Remaining | Baseline start | Baseline finish | Baseline duration | Total slack | Free slack | Constraint | Resources | Work | Actual work | Text8 | Text9 | Text3 | Text7 | Text1 | Text4 | Text6 | Text2 | Text5 |
| --- | --- | --- | --- | --- | --- | --- | --- | --- | --- | --- | --- | --- | --- | --- | --- | --- | --- | --- | --- | --- | --- | --- | --- | --- | --- | --- | --- |
| 341 | 53.6 | **Low chiprate TDD interworking with GERAN** |  | 101d | 2000-09-01 A | 2001-01-19 A | 340 | 100% |  | 2000-09-01 | 2001-01-19 | 101d |  |  |  |  |  |  | Paolo | 2262 |  |  |  |  |  |  |  |
| 342 | 53.6.1 | Handover and Cell Selection / Reselection to UTRA 1.28 Mcps TDD |  | 101d | 2000-09-01 A | 2001-01-19 A |  | 100% |  | 2000-09-01 | 2001-01-19 | 101d |  |  | finish no earlier than 2001-01-19 |  |  |  |  | 2263 |  |  |  |  |  |  |  |
| 343 | 53.7 | Start Testing | milestone | 0d | 2001-09-03 | 2001-09-03 | 341 |  |  | 2001-09-03 | 2001-09-03 | 0d | 427.62d | 10d | start no earlier than 2001-09-03 | MLST |  |  |  | 1911 |  |  |  |  |  |  |  |
| 344 | 53.8 | **Conformance Test Aspects - Low Chip Rate TDD** |  | 529d | 2001-09-17 A | 2003-09-25 | 343 | 49% | 267.38d | 2001-09-17 | 2003-12-01 | 576d | 156d |  |  | T1 | 10104h | 4996.94h |  | 2103 | 0% |  |  |  |  |  |  |
| 345 | 53.8.1 | Testing Layer 2 and layer 3 protocol aspects |  | 316d | 2001-09-17 A | 2002-12-02 |  | 50% | 158d | 2001-09-17 | 2002-12-02 | 316d | 369d |  | finish no earlier than 2002-12-02 | T1 | 2528h | 1264h |  | 2217 | 34.123-1, 34.123-2 | TSG |  |  |  |  |  |
| 346 | 53.8.2 | Testing Layer 2 and layer 3 protocol aspects - TTCN |  | 213d | 2002-12-03 | 2003-09-25 |  |  |  | 2002-12-03 | 2003-12-01 | 260d | 156d |  | finish no earlier than 2003-09-25 | T1 | 1704h |  |  |  | 34.123-3 | TSG |  |  |  |  |  |
| 347 | 53.8.3 | Testing RF Radio Transmission and Reception |  | 205d | 2001-09-17 A | 2002-06-28 A |  | 100% |  | 2001-09-17 | 2002-06-28 | 205d |  |  | finish no earlier than 2002-06-28 | T1 | 1640h | 1640h |  | 2218 |  | TSG |  |  |  |  |  |
| 348 | 54 | **Enable bearer independent CS architecture** |  | 565d | 2000-01-03 A | 2002-03-01 |  | 80% | 114.5d | 2000-01-03 | 2002-03-01 | 565d | 565d |  |  | S2 | 20176h | 13788h | Kimmo |  |  | TSG | CSSPLIT | Alexander Milinski, Siemens | Rel4 |  |  |
| 349 | 54.1 | **Enable bearer-independent call control** |  | 424d | 2000-01-03 A | 2001-08-16 |  | 99% | 0d | 2000-01-03 | 2001-08-16 | 424d | 0d |  |  | N4 | 12336h | 8944h |  | 1323 |  | WG |  | Heinz-Peter Keutman, Ericsson |  | CCaR | Heinz-Peter.Keutmann@eed.ericsson.se |
| 350 | 54.1.1 | Architecture and Stage 2 description |  | 180d | 2000-01-03 A | 2000-09-08 A |  | 100% |  | 2000-01-03 | 2000-09-08 | 180d |  |  | finish no earlier than 2000-09-08 | S2 | 1440h | 1440h |  | 1516 | 23.002 |  |  |  |  | CCaR |  |
| 351 | 54.1.2 | Standardisation of protocols (control & user planes) over Nb interface |  | 64d | 2001-01-02 A | 2001-03-30 A |  | 100% |  | 2001-01-02 | 2001-03-30 | 64d |  |  | finish no earlier than 2001-03-30 | N3 | 512h | 512h |  | 1325 |  | TSG |  |  |  | CCaR |  |
| 352 | 54.1.3 | Standardisation of protocols over reference points between MSC server and Gateway MSC server |  | 130d | 2000-09-25 A | 2001-03-23 A |  | 100% |  | 2000-09-25 | 2001-03-23 | 130d |  |  | finish no earlier than 2001-03-23 | N4 | 1040h | 1040h |  | 1326 |  | TSG |  |  |  | CCaR |  |
| 353 | 54.1.4 | Standardisation of detailed stage 2 description |  | 180d | 2000-07-17 A | 2001-03-23 A |  | 100% |  | 2000-07-17 | 2001-03-23 | 180d |  |  | finish no earlier than 2001-03-23 | N4 | 1440h | 1440h |  | 1616 |  | TSG |  |  |  |  |  |
| 354 | 54.1.5 | **Bearer control between MSC server and MGW** |  | 250d | 2000-09-01 A | 2001-08-16 A |  | 100% |  | 2000-09-01 | 2001-08-16 | 250d |  |  |  | N4 | 4512h | 4512h |  | 1327 |  | TSG |  |  |  | CCaR |  |
| 355 | 54.1.5.1 | stage 3 - protocol issues |  | 250d | 2000-09-01 A | 2001-08-16 A |  | 100% |  | 2000-09-01 | 2001-08-16 | 250d |  |  | finish no earlier than 2001-08-16 | N4 | 2000h | 2000h |  | 1328 |  | TSG |  |  |  | CCaR |  |
| 356 | 54.1.5.2 | stage 3 - parameter value issues |  | 64d | 2001-01-02 A | 2001-03-30 A |  | 100% |  | 2001-01-02 | 2001-03-30 | 64d |  |  | finish no earlier than 2001-03-30 | N3 | 512h | 512h |  | 1329 |  |  |  |  |  | CCaR |  |
| 357 | 54.2 | Lawful interception |  | 155d | 2000-08-21 A | 2001-03-23 A |  | 100% |  | 2000-08-21 | 2001-03-23 | 155d |  |  | finish no earlier than 2001-03-23 | S3 | 1240h | 1240h |  | 1331 |  |  |  |  |  | CCaR |  |
| 358 | 54.3 | Start Testing | milestone | 0d | 2001-03-05 | 2001-03-05 |  |  |  | 2001-03-05 | 2001-03-05 | 0d | 565d | 0d | start no earlier than 2001-03-05 | MLST |  |  |  | 1918 |  |  |  |  |  |  |  |
| 359 | 54.4 | Conformance Test Aspects - Enable bearer independent CS architecture |  | 260d | 2001-03-05 | 2002-03-01 | 358 |  |  | 2001-03-05 | 2002-03-01 | 260d | 565d |  |  | T1 | 2080h |  |  |  | 0% |  | CSSPLIT-TEST |  |  |  |  |
| 360 | 55 | **MExE enhancements Rel-4** |  | 802d | 2000-01-03 A | 2003-01-28 |  | 88% | 96.68d | 2000-01-03 | 2002-05-28 | 627d | 328d |  |  | T2 | 22768h | 20426.6h | Friedhelm | 1445 |  | TSG | MEXE |  | Rel4 | Ter |  |
| 361 | 55.1 | **MExE Security Analysis Activity** |  | 474d | 2000-02-22 A | 2001-12-14 A |  | 100% |  | 2000-02-22 | 2001-12-14 | 474d |  |  |  | S3 | 8464h | 8464h |  | 1447 |  | TSG | MEXE-SEC | Colin Blanchard, BT |  | Ter | colin.blanchard@bt.com |
| 362 | 55.1.1 | Stage 3 |  | 370d | 2000-07-17 A | 2001-12-14 A |  | 100% |  | 2000-07-17 | 2001-12-14 | 370d |  |  | finish no earlier than 2001-12-14 | S3 | 2960h | 2960h |  | 2045 |  |  | MEXE1-SEC |  |  | Ter |  |
| 363 | 55.1.2 | Terminal aspects |  | 214d | 2000-02-22 A | 2000-12-15 A |  | 100% |  | 2000-02-22 | 2000-12-15 | 214d |  |  | finish no earlier than 2000-12-15 | T2 | 1712h | 1712h |  | 1448 |  |  |  |  |  | Ter |  |
| 364 | 55.2 | **MExE Rel4 Improvements and Investigations** |  | 250d | 2000-01-03 A | 2000-12-15 |  | 99% | 0d | 2000-01-03 | 2000-12-15 | 250d | 0d |  |  | T2 | 6480h | 6320h |  | 1810 | 22.057, 23.057 | TSG | MEXE-ENHANC | Mark CATALDO, Motorola |  | Ter | mcatald1@MOTOROLA.COM |
| 365 | 55.2.1 | 3rd MExE classmark |  | 250d | 2000-01-03 A | 2000-12-15 A |  | 100% |  | 2000-01-03 | 2000-12-15 | 250d |  |  | finish no earlier than 2000-12-15 | T2 | 2000h | 2000h |  | 1812 | 22.057, 23.057 | TSG |  | Mark CATALDO, Motorola |  | Ter | mcatald1@MOTOROLA.COM |
| 366 | 55.2.2 | FS on Secure download mechanism and capabilities to support SDR concepts |  | 225d | 2000-02-07 A | 2000-12-15 A |  | 100% |  | 2000-02-07 | 2000-12-15 | 225d |  |  | finish no earlier than 2000-12-15 | T2 | 1800h | 1800h |  | 1814 | 22.057, 23.057 | TSG |  | Mark CATALDO, Motorola |  | Ter | mcatald1@MOTOROLA.COM |
| 367 | 55.2.3 | FS on Support of MP3/MPEG4 content |  | 225d | 2000-02-07 A | 2000-12-15 A |  | 100% |  | 2000-02-07 | 2000-12-15 | 225d |  |  | finish no earlier than 2000-12-15 | T2 | 1800h | 1800h |  | 1815 | 22.057, 23.057 | TSG |  | Mark CATALDO, Motorola |  | Ter | mcatald1@MOTOROLA.COM |
| 368 | 55.3 | Conformance testing of MExE capability (Feasibility study) |  | 176d | 2002-05-28 | 2003-01-28 |  |  |  | 2002-05-28 | 2002-05-28 | 1d | 328d |  | finish no earlier than 2003-01-28 | T1 | 1408h |  |  |  |  | TSG |  |  | Rel4 |  |  |

Notes:
- 345: duration set to 6 months (was 0)
- 347: duration set to 6 months (was 0), finish date set
- 349: DAB 12.12.01 should be 100% hence closed
- 350: R00 stage 2 at least 80 % complete in TSGS #8 21.-23.6.2000
- 357: Requirements capture: S3#14 (Aug 00), Feature specification: S3#15 (Sep 00), Definition of architecture. Should be included in general LI work mentioned above.
- 361: Presentation to S3 of threats and countermeasures analysis: S3#15, Feature specification: S3#16. S3#18: WID updated
- 362: Analysis undertaken by T2. No additional analysis needed for Rel-4
- 365: Additional features for MExE R2000

| ID | WBS | Task | Duration | Start | Finish | Complete | Remaining | Baseline start | Baseline finish | Baseline duration | Total slack | Constraint | Resources | Work | Actual work | Text1 | Text2 | Text6 | Text8 | Text9 | Text3 | Text5 | Text7 |
| --- | --- | --- | --- | --- | --- | --- | --- | --- | --- | --- | --- | --- | --- | --- | --- | --- | --- | --- | --- | --- | --- | --- | --- |
| 369 | 56 | **Tandem Free aspects for 3G and between 2G and 3G systems** | 344d | 2000-02-22 A | 2001-06-15 A | 100% |  | 2000-02-22 | 2001-06-15 | 344d |  |  | S4 | 9696h | 9696h | TFO | Cod | Rel4 | Paolo | 1631 |  |  |  |
| 370 | 56.1 | **Tandem Free AMR** | 344d | 2000-02-22 A | 2001-06-15 A | 100% |  | 2000-02-22 | 2001-06-15 | 344d |  |  | S4 | 6944h | 6944h | TFO-AMR | Cod |  |  | 1632 |  |  |  |
| 371 | 56.1.1 | Specification | 284d | 2000-02-22 A | 2001-03-23 A | 100% |  | 2000-02-22 | 2001-03-23 | 284d |  | start no earlier than 2000-02-22 | S4 | 2272h | 2272h |  | Cod |  |  | 130 | 28.062 |  |  |
| 372 | 56.1.2 | **Impact on:** | 115d | 2001-01-08 A | 2001-06-15 A | 100% |  | 2001-01-08 | 2001-06-15 | 115d |  |  | NP | 1920h | 1920h |  | Cod |  |  | 907 |  |  |  |
| 373 | 56.1.2.1 | CN | 60d | 2001-03-26 A | 2001-06-15 A | 100% |  | 2001-03-26 | 2001-06-15 | 60d |  | finish no earlier than 2001-06-15 | NP | 480h | 480h |  | Cod |  |  | 131 |  |  |  |
| 374 | 56.1.2.2 | GERAN | 65d | 2001-01-08 A | 2001-04-06 A | 100% |  | 2001-01-08 | 2001-04-06 | 65d |  | finish no earlier than 2001-04-06 | GP | 520h | 520h |  | Cod |  |  | 132 |  |  |  |
| 375 | 57 | **Advanced Speech Call Items enhancements_REL-4** | 334d | 2000-12-03 A | 2002-03-14 A | 100% |  | 2000-12-03 | 2002-03-14 | 334d |  |  | N1 | 5925.6h | 5925.6h | ASCI |  | Rel4 | Per | 2230 |  | sonia.garapaty@nortelnetworks.com | TSG |
| 376 | 57.1 | Stage 2 | 326.7d | 2000-12-03 A | 2002-03-14 A | 100% |  | 2000-12-03 | 2002-03-14 | 326.7d |  | finish no earlier than 2002-03-14 | N4 | 2613.6h | 2613.6h |  |  |  | Kimmo | 2232 | 23.067, 24.067 |  | WG |
| 377 | 57.2 | Stages 2 and 3 on A interface | 80d | 2000-12-03 A | 2001-03-23 A | 100% |  | 2000-12-03 | 2001-03-23 | 80d |  | finish no earlier than 2001-03-23 | N1 | 640h | 640h |  |  |  | Per | 2231 | 44.068, 44.069, 24.008 | sonia.garapaty@nortelnetworks.com | WG |
| 378 | 58 | **700 MHz spectrum support** | 775d | 2000-01-03 A | 2002-12-20 | 99% | 0d | 2000-01-03 | 2002-06-28 | 650d | 0d |  | GP | 25000h | 18800h | 700SS |  | Rel4 | Paolo | 2403 |  |  |  |
| 379 | 58.1 | **GERAN support for the 700 MHz band** | 275d | 2000-01-03 A | 2001-01-19 A | 100% |  | 2000-01-03 | 2001-01-19 | 275d |  |  | GP | 8800h | 8800h |  |  |  |  | 2404 |  |  |  |
| 380 | 58.1.1 | Signalling support | 275d | 2000-01-03 A | 2001-01-19 A | 100% |  | 2000-01-03 | 2001-01-19 | 275d |  | finish no earlier than 2001-01-19 | GP | 2200h | 2200h |  |  |  |  | 2405 |  |  |  |
| 381 | 58.1.2 | Physical layer definitions | 275d | 2000-01-03 A | 2001-01-19 A | 100% |  | 2000-01-03 | 2001-01-19 | 275d |  | finish no earlier than 2001-01-19 | GP | 2200h | 2200h |  |  |  |  | 2406 |  |  |  |
| 382 | 58.1.3 | Receiver performance and RF budget | 275d | 2000-01-03 A | 2001-01-19 A | 100% |  | 2000-01-03 | 2001-01-19 | 275d |  | finish no earlier than 2001-01-19 | GP | 2200h | 2200h |  |  |  |  | 2407 |  |  |  |
| 383 | 58.2 | **GERAN MS Conformance test for 700 MHz band** | 175d | 2001-04-02 A | 2001-11-30 A | 100% |  | 2001-04-02 | 2001-11-30 | 175d |  |  | GP | 2800h | 2800h |  |  |  |  | 2408 |  |  |  |
| 384 | 58.2.1 | MS test | 175d | 2001-04-02 A | 2001-11-30 A | 100% |  | 2001-04-02 | 2001-11-30 | 175d |  | finish no earlier than 2001-11-30 | GP | 1400h | 1400h |  |  |  |  | 2409 |  |  |  |
| 385 | 58.3 | **GERAN BTS Conformance test for 700 MHz band** | 450d | 2001-04-02 A | 2002-12-20 A | 100% |  | 2001-04-02 | 2002-06-28 | 325d |  |  | GP | 7200h | 7200h |  |  |  | Paolo | 2410 |  |  |  |
| 386 | 58.3.1 | BTS test | 450d | 2001-04-02 A | 2002-12-20 A | 100% |  | 2001-04-02 | 2002-06-28 | 325d |  | finish no earlier than 2002-12-20 | GP | 3600h | 3600h |  |  |  |  | 2411 |  |  |  |
| 387 | 59 | Operator Determined Barring for Packet Oriented Services | 208d | 2000-06-01 A | 2001-03-19 A | 100% |  | 2000-06-01 | 2001-03-19 | 208d |  | finish no earlier than 2001-03-19 | NP | 1664h | 1664h | ODB |  | Rel4 |  | 2463 |  | tamurato@nsf.ncos.nec.co.jp | TSG |
| 388 | 60 | **UMTS QoS Architecture for PS Domain** | 758d | 2000-01-03 A | 2002-11-27 | 61% | 295.18d | 2000-01-03 | 2002-11-27 | 758d | 372d |  | S2 | 54256h | 20605.3h | QoSPS |  | Rel4 |  |  |  | Ina.widegren@era.ericsson.se | TSG |
| 389 | 60.1 | Architecture | 153d | 2000-06-05 A | 2001-01-03 A | 100% |  | 2000-06-05 | 2001-01-03 | 153d |  | finish no earlier than 2001-01-03 | S2 | 1224h | 1224h |  |  |  |  |  | 23.107 |  | TSG |
| 390 | 60.2 | Charging and OAM&P for QoS Management | 201d | 2001-09-21 A | 2002-06-28 A | 100% |  | 2001-09-21 | 2002-06-28 | 201d |  | finish no earlier than 2002-06-28 | S5 | 1608h | 1608h | QoSPS-OAM |  |  |  |  | 32-series | Albert.Yuhan@voicestream.com; Michael.Truss@MOTOROLA.COM | TSG |
| 391 | 60.3 | **RAB Quality of Service (re)Negotiation over Iu** | 155d | 2000-08-21 A | 2001-03-23 | 99% | 0d | 2000-08-21 | 2001-03-23 | 155d | 0d |  | R3 | 3648h | 2501.6h | QoSPS-MAPEND-RABQoS |  |  |  | 1681 | 25.413 |  | TSG |
| 392 | 60.3.1 | RAB Quality of Service Negotiation over Iu | 155d | 2000-08-21 A | 2001-03-23 A | 100% |  | 2000-08-21 | 2001-03-23 | 155d |  | finish no earlier than 2001-03-23 | R3 | 1240h | 1240h | QoSPS-MAPEND-RABQoS-Negot |  |  |  | 1991 |  |  | TSG |
| 393 | 60.3.2 | RAB Quality of Service Negotiation over Iu during relocation | 16d | 2001-03-02 A | 2001-03-23 A | 100% |  | 2001-03-02 | 2001-03-23 | 16d |  | start no earlier than 2001-03-02 | R3 | 128h | 128h | QoSPS-MAPEND-RABQoS-NegotReloc |  |  |  | 2456 |  |  | TSG |
| 394 | 60.3.3 | RAB Quality of Service Re-Negotiation over Iu | 130d | 2000-09-25 A | 2001-03-23 A | 100% |  | 2000-09-25 | 2001-03-23 | 130d |  | finish no earlier than 2001-03-23 | R3 | 1040h | 1040h | QoSPS-MAPEND-RABQoS-ReNegot |  |  |  | 1992 |  |  | TSG |

Notes:
- 369: RAN and CN to verify no problems for GSM terminals roaming in 3G R99
- 370: RAN and CN to verify UMTS_AMR_2 support
- 372: "Implementation" changed to "Impact on:" by A. Sultan (for better wording)
- 373: RAN and CN to verify UMTS_AMR_2 support
- 374: End date Modified from June to March to have it in Rel4
- 375: Approved in TSGN_10 / Text4: Sonia Garapaty
- 376: CN4#11 30/11/02: no inputs received in CN4 / Text4: Vivien Perlic, Sagem
- 377: Text4: Sonia Garapaty
- 387: Completed WI missing from the P-plan Added for tracking / Text4: oshiyuki Tamura
- 388: Text4: Ina Widegren, Ericsson
- 390: Text4: Albert YUHAN (VoiceStream Wireless), Michael TRUSS (Motorola)
- 391: Text4: A. Molander, Ericsson
- 392: Text4: A. Molander, Ericsson
- 394: Text4: S. Irwin, Motorola

| ID | WBS | Task | Duration | Start | Finish | Complete | Remaining | Baseline start | Baseline finish | Baseline duration | Total slack | Constraint | Resources | Work | Actual work | Text1 | Text2 | Text7 | Text8 | Text9 | Text4 | Text3 | Text6 |
| --- | --- | --- | --- | --- | --- | --- | --- | --- | --- | --- | --- | --- | --- | --- | --- | --- | --- | --- | --- | --- | --- | --- | --- |
| 395 | 60.4 | **GERAN QoS Aspects - Handovers: maintenance of real-time QoS while moving between cells in the PLMN including inter-SGSN and SRNS relocation or possibly other mechanisms** | 500d | 2000-01-03 A | 2001-11-30 | 99% | 0d | 2000-01-03 | 2001-11-30 | 500d | 0d |  | GP | 14440h | 10544h | GERQoS | QoS | TSG | Paolo | 1553 |  |  |  |
| 396 | 60.4.1 | **Handover Concept for the PS domain** | 500d | 2000-01-03 A | 2001-11-30 | 99% | 0d | 2000-01-03 | 2001-11-30 | 500d | 0d |  | GP | 10440h | 6544h |  |  | TSG |  | 2306 |  |  |  |
| 397 | 60.4.1.1 | Stable RT handover report 25.936 including header removal | 13d | 2000-01-03 A | 2000-01-19 A | 100% |  | 2000-01-03 | 2000-01-19 | 13d |  | start no earlier than 2000-01-03 | GP | 104h | 104h |  |  | TSG |  | 2309 |  |  |  |
| 398 | 60.4.1.2 | Update of stage 2 | 292d | 2000-01-03 A | 2001-02-13 A | 100% |  | 2000-01-03 | 2001-02-13 | 292d |  | finish no earlier than 2001-02-13 | GP | 2336h | 2336h |  |  | TSG |  | 2307 |  |  |  |
| 399 | 60.4.1.3 | Update of relevant stage 3 specs -> RRC | 500d | 2000-01-03 A | 2001-11-30 A | 100% |  | 2000-01-03 | 2001-11-30 | 500d |  | finish no earlier than 2001-11-30 | G2 | 4000h | 4000h |  |  | TSG |  | 2308 |  |  |  |
| 400 | 60.5 | **GERAN MS Conformance test for inter-system and intra-system Packet data real-time Handover** | 324d | 2001-08-31 | 2002-11-27 |  |  | 2001-08-31 | 2002-11-27 | 324d | 372d |  | G4; R3 | 25920h |  | GERQoS-Mstest |  | TSG |  |  |  |  |  |
| 401 | 60.5.1 | **Handover for the PS domain** | 324d | 2001-08-31 | 2002-11-27 |  |  | 2001-08-31 | 2002-11-27 | 324d | 372d |  | G4; R3 | 20736h |  |  |  | TSG |  |  |  |  |  |
| 402 | 60.5.1.1 | Stable RT handover report 25.936 including header removal | 324d | 2001-08-31 | 2002-11-27 |  |  | 2001-08-31 | 2002-11-27 | 324d | 372d | finish no earlier than 2002-11-27 | G4; R3 | 5184h |  |  |  | TSG |  |  |  |  |  |
| 403 | 60.5.1.2 | Update of stage 2 | 324d | 2001-08-31 | 2002-11-27 |  |  | 2001-08-31 | 2002-11-27 | 324d | 372d | finish no earlier than 2002-11-27 | G4; R3 | 5184h |  |  |  | TSG |  |  |  |  |  |
| 404 | 60.5.1.3 | Update of relevant stage 3 specs | 324d | 2001-08-31 | 2002-11-27 |  |  | 2001-08-31 | 2002-11-27 | 324d | 372d | finish no earlier than 2002-11-27 | G4; R3 | 5184h |  |  |  | TSG |  |  |  |  |  |
| 405 | 60.6 | PS-domain handover for real-time services | 155d | 2000-08-28 A | 2001-03-30 A | 100% |  | 2000-08-28 | 2001-03-30 | 155d |  | finish no earlier than 2001-03-30 | R3 | 1240h | 1240h | QoSPS-PSdoRTS | QoS | TSG |  | 1685 | A. Lansisalmi, Nokia |  |  |
| 406 | 60.7 | RAB QoS Renegotiation at Relocation | 58d | 2001-01-03 | 2001-03-23 |  |  | 2001-01-03 | 2001-03-23 | 58d | 810d | finish no earlier than 2001-03-23 | R3 | 464h |  |  |  | TSG |  |  |  | 25.851, 25.946 |  |
| 407 | 61 | small Technical Enhancements and Improvements for Rel4 | 325d | 2000-01-03 A | 2001-03-30 A | 100% |  | 2000-01-03 | 2001-03-30 | 325d |  |  | Generic | 2600h | 2600h | TEI4 |  | TSG |  | 1993 |  |  | Rel4 |
| 408 | 62 | **Rel-4 Evolutions of the transport in the UTRAN** | 525d | 2000-08-21 A | 2002-08-23 | 69% | 162.5d | 2000-08-21 | 2002-08-23 | 525d | 440d |  | RP | 8600h | 6501.38h | ETRAN |  | TSG | Joern |  | Francois Courau |  | NA |
| 409 | 62.1 | QoS optimisation for AAL2 connections over Iub and Iur interfaces | 160d | 2000-08-21 A | 2001-03-30 A | 100% |  | 2000-08-21 | 2001-03-30 | 160d |  | finish no earlier than 2001-03-30 | R3 | 1280h | 1280h | ETRAN-QoSAAL2 | BaAS | TSG |  | 12 | T. Yoshimura, Japan Telecom |  | Rel4 |
| 410 | 62.2 | Transport bearer modification procedure on Iub, Iur, and Iu | 130d | 2000-10-02 A | 2001-03-30 A | 100% |  | 2000-10-02 | 2001-03-30 | 130d |  | finish no earlier than 2001-03-30 | R3 | 1040h | 1040h | ETRAN-MigrMod |  | TSG |  | 1995 | T. Yoshimura, Japan Telecom |  | Rel4 |
| 411 | 62.3 | **Conformance Test Aspects of Rel-4 evolutions of the transport in UTRAN** | 130d | 2002-02-25 | 2002-08-23 |  |  | 2002-02-25 | 2002-08-23 | 130d | 440d |  | T1 | 2080h |  |  |  |  |  | 1834 |  |  |  |
| 412 | 62.3.1 | Testing RAB support enhancements | 130d | 2002-02-25 | 2002-08-23 |  |  | 2002-02-25 | 2002-08-23 | 130d | 440d | finish no earlier than 2002-08-23 | T1 | 1040h |  | CT-RABS? |  |  |  | 2208 |  | 34.108, 34. 121, 34.122, 34.123 pts 1,2, 34.123 pt 3 |  |
| 413 | 63 | **Rel-4 Evolutions of the transport in the CN** | 215d | 2000-05-29 A | 2001-03-23 A | 100% |  | 2000-05-29 | 2001-03-23 | 215d |  |  | N4 | 7968h | 7968h | CNTRSP | BaAS |  | Kimmo |  |  |  | NA |
| 414 | 63.1 | **IP Transport of CN protocols (e.g., CAP, MAP)** | 77d | 2000-12-07 A | 2001-03-23 A | 100% |  | 2000-12-07 | 2001-03-23 | 77d |  |  | N4 | 2808h | 2808h | SS7IP | BaAS |  |  | 859 |  |  | Rel4 |
| 415 | 63.1.1 | **Stage 3** | 77d | 2000-12-07 A | 2001-03-23 A | 100% |  | 2000-12-07 | 2001-03-23 | 77d |  |  | N4 | 2192h | 2192h |  |  |  |  | 1679 |  |  |  |
| 416 | 63.1.1.1 | CAP | 77d | 2000-12-07 A | 2001-03-23 A | 100% |  | 2000-12-07 | 2001-03-23 | 77d |  | finish no earlier than 2001-03-23 | N2 | 616h | 616h |  |  | WG |  | 2018 |  |  |  |
| 417 | 63.1.1.2 | MAP | 77d | 2000-12-07 A | 2001-03-23 A | 100% |  | 2000-12-07 | 2001-03-23 | 77d |  | finish no earlier than 2001-03-23 | N4 | 616h | 616h |  |  |  |  | 2019 |  |  |  |
| 418 | 63.1.1.3 | BSSAP+ | 43d | 2001-01-15 A | 2001-03-14 A | 100% |  | 2001-01-15 | 2001-03-14 | 43d |  | finish no earlier than 2001-03-14 | N1 | 344h | 344h | SS7IP-BSSAP+ | Loc | WG |  | 2253 |  |  |  |

Notes:
- 400: Still exist? To be clarified by GERAN4/5
- 407: "Joker" WI, to be used for a Rel 4 CR not related to any feature and with very limited impact on the system
- 412: Requires supporting companies
- 413: WI formulation assigned to N4
- 414: AS: corrected to Rel4 as stated at SA#10

| ID | WBS | Task | Type | Duration | Start | Finish | Predecessors | Complete | Remaining | Baseline start | Baseline finish | Baseline duration | Total slack | Free slack | Constraint | Resources | Work | Actual work | Text2 | Text4 | Text5 | Text6 | Text7 | Text9 | Text1 | Text8 | Text3 |
| --- | --- | --- | --- | --- | --- | --- | --- | --- | --- | --- | --- | --- | --- | --- | --- | --- | --- | --- | --- | --- | --- | --- | --- | --- | --- | --- | --- |
| 419 | 63.2 | **FS on Transport and control separation in the PS CN domain** |  | 215d | 2000-05-29 A | 2001-03-23 A |  | 100% |  | 2000-05-29 | 2001-03-23 | 215d |  |  |  | S2 | 3440h | 3440h | BaAS | Juan-Antonio Ibanez, Ericsson Deutschland | Juan-Antonio.Ibanez@eed.ericsson.se | Rel4 | TSG | 1513 |  |  |  |
| 420 | 63.2.1 | Architectural impacts |  | 215d | 2000-05-29 A | 2001-03-23 A |  | 100% |  | 2000-05-29 | 2001-03-23 | 215d |  |  | finish no earlier than 2001-03-23 | S2 | 1720h | 1720h | BaAS |  |  |  | WG | 1615 |  |  |  |
| 421 | 64 | **Rel-4 Improvements of Radio Interface** |  | 700d | 2000-07-10 A | 2003-03-14 |  | 83% | 117.46d | 2000-07-10 | 2003-03-14 | 700d | 295d |  |  | RP | 28624h | 23247.4h |  |  |  | NA | TSG |  | RInImp | Tsukasa |  |
| 422 | 64.1 | UTRA repeater specification (master) |  | 183d | 2000-07-10 A | 2001-03-21 A |  | 100% |  | 2000-07-10 | 2001-03-21 | 183d |  |  | finish no earlier than 2001-03-21 | R4 | 1464h | 1464h |  | T. Kummetz, Mikom; Alf Ahlström, Allgon |  | Rel4 | TSG | 1509 | RInImp-REP |  |  |
| 423 | 64.2 | DSCH power control improvement in soft handover |  | 140d | 2000-09-11 A | 2001-03-23 A |  | 100% |  | 2000-09-11 | 2001-03-23 | 140d |  |  | finish no earlier than 2001-03-23 | R1 | 1120h | 1120h |  | A. Toskala, Nokia |  | Rel4 | TSG | 1994 | RInImp-DSCHsho |  |  |
| 424 | 64.3 | UMTS 1800 |  | 320d | 2000-09-25 A | 2001-12-14 A |  | 100% |  | 2000-09-25 | 2001-12-14 | 320d |  |  | finish no earlier than 2001-12-14 | R4 | 2560h | 2560h |  | H. Benn, Motorola |  | Rel indep | TSG | 1996 | RInImp-UMTS18 |  |  |
| 425 | 64.4 | UMTS 1900 |  | 195d | 2001-03-19 A | 2001-12-14 A |  | 100% |  | 2001-03-19 | 2001-12-14 | 195d |  |  | finish no earlier than 2001-12-14 | R4 | 1560h | 1560h |  | Howard Benn, Motorola |  | Rel indep | TSG | 2467 | RInImp-UMTS19 | Cesar |  |
| 426 | 64.5 | FS on High Speed downlink packet access |  | 155d | 2000-08-21 A | 2001-03-23 A |  | 100% |  | 2000-08-21 | 2001-03-23 | 155d |  |  | finish no earlier than 2001-03-23 | R2 | 1240h | 1240h |  | A. Ghosh, Motorola |  |  | TSG | 1219 | RInImp-HSDPA |  |  |
| 427 | 64.6 | FS on improved common DL channel for Cell-FACH state |  | 340d | 2000-09-11 A | 2001-12-28 A |  | 100% |  | 2000-09-11 | 2001-12-28 | 340d |  |  | finish no earlier than 2001-12-28 | R2 | 2720h | 2720h |  | J. Kwak, GBT |  |  | TSG | 1510 | RInImp-DLCFACH |  |  |
| 428 | 64.7 | **Conformance Test Spec. Rel-4 improvements in Radio Interface** |  | 375d | 2001-10-08 A | 2003-03-14 |  | 64% | 134.62d | 2001-10-08 | 2003-03-14 | 375d | 295d |  |  | T1 | 12360h | 7923.08h |  |  |  |  |  |  |  |  |  |
| 429 | 64.7.1 | Testing Improved usage of downlink resource in FDD for CCTrCHs of dedicated type |  | 140d | 2002-02-18 | 2002-08-30 |  |  |  | 2002-02-18 | 2002-08-30 | 140d | 435d |  | finish no earlier than 2002-08-30 | T1 | 1120h |  |  |  |  |  |  | 2212 |  |  |  |
| 430 | 64.7.2 | Testing Terminal Power saving features |  | 140d | 2002-02-18 | 2002-08-30 |  |  |  | 2002-02-18 | 2002-08-30 | 140d | 435d |  | finish no earlier than 2002-08-30 | T1 | 1120h |  |  |  |  |  |  | 2213 |  |  |  |
| 431 | 64.7.3 | Testing DSCH power control improvement in soft handover |  | 140d | 2002-02-18 | 2002-08-30 |  |  |  | 2002-02-18 | 2002-08-30 | 140d | 435d |  | finish no earlier than 2002-08-30 | T1 | 1120h |  |  |  |  | Rel4 |  | 2214 |  |  |  |
| 432 | 64.7.4 | Testing UMTS 1800 |  | 180d | 2001-10-08 A | 2002-06-14 A |  | 100% |  | 2001-10-08 | 2002-06-14 | 180d |  |  | finish no earlier than 2002-06-14 | T1 | 1440h | 1440h |  |  |  | Rel indep | TSG | 2215 |  |  | 34.108, 34,121, 34.122, 34.123-1 |
| 433 | 64.7.5 | Testing UMTS 1900 |  | 180d | 2001-10-08 A | 2002-06-14 A |  | 100% |  | 2001-10-08 | 2002-06-14 | 180d |  |  | finish no earlier than 2002-06-14 | T1 | 1440h | 1440h |  |  |  | Rel indep | TSG | 2215 |  |  | 34.108, 34,121, 34.122, 34.123-1 |
| 434 | 64.7.6 | Testing UMTS 1800 - TTCN |  | 195d | 2002-06-17 A | 2003-03-14 A |  | 100% |  | 2002-06-17 | 2003-03-14 | 195d |  |  | finish no earlier than 2003-03-14 | T1 | 1560h | 1560h |  |  |  | Rel indep | TSG |  |  |  | 34.123-3 |
| 435 | 64.7.7 | Testing UMTS 1900 - TTCN |  | 195d | 2002-06-17 A | 2003-03-14 A |  | 100% |  | 2002-06-17 | 2003-03-14 | 195d |  |  | finish no earlier than 2003-03-14 | T1 | 1560h | 1560h |  |  |  | Rel indep | TSG |  |  |  | 34.123-3 |
| 436 | 65 | **Rel-4 RAN improvements** |  | 817d | 2000-08-14 A | 2003-09-30 |  | 23% | 632.57d | 2000-08-14 | 2003-03-03 | 666d | 153d |  |  | RP | 22304h | 4293.53h |  |  |  | NA | TSG |  | RANimp | Cesar |  |
| 437 | 65.1 | Node B synchronisation for TDD |  | 160d | 2000-08-14 A | 2001-03-23 A |  | 100% |  | 2000-08-14 | 2001-03-23 | 160d |  |  | finish no earlier than 2001-03-23 | R1 | 1280h | 1280h | BaAS | S. Oestreich, Siemens |  | Rel4 | TSG | 655 | RANimp-NBsync |  |  |
| 438 | 65.2 | RAB support enhancement for Rel-4 |  | 155d | 2000-08-21 A | 2001-03-23 A |  | 100% |  | 2000-08-21 | 2001-03-23 | 155d |  |  | finish no earlier than 2001-03-23 | R2 | 1240h | 1240h |  | M. Israelsson, A. Krishnarajah, Ericsson |  | Rel4 | TSG | 2206 | RANimp-RABSE |  |  |
| 439 | 65.3 | Start Testing | milestone | 0d | 2001-12-03 | 2001-12-03 |  |  |  | 2001-12-03 | 2001-12-03 | 0d | 207d | 21d | start no earlier than 2001-12-03 | MLST |  |  |  |  |  |  |  | 1912 |  |  |  |
| 440 | 65.4 | **Conformance Test Aspects - Rel-4 RAN Improvements** |  | 456d | 2002-01-01 A | 2003-09-30 | 439 | 2% | 445.74d | 2002-01-01 | 2003-03-03 | 305d | 153d |  |  | T1 | 13248h | 298.08h |  |  |  |  |  | 2102 |  |  | 0% |
| 441 | 65.4.1 | Testing Radio access bearer support enhancments |  | 175d | 2002-01-01 | 2002-09-02 |  |  |  | 2002-01-01 | 2002-09-02 | 175d | 434d |  | finish no earlier than 2002-09-02 | T1 | 1400h |  |  |  |  |  |  | 2222 |  |  |  |
| 442 | 65.4.2 | Testing RAB support enhancements-Robust Header Compression |  | 200d | 2002-05-28 | 2003-03-03 |  |  |  | 2002-05-28 | 2003-03-03 | 200d | 304d |  | finish no earlier than 2003-03-03 | T1 | 1600h |  |  |  |  | Rel4 | TSG | 2461 | RABimp-RoCH |  | 34.123-1, -2 |
| 443 | 65.4.3 | Testing RAB support enhancements-Robust Header Compression - TTCN |  | 285d | 2002-05-28 | 2003-06-30 |  |  |  |  |  |  | 219d |  | finish no earlier than 2003-06-30 | T1 | 2280h |  |  |  |  | Rel4 | TSG |  |  |  | 34.123-3 |
| 444 | 65.4.4 | Testing of Extended Robut Header Compression |  | 270d | 2002-09-18 A | 2003-09-30 |  | 10% | 243d |  |  |  | 153d |  | finish no earlier than 2003-09-30 | T1 | 2160h | 216h |  |  |  | Rel4 | TSG |  | Ext-RoHC |  | 34.123-1, -2 |
| 445 | 65.4.5 | Testing of Extended Robut Header Compression - TTCN |  | 270d | 2002-09-18 | 2003-09-30 |  |  |  |  |  |  | 153d |  | finish no earlier than 2003-09-30 | T1 | 2160h |  |  |  |  | Rel4 | TSG |  |  |  | 34.123-3 |

Notes:
- 419: Rel4 added
- 427: Stopped at RAN#14
- 429: start/finish dates set / Not started yet due to lack of supporting companies
- 430: start/finish dates set / Not started yet due to lack of supporting companies
- 431: start/finish dates set / Not started yet due to lack of supporting companies
- 432: finish date set
- 433: finish date set
- 434: finish date set
- 435: finish date set
- 438: 29 Nov 2000: split into ROHC and non-ROHC part; 5 Mar 2001: splitting off of ROHC for Rel-4 agreed by R2
- 439: UID changed
- 441: duration set to 6 months (was 0) / Task not started due to lack of supporting companies
- 442: UID changed
- 443: UID changed

| ID | WBS | Task | Duration | Start | Finish | Complete | Remaining | Baseline start | Baseline finish | Baseline duration | Total slack | Constraint | Resources | Work | Actual work | Text1 | Text2 | Text4 | Text5 | Text6 | Text7 | Text8 | Text9 | Text3 |
| --- | --- | --- | --- | --- | --- | --- | --- | --- | --- | --- | --- | --- | --- | --- | --- | --- | --- | --- | --- | --- | --- | --- | --- | --- |
| 446 | 66 | **Rel-4 Emergency call enhancements** | 627d | 2000-01-03 A | 2002-05-28 | 64% | 227.72d | 2000-01-03 | 2002-05-28 | 627d | 503d |  | N1 | 7936h | 5161.18h | EMC1 | CCaR | Mr Rouzbeh, Ericsson | EUSFARO@am1.ericsson.se | NA | WG | Per | 1652 |  |
| 447 | 66.1 | **For CS based calls** | 627d | 2000-01-03 A | 2002-05-28 | 64% | 227.72d | 2000-01-03 | 2002-05-28 | 627d | 503d |  | N1 | 3600h | 2400h | EMC1-CS | CCaR | Mr Rouzbeh, Ericsson | EUSFARO@am1.ericsson.se | Rel4 | TSG |  | 1654 |  |
| 448 | 66.1.1 | Distinction in CS domain of emergency call types to different emergency services | 40d | 2000-05-01 A | 2000-06-23 A | 100% |  | 2000-05-01 | 2000-06-23 | 40d |  | finish no earlier than 2000-06-23 | S1 | 320h | 320h |  | CCaR |  |  |  |  |  | 1320 |  |
| 449 | 66.1.2 | Distinction in CS domain of emergency calls to different emergency types | 22d | 2000-08-28 A | 2000-09-26 A | 100% |  | 2000-08-28 | 2000-09-26 | 22d |  | finish no earlier than 2000-09-22 | N1 | 176h | 176h |  |  |  |  |  |  |  | 1999 |  |
| 450 | 66.1.3 | Conformance Test Aspects - Emergency call enhancements | 150d | 2000-01-03 | 2000-07-28 |  |  | 2000-01-03 | 2000-07-28 | 150d | 980d |  | T1 | 1200h |  |  |  |  |  |  |  |  | 2224 |  |
| 451 | 66.1.4 | Testing CS based emergency calls | 67d | 2002-02-25 A | 2002-05-28 A | 100% |  | 2002-02-25 | 2002-05-28 | 67d |  | finish no earlier than 2002-05-28 | T1 | 536h | 536h |  |  |  |  |  | TSG |  | 2226 | 34.123-1 |
| 452 | 66.1.5 | Testing CS based emergency calls - TTCN | 134d | 2001-11-22 A | 2002-05-28 A | 100% |  | 2001-11-22 | 2002-05-28 | 134d |  | finish no earlier than 2002-05-28 | T1 | 1072h | 1072h |  |  |  |  |  | TSG |  |  | 34.123-3 |
| 453 | 67 | **Rel-4 Terminal interfaces** | 314d | 2000-01-03 A | 2001-03-15 | 99% | 0d | 2000-01-03 | 2001-03-15 | 314d | 0d |  | T2 | 15651.6h | 10635.6h | TI | Ter |  |  | NA |  | Friedhelm | 1826 |  |
| 454 | 67.1 | **AT commands enhancements** | 313d | 2000-01-03 A | 2001-03-14 A | 100% |  | 2000-01-03 | 2001-03-14 | 313d |  |  | T2 | 5008h | 5008h | TI-ATC | Ter |  |  | Rel4 |  |  | 1827 | 27.007 |
| 455 | 67.1.1 | Specification of AT commands for new services | 313d | 2000-01-03 A | 2001-03-14 A | 100% |  | 2000-01-03 | 2001-03-14 | 313d |  | finish no earlier than 2001-03-14 | T2 | 2504h | 2504h |  | Ter |  |  |  |  |  | 1828 | 27.007 |
| 456 | 67.2 | **Wide Area Data Synchronisation** | 313d | 2000-01-03 A | 2001-03-14 | 99% | 0d | 2000-01-03 | 2001-03-14 | 313d | 0d |  | T2 | 5655.2h | 3151.2h | TI-WADS | Ter |  |  | NA |  |  | 1829 |  |
| 457 | 67.2.1 | Continues evolution of Synchronisation protocol | 313d | 2000-01-03 A | 2001-03-14 A | 100% |  | 2000-01-03 | 2001-03-14 | 313d |  | finish no earlier than 2001-03-14 | T2 | 2504h | 2504h | TI-SYNC-EVOL | Ter |  |  | Rel4 |  |  | 1830 | 27.903, 27.103 |
| 458 | 67.3 | Terminal local model | 218d | 2000-05-16 A | 2001-03-15 A | 100% |  | 2000-05-16 | 2001-03-15 | 218d |  | finish no earlier than 2001-03-15 | T2 | 1744h | 1744h | TLM | Ter | Olga Tomé, Ericsson | Olga.Tome@ECS.ERICSSON.SE | Rel4 | TSG |  | 1832 | 23.227 |
| 459 | 68 | **Rel-4 Location Services enhancements** | 455d | 2000-04-03 A | 2001-12-28 | 99% | 0d | 2000-04-03 | 2001-12-28 | 455d | 0d |  | S2 | 28240.8h | 21192.8h | LCS1 |  | Jan Kall, Nokia |  | NA | TSG | Alain | 1536 |  |
| 460 | 68.1 | CBS interactions | 455d | 2000-04-03 A | 2001-12-28 A | 100% |  | 2000-04-03 | 2001-12-28 | 455d |  | finish no earlier than 2001-12-28 | T2 | 3640h | 3640h | LCS1-CBS | Loc |  |  | Rel4 |  |  | 2229 | 23.041 |
| 461 | 68.2 | LCS support in the CS domain | 180d | 2000-05-15 A | 2001-01-19 A | 100% |  | 2000-05-15 | 2001-01-19 | 180d |  | finish no earlier than 2001-01-19 | S2 | 1440h | 1440h | LCS1-CS | Loc |  |  | Rel4 |  |  | 523 |  |
| 462 | 68.3 | **LCS support in the PS domain** | 435d | 2000-05-01 A | 2001-12-28 | 99% | 0d | 2000-05-01 | 2001-12-28 | 435d | 0d |  | S2 | 14164.8h | 10684.8h | LCS1-PS |  |  |  | Rel4 |  |  | 525 |  |
| 463 | 68.3.1 | Stage 1 | 40d | 2000-07-03 A | 2000-08-25 A | 100% |  | 2000-07-03 | 2000-08-25 | 40d |  | start no earlier than 2000-07-03 | S1 | 320h | 320h |  | Loc | Randolph Wohlert, Pacific Bell Wireless | rwohlert@tri.sbc.com |  |  |  | 1642 | 22.071 |
| 464 | 68.3.2 | Stage 2 | 190d | 2000-05-01 A | 2001-01-19 A | 100% |  | 2000-05-01 | 2001-01-19 | 190d |  | finish no earlier than 2001-01-19 | S2 | 1520h | 1520h |  |  |  |  |  |  |  | 1181 | 23.271 |
| 465 | 68.3.3 | **Stage 3** | 355d | 2000-08-21 A | 2001-12-28 A | 100% |  | 2000-08-21 | 2001-12-28 | 355d |  |  | N1 | 8240h | 8240h |  | Loc |  |  |  |  |  | 1180 |  |
| 466 | 68.3.3.1 | Layer 3 LCS signaling UE (MS) -SGSN (UMTS PS and and GSM-GPRS) | 355d | 2000-08-21 A | 2001-12-28 A | 100% |  | 2000-08-21 | 2001-12-28 | 355d |  | finish no earlier than 2001-12-28 | N1 | 2840h | 2840h |  | Loc | Janne Muhonen / Nokia |  |  |  |  | 526 |  |
| 467 | 68.3.3.2 | MAP impacts of LCS | 160d | 2000-08-21 A | 2001-03-30 A | 100% |  | 2000-08-21 | 2001-03-30 | 160d |  | finish no earlier than 2001-03-30 | N4 | 1280h | 1280h |  | Loc |  |  |  |  |  | 2462 |  |
| 468 | 68.3.3.3 | GTP signaling for LCS | 160d | 2000-08-21 A | 2001-03-30 A | 100% |  | 2000-08-21 | 2001-03-30 | 160d |  | finish no earlier than 2001-03-30 | N4 | 1280h | 1280h |  | Loc |  |  |  |  |  | 527 |  |
| 469 | 68.4 | **UE positioning Rel-4** | 260d | 2000-04-03 A | 2001-03-30 A | 100% |  | 2000-04-03 | 2001-03-30 | 260d |  |  | RP | 4591.2h | 4591.2h | LCS1-UEpos |  |  |  | NA | TSG |  | 1600 |  |
| 470 | 68.4.1 | Iub/Iur interfaces for methods Rel 99 | 233.9d | 2000-04-03 A | 2001-03-30 A | 100% |  | 2000-04-03 | 2001-03-30 | 233.9d |  | finish no earlier than 2001-03-30 | R3 | 1871.2h | 1871.2h | LCS1-UEpos-IubIur |  | Yun-Chao Hu, Ericsson |  | Rel4 | TSG |  | 1601 |  |
| 471 | 68.4.2 | UE positioning enhancements - IPDL for TDD | 150d | 2000-08-28 A | 2001-03-23 A | 100% |  | 2000-08-28 | 2001-03-23 | 150d |  | finish no earlier than 2001-03-23 | R2 | 1200h | 1200h | LCS1-UEpos-enh |  | M. Beckmann, Siemens |  | Rel4 | TSG |  | 1602 |  |

Notes:
- 447: WI approved in TSG_10 / CN1#15: ID 2101 REMOVE-Emergency call recalling capability enhancement, no contributions
- 449: Calls to different emergency services such as ambulance, fire brigade, police, etc. can be routed to respective different emergency centres. / NP-000447 is the stage 3 changes for CS call control protocol.
- 450: UID changed
- 455: goal not completely achieved because of missing input
- 456: AS: Rel5 changed to Rel4 according to SA#10 decision, milestone on testing added
- 461: Only MAP impact foreseen so far. To be further split if needed.
- 463: To be also considered: External LCS client identity, and Privacy options when PDP-context and when no PDP-context is established
- 464: AS: 23.271 completed at SA#10
- 467: Missing work task
- 469: UID changed
- 470: 27/11: WG corrected; rapporteur corrected
- 471: 5 Mar 2001: splitting off of IPDL for TDD for Rel-4 agreed by R2

| ID | WBS | Task | Duration | Start | Finish | Complete | Remaining | Baseline start | Baseline finish | Baseline duration | Total slack | Constraint | Resources | Work | Actual work | Text1 | Text2 | Text6 | Text8 | Text9 | Text3 | Text7 | Text5 |
| --- | --- | --- | --- | --- | --- | --- | --- | --- | --- | --- | --- | --- | --- | --- | --- | --- | --- | --- | --- | --- | --- | --- | --- |
| 472 | 69 | **Rel-4 UICC/(U)SIM enhancements and interworking** | 175d | 2000-07-24 A | 2001-03-23 A | 100% |  | 2000-07-24 | 2001-03-23 | 175d |  |  | T3 | 2800h | 2800h | UICC1 | Ter | NA | Claus | 1560 |  |  |  |
| 473 | 69.1 | Common PCN Handset Specification (CPHS) | 175d | 2000-07-24 A | 2001-03-23 A | 100% |  | 2000-07-24 | 2001-03-23 | 175d |  | finish no earlier than 2001-03-23 | T3 | 1400h | 1400h | UICC1-CPHS | Ter | Rel4 |  | 1799 | 27.103 | TSG |  |
| 474 | 70 | **Rel-4 (U)SIM toolkit enhancements** | 210d | 2000-06-05 A | 2001-03-23 A | 100% |  | 2000-06-05 | 2001-03-23 | 210d |  |  | T3 | 3360h | 3360h | USAT1 | Ter | NA | Claus | 1800 |  |  |  |
| 475 | 70.1 | USAT local link | 210d | 2000-06-05 A | 2001-03-23 A | 100% |  | 2000-06-05 | 2001-03-23 | 210d |  | finish no earlier than 2001-03-23 | T3 | 1680h | 1680h | USAT1-LocLnk |  | Rel4 |  | 2034 |  | TSG |  |
| 476 | 71 | **Rel-4 Security enhancements** | 575d | 2000-01-03 A | 2002-03-15 | 87% | 74.38d | 2000-01-03 | 2002-03-15 | 575d | 555d |  | S3 | 24144h | 20865.5h | SEC1 |  | NA | Maurice |  |  | TSG | Peter.Howard@vodafone.com |
| 477 | 71.1 | Evolution of GSM CS algorithms (e.g. A5/3 development and deployment) | 271d | 2000-01-03 A | 2001-01-15 A | 100% |  | 2000-01-03 | 2001-01-15 | 271d |  | finish no earlier than 2001-01-15 | S3 | 2168h | 2168h | SEC1-CSALGO1 | Sec | Rel4 |  | 1587 |  | TSG |  |
| 478 | 71.2 | **Evolution of GSM PS algorithms (e.g. GEA 2 deployment)** | 219d | 2000-02-22 A | 2000-12-22 A | 100% |  | 2000-02-22 | 2000-12-22 | 219d |  |  | S3 | 6024h | 6024h | SEC1-PSALGO1 | Sec | Rel4 |  | 1588 |  | TSG |  |
| 479 | 71.2.1 | Main aspects | 199d | 2000-02-22 A | 2000-11-24 A | 100% |  | 2000-02-22 | 2000-11-24 | 199d |  | finish no earlier than 2000-11-24 | S3 | 1592h | 1592h |  | Sec |  |  | 1589 |  |  |  |
| 480 | 71.2.2 | Impact on GTP | 200d | 2000-03-20 A | 2000-12-22 A | 100% |  | 2000-03-20 | 2000-12-22 | 200d |  | finish no earlier than 2000-12-22 | N4 | 1600h | 1600h |  |  |  |  | 1618 |  | WG |  |
| 481 | 71.2.3 | GEA capability indication in MS CM | 135d | 2000-06-19 A | 2000-12-22 A | 100% |  | 2000-06-19 | 2000-12-22 | 135d |  | finish no earlier than 2000-12-22 | N1 | 1080h | 1080h | SEC1-PSALGO1-GEACAP | Sec |  |  | 1661 |  |  |  |
| 482 | 71.3 | **MAP application layer security** | 575d | 2000-01-03 A | 2002-03-15 | 76% | 135.92d | 2000-01-03 | 2002-03-15 | 575d | 555d |  | S3 | 11352h | 8668.59h | SEC1-MAPAL | Sec | Rel4 |  |  |  | TSG |  |
| 483 | 71.3.1 | Main aspects | 199d | 2000-02-21 A | 2001-03-29 A | 100% |  | 2000-02-21 | 2001-03-29 | 199d |  | start no earlier than 2000-02-21 | S3 | 1592h | 1592h |  | Sec |  |  | 1584 |  | WG |  |
| 484 | 71.3.2 | Other stage 3 aspects | 199d | 2000-02-22 A | 2000-11-24 A | 100% |  | 2000-02-22 | 2000-11-24 | 199d |  | finish no earlier than 2000-11-24 | N4 | 1592h | 1592h |  | Sec |  |  | 2025 |  | TSG |  |
| 485 | 71.3.3 | CHECK STATUS - Visibility and Configurability of security | 575d | 2000-01-03 A | 2002-03-15 | 60% | 230d | 2000-01-03 | 2002-03-15 | 575d | 555d | finish no earlier than 2002-03-15 | S3 | 4600h | 2760h | SEC1-VCS | Sec | Rel5 |  | 1594 |  | TSG | Sebastien.nguyenngoc@rd.francetelecom.com |
| 486 | 72 | **Rel-4 Charging and OAM&P** | 221d | 2000-12-01 A | 2001-10-05 A | 100% |  | 2000-12-01 | 2001-10-05 | 221d |  |  | S5 | 10472h | 10472h | OAM |  | NA | Adrian |  | 32-series | TSG | Albert.Yuhan@voicestream.com; Michael.Truss@MOTOROLA.COM |
| 487 | 72.1 | Rel4 Principles, high level Requirements and Architecture | 145d | 2000-12-01 A | 2001-06-21 A | 100% |  | 2000-12-01 | 2001-06-21 | 145d |  | finish no earlier than 2001-06-21 | S5 | 1160h | 1160h | OAM-AR/PR | BCaM | Rel4 |  | 2089 | 32.101, 32.102 | TSG | Michael.Truss@MOTOROLA.COM; Tommy.R.Berggren@TELIA.SE |
| 488 | 72.2 | Rel4 Performance Management | 216d | 2000-12-01 A | 2001-09-28 A | 100% |  | 2000-12-01 | 2001-09-28 | 216d |  | finish no earlier than 2001-06-21 | S5 | 1728h | 1728h |  | BCaM | Rel4 |  | 2088 | 32.4xy, 52.402 | TSG | karl-heinz.nenner@t-mobile.de |
| 489 | 72.3 | Fault Management | 221d | 2000-12-01 A | 2001-10-05 A | 100% |  | 2000-12-01 | 2001-10-05 | 221d |  | finish no earlier than 2001-06-21 | S5 | 1768h | 1768h |  | BCaM | Rel4 |  | 2081 | 32.111-1/4 | TSG | pjure@LUCENT.COM |
| 490 | 72.4 | Configuration Management | 145d | 2000-12-01 A | 2001-06-21 A | 100% |  | 2000-12-01 | 2001-06-21 | 145d |  | finish no earlier than 2001-06-21 | S5 | 1160h | 1160h | OAM-CM | BCaM | Rel4 |  | 2082 | 32.106-1/8 | TSG | Thomas.Tovinger@emw.ericsson.se |
| 491 | 72.5 | Rel4 Charging Management | 216d | 2000-12-01 A | 2001-09-28 A | 100% |  | 2000-12-01 | 2001-09-28 | 216d |  | finish no earlier than 2001-06-21 | S5 | 1728h | 1728h | OAM-CH | BCaM | Rel4 |  | 2083 | 32.2xy (Charging) | TSG | karl-heinz.nenner@t-mobile.de |
| 492 | 72.6 | UTRAN Operations and Maintenance procedures | 145d | 2000-12-01 A | 2001-06-21 A | 100% |  | 2000-12-01 | 2001-06-21 | 145d |  | finish no earlier than 2001-06-21 | S5 | 1160h | 1160h | UOAM |  | Rel4 | Adrian | 2071 | 32.800 | TSG | bert.boden@d2mannesmann.de |
| 493 | 73 | **Global Text Telephony** | 567d | 2000-06-28 A | 2002-08-29 | 82% | 101.67d | 2000-06-28 | 2002-08-29 | 567d | 436d |  | S2 | 9984h | 8388.85h | GTT |  | Rel Indep | Alain |  |  | TSG | gunnar.hellstrom@omnitor.se |
| 494 | 73.1 | Stage 1 | 188d | 2000-06-28 A | 2001-03-16 A | 100% |  | 2000-06-28 | 2001-03-16 | 188d |  | finish no earlier than 2000-12-22 | S1 | 1504h | 1504h |  |  |  |  | 1634 | 22.976, 22.226 | TSG |  |
| 495 | 73.2 | Stage 2 | 205d | 2000-09-11 A | 2001-06-22 A | 100% |  | 2000-09-11 | 2001-06-22 | 205d |  |  | S2 | 1640h | 1640h |  |  |  |  |  | 23.226 | TSG |  |

Notes:
- 473: 28/5/2001: CRs approved at TP-11. WI complete. / Text4: ?, One2One
- 475: 25/5/2001:CR was approved at TP-11. WI is complete / Text4: Jean-Francois Rubon (Gemplus)
- 476: Added BB UE authentication and rapporteur added. TO BE DELETED / Text4: Peter Howard, Vodafone
- 477: Algorithm development go-ahead at SA3#21. Scheduled for completion in August 2002?. Approved SA#17. DELETE ENTRY FROM REL-4?
- 478: A5/3 development will consider new GEA algorithm based on Kasumi.
- 479: Complete TSG#09 (09/2000). S3#17: Proposed for deletion. TO BE DELETED
- 481: Text4: Duncan Mills / Vodafone Airtouch
- 482: TO DELETE: REPLACED BY NDS-MAP and NDS-IP. TO BE DELETED, but replacement NDS-MAP was missing. Completed Auto Key Management -> Rel-6
- 483: UID changed
- 484: UID changed
- 485: CR approved at SA3#21 awaiting comments from CN1. / Text4: Sébastien Nguyen Ngoc, France Telecom
- 486: az: WID appr.SA#13. / Text4: Albert YUHAN (VoiceStream Wireless), Michael TRUSS (Motorola)
- 487: Text4: Michael TRUSS (Motorola), Tommy BERGGREN (Telia AB)
- 488: Changed Rapp email / Text4: Karl-Heinz NENNER (T-Mobile)
- 489: Text4: Patrick JURÉ (Lucent Technologies)
- 490: Text4: Thomas TOVINGER (Ericsson)
- 491: Changed Rapp email / Text4: Karl-Heinz NENNER (T-Mobile)
- 492: Text4: Bert Boden (Mannesmann Mobilfunk)
- 493: SP-000162 agreed WI. Rapporteur / Gunnar Hellström, Ericsson Radio Systems AB, / email: gunnar.hellstrom@omnitor.se tel: +46 708 204 288 / Text4: Gunnar Hellström, Ericsson

| ID | WBS | Task | Type | Duration | Start | Finish | Predecessors | Complete | Remaining | Baseline start | Baseline finish | Baseline duration | Total slack | Free slack | Constraint | Resources | Work | Actual work | Text1 | Text9 | Text3 | Text4 | Text6 | Text7 | Text8 | Text2 |
| --- | --- | --- | --- | --- | --- | --- | --- | --- | --- | --- | --- | --- | --- | --- | --- | --- | --- | --- | --- | --- | --- | --- | --- | --- | --- | --- |
| 496 | 73.3 | **Specification of Cellular Text telephone Modem** |  | 136d | 2000-09-11 A | 2001-03-19 A |  | 100% |  | 2000-09-11 | 2001-03-19 | 136d |  |  |  | S4 | 2704h | 2704h | GTT-CTM | 2234 |  |  |  |  |  |  |
| 497 | 73.3.1 | General description and C-code |  | 66d | 2000-09-11 A | 2000-12-11 A |  | 100% |  | 2000-09-11 | 2000-12-11 | 66d |  |  | finish no earlier than 2000-12-11 | S4 | 528h | 528h |  | 2238 | 26.226, 26.230 |  |  |  |  |  |
| 498 | 73.3.2 | Minimum Performance requirements |  | 136d | 2000-09-11 A | 2001-03-19 A |  | 100% |  | 2000-09-11 | 2001-03-19 | 136d |  |  | finish no earlier than 2001-03-19 | S4 | 1088h | 1088h |  | 2237 | 26.231 |  |  |  |  |  |
| 499 | 73.4 | Start Testing | milestone | 0d | 2002-02-18 | 2002-02-18 |  |  |  | 2002-02-18 | 2002-02-18 | 0d | 445d | 9d | start no earlier than 2002-02-18 | MLST |  |  |  |  |  |  |  |  |  |  |
| 500 | 73.5 | Conformance Test Aspects - Global Text telephony |  | 130d | 2002-03-01 | 2002-08-29 | 499 |  |  | 2002-03-01 | 2002-08-29 | 130d | 436d |  | finish no earlier than 2002-08-29 | T1 | 1040h |  |  |  | 34.125 |  |  |  |  |  |
| 501 | 75 | Enhanced Tandem Free Operation |  | 160d | 2002-11-11 | 2003-06-20 |  |  |  |  |  |  | 225d |  | finish no earlier than 2003-06-20 | S4 | 1280h |  | eTFO |  |  | Andrew Harrison, Nortel Networks | Rel6 | WG | Paolo |  |
| 502 | 76 | Packet Switched Streaming Services Rel-6 |  | 160d | 2002-11-11 | 2003-06-20 |  |  |  |  |  |  | 225d |  | finish no earlier than 2003-06-20 | S4 | 1280h |  | PSSrel6 |  |  | Olle Franceschi (Ericsson) | Rel6 | WG | Paolo |  |
| 503 | 77 | AMR-WB extension for high audio quality |  | 160d | 2002-11-11 | 2003-06-20 |  |  |  |  |  |  | 225d |  | finish no earlier than 2003-06-20 | S4 | 1280h |  | AMRWB+ |  |  | Janne Vainio (Nokia) | Rel6 | WG | Paolo |  |
| 504 | 74 | ----- Rel-5 features listed below ----- |  | 1d | 2000-01-03 | 2000-01-03 |  |  |  | 2000-01-03 | 2000-01-03 | 1d | 1129d |  |  |  |  |  |  |  |  |  | Rel5 |  |  |  |
| 505 | 75 | IP transport in the UTRAN |  | 445d | 2000-07-17 A | 2002-03-29 A |  | 100% |  | 2000-07-17 | 2002-03-29 | 445d |  |  | finish no earlier than 2002-03-29 | R3 | 3560h | 3560h | ETRAN-IPtrans | 625 |  | Nicolas Drevon, Alcatel | Rel5 | TSG |  | BaAS |
| 506 | 76 | FS on Usage of SUA |  | 205d | 2001-03-12 A | 2001-12-21 A |  | 100% |  | 2001-03-12 | 2001-12-21 | 205d |  |  | finish no earlier than 2001-12-21 | N4 | 1640h | 1640h | SS7IP | 2455 |  |  | Rel5 |  |  |  |
| 507 | 77 | **High Speed Downlink Packet Access** |  | 510d | 2001-04-02 A | 2003-03-14 |  | 96% | 20.14d | 2001-04-02 | 2002-10-04 | 395d | 295d |  |  | R2 | 14312h | 13746.9h | HSDPA | 2476 |  | Ravi Kuchibhotla, Motorola | Rel5 | TSG | Cesar |  |
| 508 | 77.1 | Physical Layer |  | 257d | 2001-04-05 A | 2002-03-29 A |  | 100% |  | 2001-04-05 | 2002-03-29 | 257d |  |  | finish no earlier than 2002-03-29 | R1 | 2056h | 2056h | HSDPA-Phys | 2477 |  | Amitava Ghosh, Motorola |  | TSG |  |  |
| 509 | 77.2 | Layer 2 and 3 aspects |  | 257d | 2001-04-05 A | 2002-03-29 A |  | 100% |  | 2001-04-05 | 2002-03-29 | 257d |  |  | finish no earlier than 2002-03-29 | R2 | 2056h | 2056h | HSDPA-L23 | 2478 |  | Ravi Kuchibhotla, Motorola |  | TSG |  |  |
| 510 | 77.3 | Iub/Iur protocol aspects |  | 260d | 2001-04-02 A | 2002-03-29 A |  | 100% |  | 2001-04-02 | 2002-03-29 | 260d |  |  | finish no earlier than 2002-03-29 | R3 | 2080h | 2080h | HSDPA-IubIur | 2479 |  | Mike Diesen, Motorola |  | TSG |  |  |
| 511 | 77.4 | RF Radio Transmission/ Reception, System Performance Requirements and Conformance Testing |  | 505d | 2001-04-09 A | 2003-03-14 |  | 90% | 50.5d | 2001-04-09 | 2002-10-04 | 390d | 295d |  | finish no earlier than 2003-03-14 | R4 | 4040h | 3636h | HSDPA-RF | 2480 |  | Howard Benn, Motorola |  | TSG |  |  |
| 512 | 78 | **Rel-5 Improvements of Radio Interface** |  | 535d | 2000-08-14 A | 2002-08-30 |  | 89% | 56.7d | 2000-06-19 | 2003-06-30 | 791d | 435d |  |  | RP | 30376h | 27009h | RInImp |  |  |  | NA | TSG | Tsukasa |  |
| 513 | 78.1 | **Base station classification** |  | 480d | 2000-08-14 A | 2002-06-14 A |  | 100% |  | 2000-08-14 | 2002-12-20 | 615d |  |  |  | R4 | 9208h | 9208h | RInImp-BSClass | 1471 |  | A. Toskala, Nokia | Rel5 | TSG |  | BaAS |
| 514 | 78.1.1 | TDD Base station classification |  | 410d | 2000-08-14 A | 2002-03-08 A |  | 100% |  | 2000-08-14 | 2002-03-08 | 410d |  |  | finish no earlier than 2002-03-08 | R4 | 3280h | 3280h | RInImp-BSClass-TDD | 1477 |  | A. Toskala, Nokia |  | TSG |  | BaAs |
| 515 | 78.1.2 | Base Station Classification for 1.28 Mcps TDD option |  | 261d | 2001-06-15 A | 2002-06-14 A |  | 100% |  | 2001-06-15 | 2002-06-14 | 261d |  |  | finish no earlier than 2002-06-14 | R4 | 2088h | 2088h | RInImp-BSClass-LCRTDD |  |  | Meik Kottkamp, Siemens |  | TSG |  |  |
| 516 | 78.2 | Enhancement on the DSCH hard split mode |  | 271d | 2001-03-16 A | 2002-03-29 A |  | 100% |  | 2001-03-16 | 2002-03-29 | 271d |  |  | finish no earlier than 2002-03-29 | R1 | 2168h | 2168h | RInImp-DSCHhsp | 2469 |  | Jaeyoel KIM, Samsung | Rel5 | TSG |  |  |
| 517 | 78.3 | Hybrid ARQ II/III |  | 355d | 2000-08-21 A | 2001-12-28 A |  | 100% |  | 2000-08-21 | 2001-12-28 | 355d |  |  | finish no earlier than 2001-12-28 | R2 | 2840h | 2840h | RInImp-HARQ | 1217 |  | A. Sitte, Siemens | Rel5 | TSG |  |  |
| 518 | 78.4 | FS on USTS |  | 355d | 2000-08-14 A | 2001-12-21 A |  | 100% |  | 2000-08-14 | 2001-12-21 | 355d |  |  | finish no earlier than 2001-12-21 | R1 | 2840h | 2840h | RInImp-USTS | 1221 |  | D. Kim, SK Telecom | Rel5 | TSG |  | BaAS |
| 519 | 78.5 | FS on UE antenna efficency test method performance requirements |  | 255d | 2000-09-25 A | 2001-09-14 A |  | 100% |  | 2000-09-25 | 2001-09-14 | 255d |  |  | finish no earlier than 2001-09-14 | R4 | 2040h | 2040h | RInImp-UEAnTM | 1997 |  | O. Edvardsson, Allgon | Rel5 | TSG |  |  |
| 520 | 78.6 | FS on the re-introduction of the downlink SIR measurement |  | 200d | 2001-03-12 A | 2001-12-14 A |  | 100% |  | 2001-03-12 | 2001-12-14 | 200d |  |  | finish no earlier than 2001-12-14 | R4 | 1600h | 1600h | RInImp-SIR | 24002 |  | Torgny Palenius, Ericsson | Rel5 | TSG | Cesar |  |
| 521 | 78.7 | FS on mitigating the effect of CPICH interference at the UE |  | 255d | 2001-03-19 A | 2002-03-08 A |  | 100% |  | 2001-03-19 | 2002-03-08 | 255d |  |  | finish no earlier than 2002-03-08 | R4 | 2040h | 2040h | RInImp-CPICH_Intf | 24001 |  | Shimon Moshavi, Intel | Rel5 | TSG | Cesar |  |

Notes:
- 500: Bearer services, new spec document? / This task requires supporting companies before it can start
- 506: update WID / 30.11.2001: To CN #14 for approval
- 509: 30 November: Completion date shifted to March 2002
- 517: Stopped at RAN#14; work on this task was performed as part of High Speed Downlink Packet Access feature

| ID | WBS | Task | Type | Duration | Start | Finish | Predecessors | Complete | Remaining | Baseline start | Baseline finish | Baseline duration | Total slack | Free slack | Constraint | Resources | Work | Actual work | Text6 | Text9 | Text1 | Text7 | Text8 | Text2 | Text4 | Text3 |
| --- | --- | --- | --- | --- | --- | --- | --- | --- | --- | --- | --- | --- | --- | --- | --- | --- | --- | --- | --- | --- | --- | --- | --- | --- | --- | --- |
| 522 | 78.8 | **Conformance Test Spec. improvements in Radio Interface** |  | 140d | 2002-02-18 | 2002-08-30 |  |  |  | 2002-02-18 | 2002-08-30 | 140d | 435d |  |  | T1 | 3360h |  |  |  |  |  |  |  |  |  |
| 523 | 78.8.1 | Testing improvement of inter-frequency and inter-system measurement |  | 140d | 2002-02-18 | 2002-08-30 |  |  |  | 2002-02-18 | 2002-08-30 | 140d | 435d |  | finish no earlier than 2002-08-30 | T1 | 1120h |  | Rel5 | 2210 |  |  |  |  |  |  |
| 524 | 78.8.2 | Testing Hybrid ARQ II/III |  | 140d | 2002-02-18 | 2002-08-30 |  |  |  | 2002-02-18 | 2002-08-30 | 140d | 435d |  | finish no earlier than 2002-08-30 | T1 | 1120h |  | Rel5 | 2211 |  |  |  |  |  |  |
| 525 | 79 | **Rel-5 RAN improvements** |  | 383d | 2001-03-16 A | 2002-09-03 |  | 94% | 21.75d | 2000-08-21 | 2003-06-30 | 746d | 433d |  |  | RP | 31664h | 28864h | NA |  | RANimp | TSG | Cesar |  |  |  |
| 526 | 79.1 | **RRM optimization for Iur and Iub** |  | 318d | 2001-03-16 A | 2002-06-04 A |  | 100% |  | 2001-03-16 | 2002-06-28 | 336d |  |  |  | R3 | 8904h | 8904h | Rel5 | 656 | RANimp-RRMopt | TSG |  | BaAS | Gert-Jan van Lieshout, Ericsson |  |
| 527 | 79.1.1 | Iur common transport channel efficiency optimisation |  | 271d | 2001-03-16 A | 2002-03-29 A |  | 100% |  | 2001-03-16 | 2002-03-29 | 271d |  |  | finish no earlier than 2002-03-29 | R3 | 2168h | 2168h |  |  | RANimp-RRMopt-ctc | TSG |  |  | Shahrokh Amirijoo, Ericsson |  |
| 528 | 79.1.2 | Iur neighbouring cell reporting efficiency optimisation |  | 271d | 2001-03-16 A | 2002-03-29 A |  | 100% |  | 2001-03-16 | 2002-03-29 | 271d |  |  | finish no earlier than 2002-03-29 | R3 | 2168h | 2168h |  |  | RANimp-RRMopt-ncr | TSG |  |  | Shahrokh Amirijoo, Ericsson |  |
| 529 | 79.1.3 | FS Introduction of direct transport bearers between SRNC and Node-B |  | 253d | 2001-06-15 A | 2002-06-04 A |  | 100% |  | 2001-06-15 | 2002-06-28 | 271d |  |  | finish no earlier than 2002-06-28 | R3 | 2024h | 2024h |  |  | RAN-imp-RRMopt-DTB | TSG |  |  | Risto Sepponen, Ericsson |  |
| 530 | 79.2 | RL Timing Adjustment |  | 271d | 2001-03-16 A | 2002-03-29 A |  | 100% |  | 2001-03-16 | 2002-03-29 | 271d |  |  | finish no earlier than 2002-03-29 | R3 | 2168h | 2168h | Rel5 | 22003 | RANimp-RLTA | TSG |  |  | Elena Voltolina, Ericsson |  |
| 531 | 79.3 | Separation of resource reservation and radio link activation |  | 271d | 2001-03-16 A | 2002-03-29 A |  | 100% |  | 2001-03-16 | 2002-03-29 | 271d |  |  | finish no earlier than 2002-03-29 | R3 | 2168h | 2168h | Rel5 | 22004 | RANimp-SepRR | TSG |  |  | Gert-Jan van Lieshout, Ericsson |  |
| 532 | 79.4 | FS SRNS Relocation Procedure Enhancement |  | 318d | 2001-06-15 A | 2002-09-03 A |  | 100% |  | 2001-06-15 | 2002-06-28 | 271d |  |  | finish no earlier than 2002-09-06 | R3 | 2544h | 2544h | Rel5 |  | RANimp-SRNS | TSG |  |  | Olivier Guyot, Nokia |  |
| 533 | 79.5 | FS Improvement of Radio Resource Management across RNS and RNS/PSS |  | 201d | 2001-03-16 A | 2001-12-21 A |  | 100% |  | 2001-03-16 | 2001-12-21 | 201d |  |  | finish no earlier than 2001-12-21 | R3 | 1608h | 1608h | Rel5 | 22001 | RANimp-ImpRRM | TSG |  |  | Antti Toskala, Nokia |  |
| 534 | 79.6 | Re-arrangements of Iub transport bearers |  | 271d | 2001-03-16 A | 2002-03-29 A |  | 100% |  | 2001-03-16 | 2002-03-29 | 271d |  |  | finish no earlier than 2002-03-29 | R3 | 2168h | 2168h | Rel5 | 22002 | RANimp-TTPS | TSG |  |  | Antti Toskala, Nokia |  |
| 535 | 79.7 | RAB support enhancement for Rel-5 |  | 325d | 2001-04-02 A | 2002-06-28 A |  | 100% |  | 2001-04-02 | 2002-06-28 | 325d |  |  | finish no earlier than 2002-06-28 | R2 | 2600h | 2600h | Rel5 |  | RANimp-RABSE5 | TSG |  |  | Juha Mikola, Nokia |  |
| 536 | 79.8 | Beamforming requirements for UE |  | 61d | 2001-09-21 A | 2001-12-14 A |  | 100% |  | 2001-09-21 | 2001-12-14 | 61d |  |  | finish no earlier than 2001-12-14 | R1 | 488h | 488h | Rel5 |  | RANimp-BFR-UE | TSG |  |  | Jussi Kähtävä, Nokia |  |
| 537 | 79.9 | Support of Site Selection Diversity Transmission in UTRAN |  | 123d | 2001-12-14 A | 2002-06-04 A |  | 100% |  | 2001-12-14 | 2002-06-04 | 123d |  |  | finish no earlier than 2002-06-04 | R1 | 984h | 984h | Rel5 |  | RANimp-SSDT | TSG |  |  | NEC |  |
| 538 | 79.10 | Node B Synchronisation for 1.28 Mcps TDD |  | 271d | 2001-03-16 A | 2002-03-29 A |  | 100% |  | 2001-03-16 | 2002-03-29 | 271d |  |  | finish no earlier than 2002-03-29 | R1 | 2168h | 2168h | Rel5 | 2472 | RANimp-NBSLCR | TSG |  |  | Jinling HU, CWTS/CATT |  |
| 539 | 79.11 | Start Testing | milestone | 0d | 2001-12-03 | 2001-12-03 |  |  |  | 2001-12-03 | 2001-12-03 | 0d | 455d | 21d | start no earlier than 2001-12-03 | MLST |  |  |  | 1912 |  |  |  |  |  |  |
| 540 | 79.12 | **Conformance Test Aspects - RAN Improvements** |  | 175d | 2002-01-01 | 2002-09-02 | 539 |  |  | 2002-01-01 | 2002-09-02 | 175d | 434d |  |  | T1 | 2800h |  |  | 2102 |  |  |  |  |  | 0% |
| 541 | 79.12.1 | Testing Radio access bearer support enhancments |  | 175d | 2002-01-01 | 2002-09-02 |  |  |  | 2002-01-01 | 2002-09-02 | 175d | 434d |  | finish no earlier than 2002-09-02 | T1 | 1400h |  |  | 2222 |  |  |  |  |  |  |
| 542 | 80 | UTRAN Sharing in Connected Mode |  | 197d | 2001-12-03 A | 2002-09-03 A |  | 100% |  | 2001-12-03 | 2002-07-03 | 153d |  |  | finish no earlier than 2002-09-06 | R3 | 1576h | 1576h | Rel5 |  | NETSHARE |  |  |  | Martin Israelsson, Ericsson |  |
| 543 | 81 | **Provisioning of IP-based multimedia services** |  | 977d | 2000-01-03 A | 2003-09-30 |  | 89% | 107.01d | 2000-01-03 | 2002-12-27 | 780d | 153d |  |  | S1 | 188369h | 153972h | NA |  | IMS | TSG | MichaelC/Alain |  | Mark Cataldo, Openwave |  |
| 544 | 81.1 | **Call control and roaming to support IMS in UMTS** |  | 640d | 2000-01-03 A | 2002-06-14 |  | 93% | 42.79d | 2000-01-03 | 2002-06-14 | 640d | 490d |  |  | S2 | 85934.6h | 72546h | Rel5 |  | IMS-CCR | TSG |  |  | Liz Daniel, Lucent |  |
| 545 | 81.1.1 | Stage 1 |  | 215d | 2000-02-21 A | 2000-12-15 A |  | 100% |  | 2000-02-21 | 2000-12-15 | 215d |  |  | finish no earlier than 2000-09-21 | S1 | 1720h | 1720h |  | 1633 |  |  |  | CCaR | Mark Cataldo, Motorola | 22.228 |
| 546 | 81.1.2 | Stage 2 (Architecture and Main flows) |  | 246d | 2000-04-14 A | 2001-03-23 A |  | 100% |  | 2000-04-14 | 2001-03-23 | 246d |  |  | finish no earlier than 2001-03-23 | S2 | 1968h | 1968h |  | 1514 |  | TSG |  | CCaR | Liz Daniel, Lucent | 23.228 |
| 547 | 81.1.3 | Impact on MM/CC/SM |  | 400d | 2000-08-28 A | 2002-03-08 A |  | 100% |  | 2000-08-28 | 2002-03-08 | 400d |  |  | finish no earlier than 2002-03-08 | N1 | 3200h | 3200h |  | 1296 | IMS-CCR-IWMM |  |  | CCaR | Keith Drage, Lucent |  |

Notes:
- 523: start/finish dates set / Not started due to lack of supporting companies
- 524: start/finish dates set / Not started yet due to lack of supporting companies
- 529: FS was closed and introduction of WI not agreed at RAN #16
- 533: FS was closed and WI was introduced at RAN #14
- 535: RFC 3095 context relocation
- 537: RP-020356
- 541: duration set to 6 months (was 0) / Task not started due to lack of supporting companies
- 542: Formerly 'Shared Network support in connected mode', renamed at RAN #16.
- 543: S1 WI proposed S1-000290 / TR22.976, WI Rapporteur, Mark Cataldo, Motorola
- 545: Issues include e.g.: Roaming requirements, Requirements on supplementary services, Interworking requirements / Text5: 17.-21.7., S1#9, Completion of CR's against 22 series [dates taken from 22.976]
- 546: Issues include e.g.: Mobile IP, RAB selection principles, Optimized VoIP bearer mechanisms, SIP multimedia protocol / Text5: R00 stage 2 at least 80 % complete in TSGS #8 21.-23.6.2000 [WI dates need revision. To be revised by TSG#8]
- 547: Per 26/2-02: This is understood to be the PCO & TFT CRs which CN1 provides to TSGN #15 for approval. If this is correct understanding, then the task is 100 % complete. / Text5: drage@lucent.com

| ID | WBS | Task | Duration | Start | Finish | Complete | Remaining | Baseline start | Baseline finish | Baseline duration | Total slack | Constraint | Resources | Work | Actual work | Text3 | Text4 | Text5 | Text7 | Text2 | Text9 | Text1 |
| --- | --- | --- | --- | --- | --- | --- | --- | --- | --- | --- | --- | --- | --- | --- | --- | --- | --- | --- | --- | --- | --- | --- |
| 548 | 81.1.4 | **SIP Call Control protocol for the IMS** | 640d | 2000-01-03 A | 2002-06-14 | 93% | 47.72d | 2000-01-03 | 2002-06-14 | 640d | 490d |  | N1 | 74008h | 65451.4h | TS 24.228, TS 24.229, TS 23.218 | Keith Drage, Lucent | drage@lucent.com | TSG |  |  |  |
| 549 | 81.1.4.1 | IMS signalling flows | 385d | 2000-10-02 A | 2002-03-22 | 90% | 38.5d | 2000-10-02 | 2002-03-22 | 385d | 550d | finish no earlier than 2002-03-22 | N1 | 3080h | 2772h | TS 24.228 |  |  | TSG | CCaR | 1998 |  |
| 550 | 81.1.4.2 | IMS stage 3 | 385d | 2000-10-02 A | 2002-03-22 | 90% | 38.5d | 2000-10-02 | 2002-03-22 | 385d | 550d | finish no earlier than 2002-03-22 | N1 | 3080h | 2772h | TS 24.229 |  |  | TSG | CCaR | 1278 |  |
| 551 | 81.1.4.3 | IMS Session Handling; stage 2 | 385d | 2000-10-02 A | 2002-03-22 A | 100% |  | 2000-10-02 | 2002-03-22 | 385d |  | finish no earlier than 2002-03-22 | N1 | 3080h | 3080h | TS 23.218 |  |  | TSG |  | 2255 |  |
| 552 | 81.1.4.4 | **Main IETF dependencies** | 635d | 2000-01-03 A | 2002-06-07 | 94% | 38.43d | 2000-01-03 | 2002-06-07 | 635d | 495d |  | NP | 48600h | 44286.4h |  |  |  |  |  |  |  |
| 553 | 81.1.4.4.1 | IETF: draft-ietf-sip-rfc2543bis (Session Initiation Protocol) | 346d | 2000-11-24 A | 2002-03-22 A | 100% |  | 2000-11-24 | 2002-03-22 | 346d |  | finish no earlier than 2002-03-22 | N1 | 2768h | 2768h |  |  |  |  |  |  |  |
| 554 | 81.1.4.4.2 | IETF: draft-sip-100rel | 346d | 2000-11-24 A | 2002-03-22 A | 100% |  | 2000-11-24 | 2002-03-22 | 346d |  | finish no earlier than 2002-03-22 | N1 | 2768h | 2768h |  |  |  |  |  |  |  |
| 555 | 81.1.4.4.3 | IETF: draft-sip-manyfolks-resource (Without COMET)(Integration of resource management and SIP) | 382d | 2000-11-24 A | 2002-05-13 A | 100% |  | 2000-11-24 | 2002-05-13 | 382d |  | finish no earlier than 2002-05-13 | N1 | 3056h | 3056h |  |  |  |  |  |  |  |
| 556 | 81.1.4.4.4 | IETF: draft-ietf-sip-privacy (SIP extensions for caller identity and privacy) | 382d | 2000-11-24 A | 2002-05-13 | 90% | 38.2d | 2000-11-24 | 2002-05-13 | 382d | 514d | finish no earlier than 2002-05-13 | N1 | 3056h | 2750.4h |  |  |  |  |  |  |  |
| 557 | 81.1.4.4.5 | IETF: draft-ietf-sip-call-auth (SIP extensions for media authorization) | 382d | 2000-11-24 A | 2002-05-13 A | 100% |  | 2000-11-24 | 2002-05-13 | 382d |  | finish no earlier than 2002-05-13 | N1 | 3056h | 3056h |  |  |  |  |  |  |  |
| 558 | 81.1.4.4.6 | IETF: draft-ietf-sip-events (specific event notification) | 346d | 2000-11-24 A | 2002-03-22 A | 100% |  | 2000-11-24 | 2002-03-22 | 346d |  | finish no earlier than 2002-03-22 | N1 | 2768h | 2768h |  |  |  |  |  |  |  |
| 559 | 81.1.4.4.7 | IETF: draft-ietf-sip-refer (refer method) | 401d | 2000-11-24 A | 2002-06-07 | 90% | 40.1d | 2000-11-24 | 2002-06-07 | 401d | 495d | finish no earlier than 2002-06-07 | N1 | 3208h | 2887.2h |  |  |  |  |  |  |  |
| 560 | 81.1.4.4.8 | IETF: draft-ietf-dhc-dhcpv6 (DHCP options for SIP servers) | 382d | 2000-11-24 A | 2002-05-13 | 90% | 38.2d | 2000-11-24 | 2002-05-13 | 382d | 514d | finish no earlier than 2002-05-13 | N1 | 3056h | 2750.4h |  |  |  |  |  |  |  |
| 561 | 81.1.4.4.9 | IETF: draft-ietf-sip-replaces (SIP replaces header) | 401d | 2000-11-24 A | 2002-06-07 | 90% | 40.1d | 2000-11-24 | 2002-06-07 | 401d | 495d | finish no earlier than 2002-06-07 | N1 | 3208h | 2887.2h |  |  |  |  |  |  |  |
| 562 | 81.1.4.4.10 | IETF: draft-ietf-avt-rtp-amr (AMR and AMR WB RTP and SDP) | 346d | 2000-11-24 A | 2002-03-22 A | 100% |  | 2000-11-24 | 2002-03-22 | 346d |  | finish no earlier than 2002-03-22 | N1 | 2768h | 2768h |  |  |  |  |  |  |  |
| 563 | 81.1.4.4.11 | IETF: draft-ietf-mmusic-sdp-new (IPv6 support within SDP) | 580d | 2000-01-03 A | 2002-03-22 | 90% | 58d | 2000-01-03 | 2002-03-22 | 580d | 550d | finish no earlier than 2002-03-22 | N1 | 4640h | 4176h |  |  |  |  |  |  |  |
| 564 | 81.1.4.4.12 | IETF: draft-ietf-sip-update | 382d | 2000-11-24 A | 2002-05-13 A | 100% |  |  |  |  |  | finish no earlier than 2002-05-13 | N1 | 3056h | 3056h |  |  |  |  |  |  |  |
| 565 | 81.1.4.4.13 | IETF: draft-jennings-sipping-nai (Network Asserted Identity) | 382d | 2000-11-24 A | 2002-05-13 | 90% | 38.2d |  |  |  | 514d | finish no earlier than 2002-05-13 | N1 | 3056h | 2750.4h |  |  |  |  |  |  |  |
| 566 | 81.1.4.4.14 | IETF: p-header drafts for 3GPP (Various 3GPP dependencies) | 382d | 2000-11-24 A | 2002-05-13 | 80% | 76.4d |  |  |  | 514d | finish no earlier than 2002-05-13 | N1 | 3056h | 2444.8h |  |  |  |  |  |  |  |
| 567 | 81.1.4.5 | **Addressing** | 380d | 2000-10-09 A | 2002-03-22 A | 100% |  | 2000-10-09 | 2002-03-22 | 380d |  |  | S2 | 7744h | 7744h |  |  |  |  | CCaR | 1290 |  |
| 568 | 81.1.4.5.1 | Architectural issues | 235d | 2000-10-09 A | 2001-08-31 A | 100% |  | 2000-10-09 | 2001-08-31 | 235d |  | finish no earlier than 2001-03-16 | S2 | 1880h | 1880h |  |  |  |  | CCaR | 1291 |  |
| 569 | 81.1.4.5.2 | Impact on HSS | 353d | 2000-11-15 A | 2002-03-22 A | 100% |  | 2000-11-15 | 2002-03-22 | 353d |  | finish no earlier than 2002-03-22 | N4 | 2824h | 2824h |  |  |  |  | CCaR | 1292 |  |
| 570 | 81.1.4.6 | **Service Examples** | 304d | 2001-04-17 A | 2002-06-14 | 50% | 152d | 2001-04-17 | 2002-06-14 | 304d | 490d |  | S1 | 4864h | 1502.4h | 22.928 | Mark Cataldo, Motorola | mcatald1@email.mot.com | TSG |  |  | IMS-Sex |
| 571 | 81.1.4.6.1 | IMS Framework Report | 304d | 2001-04-17 A | 2002-06-14 | 50% | 152d | 2001-04-17 | 2002-06-14 | 304d | 490d | finish no earlier than 2002-06-14 | S1 | 2432h | 1216h | 22.941 | Randolph Wohlert, SBC Technology Resources, Inc. | rwohlert@tri.sbc.com | TSG |  |  | IMS-FrWk |

Notes:
- 548: TSGN_10 approved the change:CN1 - SA2 SIP joint meeting spotted one more place for improvement: work tasks with ID 1998 and 1278 are actually subtasks under of single CN1 WT. One WI has been approved for the CN1 WT with title "SIP Call Control protocol...
- 549: TS 24.228...
- 550: TS 24.229...
- 551: TS 23.218...
- 563: [DAB 08-03-02] - Needs to be replaced by mmusic SDP IPv6 + rfc2327
- 569: 17th May, KK: This is cover by 29.228 & 29228. Work complete.

| ID | WBS | Task | Duration | Start | Finish | Complete | Remaining | Baseline start | Baseline finish | Baseline duration | Total slack | Constraint | Resources | Work | Actual work | Text1 | Text5 | Text6 | Text7 | Text9 | Text2 | Text3 |
| --- | --- | --- | --- | --- | --- | --- | --- | --- | --- | --- | --- | --- | --- | --- | --- | --- | --- | --- | --- | --- | --- | --- |
| 572 | 81.2 | **Access Security for IMS** | 270d | 2001-06-25 A | 2002-07-05 A | 100% |  | 2001-06-25 | 2002-07-05 | 270d |  |  | S3 | 6920h | 6920h | IMS-ASEC | krister.boman@emw.ericsson.se | Rel5 | TSG | 1298 |  |  |
| 573 | 81.2.1 | SA3 task | 270d | 2001-06-25 A | 2002-07-05 A | 100% |  | 2001-06-25 | 2002-07-05 | 270d |  | finish no earlier than 2002-07-05 | S3 | 2160h | 2160h |  |  |  |  |  |  |  |
| 574 | 81.2.2 | IMS impacts on UICC (ISIM application) | 185d | 2001-10-08 A | 2002-06-21 A | 100% |  | 2001-10-08 | 2002-06-21 | 185d |  | finish no earlier than 2002-06-21 | T3 | 1480h | 1480h |  |  |  |  |  |  |  |
| 575 | 81.2.3 | SIP extensions for Integrity protection | 140d | 2001-12-17 A | 2002-06-28 A | 100% |  | 2001-12-17 | 2002-06-28 | 140d |  | finish no earlier than 2002-06-28 | N1 | 1120h | 1120h |  |  |  |  |  |  |  |
| 576 | 81.3 | Security Aspects of Requirement for Network Configuration Independence | 130d | 2001-07-02 A | 2001-12-28 A | 100% |  | 2001-07-02 | 2001-12-28 | 130d |  | finish no earlier than 2001-12-28 | S3 | 1040h | 1040h | SEC1-NCI | hugh.shieh@attws.com | Rel5 | TSG |  |  |  |
| 577 | 81.4 | Lawful interception | 410d | 2000-09-04 A | 2002-03-29 A | 100% |  | 2000-09-04 | 2002-03-29 | 410d |  | finish no earlier than 2002-03-29 | S3 | 3280h | 3280h | IMS-LI | berthold.wilhelm@regtp.de | Rel5 | TSG | 1299 | CCaR |  |
| 578 | 81.5 | Charging and OAM&P for IMS | 383d | 2000-12-25 A | 2002-06-12 A | 100% |  | 2000-12-25 | 2001-12-21 | 260d |  | finish no earlier than 2002-06-12 | S5 | 3064h | 3064h | IMS-OAM | Albert.Yuhan@voicestream.com; Michael.Truss@MOTOROLA.COM | Rel5 | TSG | 1303 | CCaR | 32-series |
| 579 | 81.6 | **Multimedia codecs and protocols for conversational PS services** | 568d | 2000-07-26 A | 2002-09-27 | 94% | 31.29d | 2000-07-26 | 2002-12-06 | 618d | 415d |  | S4 | 15640h | 14778.5h | IMS-CODEC | pasi.s.ojala@nokia.com | Rel5 | TSG |  |  | 26.235, 26.236 |
| 580 | 81.6.1 | Codecs | 427d | 2000-07-26 A | 2002-03-14 A | 100% |  | 2000-07-26 | 2002-03-14 | 427d |  | finish no earlier than 2001-03-21 | S4 | 3416h | 3416h |  |  |  | TSG | 2039 |  | 26.235, 26.236 |
| 581 | 81.6.2 | Transport protocols | 1d | 2002-03-12 A | 2002-03-12 A | 100% |  | 2002-03-12 | 2002-03-12 | 1d |  | finish no earlier than 2002-03-12 | S4 | 8h | 8h | IMS-CODEC |  | Rel5 |  |  |  | 26.236 |
| 582 | 81.6.4 | recommendation for QoS parameter values for various media types | 195d | 2001-12-31 A | 2002-09-27 A | 100% |  | 2001-12-31 | 2002-09-27 | 195d |  | finish no earlier than 2002-09-27 | S4 | 1560h | 1560h |  |  |  | TSG |  |  |  |
| 583 | 81.6.5 | IETF: draft-ietf-sip-digest-aka | 382d | 2000-11-24 A | 2002-05-13 | 90% | 38.2d |  |  |  | 514d | finish no earlier than 2002-05-13 | N1 | 3056h | 2750.4h |  |  |  |  |  |  |  |
| 584 | 81.6.6 | IETF: draft-ietf-sip-sec-agree | 382d | 2000-11-24 A | 2002-05-13 | 90% | 38.2d |  |  |  | 514d | finish no earlier than 2002-05-13 | N1 | 3056h | 2750.4h |  |  |  |  |  |  |  |
| 585 | 81.7 | **SIP message compression** | 185d | 2001-09-24 A | 2002-06-07 | 56% | 81.27d | 2001-09-24 | 2002-06-07 | 185d | 495d |  | S2 | 3128h | 1753.81h |  |  | Rel5 |  |  |  |  |
| 586 | 81.7.1 | Stage 2 | 25d | 2001-09-24 A | 2001-10-26 A | 100% |  | 2001-09-24 | 2001-10-26 | 25d |  | finish no earlier than 2001-10-26 | S2 | 200h | 200h |  |  |  |  |  |  |  |
| 587 | 81.7.2 | Compression signalling | 181d | 2001-09-28 A | 2002-06-07 | 50% | 90.5d | 2001-09-28 | 2002-06-07 | 181d | 495d | finish no earlier than 2002-06-07 | N1 | 1448h | 724h |  |  |  |  |  |  |  |
| 588 | 81.8 | **Stage 3 description of IMS interfaces** | 383d | 2001-03-14 A | 2002-08-30 | 94% | 24.4d | 2001-03-14 | 2002-06-07 | 323d | 435d |  | NP | 29531.6h | 27650.5h |  |  | Rel5 |  |  |  |  |
| 589 | 81.8.1 | Cx interface (HSS to CSCF) | 135.95d | 2001-03-14 A | 2002-06-07 A | 100% |  | 2001-03-14 | 2002-06-07 | 135.95d |  | finish no earlier than 2002-06-07 | N4 | 1087.58h | 1087.58h |  |  |  | TSG |  |  |  |
| 590 | 81.8.2 | Mp interface (MRFC - MRFP) enhancements | 258d | 2001-03-14 A | 2002-03-08 A | 100% |  | 2001-03-14 | 2002-03-08 | 258d |  | finish no earlier than 2002-06-07 | N4 | 2064h | 2064h |  |  |  |  |  |  |  |
| 591 | 81.8.3 | Mw interface (CSCF to P-CSCF) | 323d | 2001-03-14 A | 2002-06-07 | 90% | 32.3d | 2001-03-14 | 2002-06-07 | 323d | 495d | finish no earlier than 2002-06-07 | N1 | 2584h | 2325.6h |  |  |  |  |  |  |  |
| 592 | 81.8.4 | Mr interface (CSCF to MRF) | 273d | 2001-03-14 A | 2002-03-29 A | 100% |  | 2001-03-14 | 2002-03-29 | 273d |  | finish no earlier than 2002-03-29 | N1 | 2184h | 2184h |  |  |  |  |  |  |  |
| 593 | 81.8.5 | Dx interface (I-CSCF to SLF) | 323d | 2001-03-14 A | 2002-06-07 A | 100% |  | 2001-03-14 | 2002-06-07 | 323d |  | finish no earlier than 2002-06-07 | N4 | 2584h | 2584h |  |  |  |  |  |  |  |
| 594 | 81.8.6 | Go interface (GGSN to PCF) | 323d | 2001-03-14 A | 2002-06-07 | 95% | 16.15d | 2001-03-14 | 2002-06-07 | 323d | 495d | finish no earlier than 2002-06-07 | N3 | 2584h | 2454.8h |  |  |  |  |  |  |  |
| 595 | 81.8.7 | ISC (IMS Service Control) Interface | 323d | 2001-03-14 A | 2002-06-07 A | 100% |  | 2001-03-14 | 2002-06-07 | 323d |  | finish no earlier than 2002-06-07 | N1 | 2584h | 2584h |  |  |  |  |  |  |  |
| 596 | 81.8.8 | Sh interface (HSS to AS) | 82d | 2002-02-14 A | 2002-06-07 A | 100% |  | 2002-02-14 | 2002-06-07 | 82d |  | finish no earlier than 2002-06-07 | N4 | 656h | 656h |  |  |  |  |  |  |  |
| 597 | 81.8.9 | Si interface (HSS to IM-SSF) | 162.5d | 2002-01-16 A | 2002-08-30 | 72% | 45d | 2002-01-16 | 2002-06-07 | 102.5d | 435d | finish no earlier than 2002-06-07 | N4 | 1300h | 940h |  |  |  |  |  |  |  |
| 598 | 81.8.10 | Gm interface (UE to CSCF) | 323d | 2001-03-14 A | 2002-06-07 | 90% | 32.3d | 2001-03-14 | 2002-06-07 | 323d | 495d | finish no earlier than 2002-06-07 | N1 | 2584h | 2325.6h |  |  |  |  |  |  |  |
| 599 | 81.8.11 | Mi interface (CSCF to BGCF) | 323d | 2001-03-14 A | 2002-06-07 | 90% | 32.3d | 2001-03-14 | 2002-06-07 | 323d | 495d | finish no earlier than 2002-06-07 | N1 | 2584h | 2325.6h |  |  |  |  |  |  |  |
| 600 | 81.8.12 | Mj interface (BGCF to MGCF) | 323d | 2001-03-14 A | 2002-06-07 | 90% | 32.3d | 2001-03-14 | 2002-06-07 | 323d | 495d | finish no earlier than 2002-06-07 | N1 | 2584h | 2325.6h |  |  |  |  |  |  |  |
| 601 | 81.8.13 | Mk interface (BGCF to BGCF) | 323d | 2001-03-14 A | 2002-06-07 | 90% | 32.3d | 2001-03-14 | 2002-06-07 | 323d | 495d | finish no earlier than 2002-06-07 | N1 | 2584h | 2325.6h |  |  |  |  |  |  |  |
| 602 | 81.9 | Support of VHE/OSA by entities and protocols of the IMS (e.g. CSCF) | 186d | 2001-09-21 A | 2002-06-07 A | 100% |  | 2001-09-21 | 2002-06-07 | 186d |  | finish no earlier than 2002-06-07 | N5 | 1488h | 1488h | IMS-ONOSA | Ard.Jan.Moerdijk@eln.ericsson.se | Rel5 | TSG | 1310 | CCaR | 29.198, 29.998 |

Notes:
- 572: TS33.203 will be presented for info at SA#14 and is scheduled for approval at SA#15. Dependencies on IETF exist. Approved SA#15 / Text4: Krister Boman, Ericsson
- 573: SHOULD BE DELETED - COVERED BY REAL S3 TASKS
- 574: Text4: Jeremy Norris (Vodafone)
- 575: Per 26/2-02: CN1 is not aware of any requirements and is not doing anything on this task.
- 576: Incorporated into IMS access security TS (33.203) which will be presented for info at SA#14 and is scheduled for approval at SA#15.Editors notes removed SA#16&17 / Text4: Hugh Shieh, AT&T Wireless Services
- 577: Rel-5 33.106 and 33.107 approved at SA#12.Revised WID including new Rel-5 specification (33.108) scheduled for approval at SA#14. 33.108 approved SA#16. CR at SA#17 / Text4: Berthold Wilhelm, Reg TP
- 578: Text4: Albert YUHAN (VoiceStream Wireless), Michael TRUSS (Motorola)
- 579: Text4: B. Aronson, Toshiba, and P. Ojala, Nokia
- 581: Text4: P. Ojala, Nokia
- 589: DAB 12/12/01 to 75% / CN4 14/02/02 to 79% / 17th May work complete. 3GPP TSs 29.228 and 29.229 will be sent for proval in CN#16
- 590: [DAB 08-03-02] - No work required in CN4
- 593: CN4#11 30/11/01: No inputs received in CN4 / 14/02/02 Completed(introduced in 29.228)
- 594: [DAB - 30/07/02] - % complete to 95% (if we exclude Diffserv)
- 596: CN4#11 30/11/01: No inputs received in CN4 / CN4#12bis 14/02/02: WID approved / 17th May 100% complete. 3GPP TS 29.329 will be sent for approval in CN#16
- 597: SA16: Part of Rel5 only if completed in September 02
- 602: Text4: Ard-Jan MOERDIJK (Ericsson)

| ID | WBS | Task | Type | Duration | Start | Finish | Predecessors | Complete | Remaining | Baseline start | Baseline finish | Baseline duration | Total slack | Free slack | Constraint | Resources | Work | Actual work | Text1 | Text2 | Text4 | Text6 | Text9 | Text3 | Text5 | Text7 | Text8 |
| --- | --- | --- | --- | --- | --- | --- | --- | --- | --- | --- | --- | --- | --- | --- | --- | --- | --- | --- | --- | --- | --- | --- | --- | --- | --- | --- | --- |
| 603 | 81.10 | **CAMEL control of IMS services** |  | 365d | 2001-04-16 A | 2002-09-06 |  | 91% | 34.05d | 2001-04-16 | 2002-06-07 | 300d | 430d |  |  | N2 | 9952h | 9023.6h | IMS-CAMEL | CCaR | Angelica Remoquillo, Lucent | Rel5 | 1310 |  |  |  |  |
| 604 | 81.10.1 | Stage2 work 'general' |  | 365d | 2001-04-16 A | 2002-09-06 A |  | 100% |  | 2001-04-16 | 2002-06-07 | 300d |  |  | finish no earlier than 2002-09-06 | N2 | 2920h | 2920h |  |  |  |  |  |  |  |  |  |
| 605 | 81.10.2 | Stage3 work 'CAP' |  | 175d | 2002-01-07 A | 2002-09-06 A |  | 100% |  | 2002-01-07 | 2002-06-07 | 110d |  |  | finish no earlier than 2002-09-06 | N2 | 1400h | 1400h |  |  |  |  |  |  |  |  |  |
| 606 | 81.10.3 | Stage2 work 'Si interface' |  | 175d | 2002-01-07 A | 2002-09-06 A |  | 100% |  | 2002-01-07 | 2002-06-07 | 110d |  |  | finish no earlier than 2002-09-06 | N2 | 1400h | 1400h |  |  |  |  |  |  |  |  |  |
| 607 | 81.10.4 | Stage3 work 'Si interface' |  | 82d | 2002-02-14 A | 2002-06-07 A |  | 100% |  | 2002-02-14 | 2002-06-07 | 82d |  |  | finish no earlier than 2002-06-07 | N4 | 656h | 656h |  |  |  |  |  |  |  |  |  |
| 608 | 81.10.5 | SDM issues for CAMEL control of IMS |  | 82d | 2002-02-14 | 2002-06-07 |  |  |  | 2002-02-14 | 2002-06-07 | 82d | 495d |  | finish no earlier than 2002-06-07 | N4 | 656h |  |  |  |  |  |  |  |  |  |  |
| 609 | 81.11 | Pre-pay/real-time charging in IMS |  | 196d | 2001-06-15 A | 2002-03-15 |  | 60% | 78.4d | 2001-06-15 | 2002-03-15 | 196d | 555d |  | finish no earlier than 2002-03-15 | S1 | 1568h | 940.8h |  |  |  | TBD |  |  |  |  |  |
| 610 | 81.12 | **Charging** |  | 289d | 2001-08-06 A | 2002-09-12 A |  | 100% |  | 2001-08-06 | 2002-06-28 | 235d |  |  |  | S5 | 4624h | 4624h | OAM-CH |  | Karl-Heinz NENNER (T-Mobile) | Rel5 |  | 32.2xy | karl-heinz.nenner@t-mobile.de | TSG |  |
| 611 | 81.12.1 | Charging Implications of IMS architecture |  | 75d | 2001-08-06 A | 2001-11-16 A |  | 100% |  | 2001-08-06 | 2001-11-16 | 75d |  |  | finish no earlier than 2001-11-16 | S2 | 600h | 600h |  |  |  |  |  |  |  |  |  |
| 612 | 81.12.2 | Charging management for IMS (off-line & on-line) |  | 214d | 2001-11-19 A | 2002-09-12 A | 611 | 100% |  | 2001-11-19 | 2002-06-28 | 160d |  |  | finish no earlier than 2002-09-12 | S5 | 1712h | 1712h | OAM-CH |  |  | Rel5 |  |  |  | TSG |  |
| 613 | 81.13 | **Other IETF depencies** |  | 401d | 2000-11-24 A | 2002-06-07 |  | 70% | 120.3d | 2000-11-24 | 2002-06-07 | 401d | 495d |  |  | NP | 9624h | 6736.8h |  |  |  | Rel5 |  |  |  |  |  |
| 614 | 81.13.1 | IETF: draft-ietf-aaa-diameter - should be CN4 |  | 401d | 2000-11-24 A | 2002-06-07 |  | 90% | 40.1d | 2000-11-24 | 2002-06-07 | 401d | 495d |  | finish no earlier than 2002-06-07 | NP | 3208h | 2887.2h |  |  |  |  |  |  |  |  |  |
| 615 | 81.13.2 | IETF: draft-johansson-aaa-diameter-mm-app - should be CN4 |  | 401d | 2000-11-24 A | 2002-06-07 |  | 50% | 200.5d | 2000-11-24 | 2002-06-07 | 401d | 495d |  | finish no earlier than 2002-06-07 | NP | 3208h | 1604h |  |  |  |  |  |  |  |  |  |
| 616 | 81.14 | Start Testing | milestone | 0d | 2002-03-18 | 2002-03-18 |  |  |  | 2002-03-18 | 2002-03-18 | 0d | 350d | 0d | start no earlier than 2002-03-18 | MLST |  |  |  |  |  | Rel5 | 1913 |  |  |  |  |
| 617 | 81.15 | Conformance Test Aspects - Provisioning of IMS |  | 205d | 2002-03-18 | 2002-12-27 | 616 |  |  | 2002-03-18 | 2002-12-27 | 205d | 350d |  | finish no earlier than 2002-12-27 | T1 | 1640h |  | IMS-TEST |  |  |  | 1844 |  |  |  |  |
| 618 | 81.16 | Testing of support for IMS - prose |  | 139d | 2002-09-18 | 2003-03-31 |  |  |  |  |  |  | 284d |  | finish no earlier than 2003-03-31 | T1 | 1112h |  |  |  | Dan Fox, Anritsu | Rel5 |  | 34.108, 34.123 | dan.fox@eu.anritsu.com | TSG |  |
| 619 | 81.17 | Testing of support for IMS - TTCN |  | 270d | 2002-09-18 | 2003-09-30 |  |  |  |  |  |  | 153d |  | finish no earlier than 2003-09-30 | T1 | 2160h |  |  |  | Dan Fox, Anritsu | Rel5 |  | 34.108, 34.123 | dan.fox@eu.anritsu.com | TSG |  |
| 620 | 82 | **Extended Transparent End-to-End PS Streaming Service** |  | 313d? | 2002-01-03 A | 2003-03-17 |  | 86% | 44.84d? | 2001-06-21 | 2002-12-06 | 382d | 294d |  |  | S4 | 6224h | 4687.31h | PSS-E |  | O. Franceschi, Ericsson | Rel5 |  | 26.233, 26.234 | olle.franceschi@nrj.ericsson.se | TSG | Paolo |
| 621 | 82.1 | **Stage 1** |  | 86d? | 2002-11-18 A | 2003-03-17 |  | 65% | 30.1d? | 2001-06-21 | 2001-09-27 | 71d | 294d |  |  | S1 | 1376h | 1015.2h |  |  | Stephen Wolak, VODAFONE Group Plc |  |  | 22.233 | stephen.wolak@vodafone.com | TSG |  |
| 622 | 86.1.1 | Interaction with other services |  | 86d? | 2002-11-18 A | 2003-03-17 |  | 65% | 30.1d? |  |  |  | 294d |  | finish no earlier than 2003-03-17 | S1 | 688h | 447.2h |  |  | Stephen Wolak, VODAFONE Group Plc |  |  | 22.233 | stephen.wolak@vodafone.com | TSG |  |
| 623 | 82.2 | Stage 2 (version Rel5 of TS 26.234) |  | 51d | 2002-01-03 A | 2002-03-14 A |  | 100% |  | 2002-01-03 | 2002-03-14 | 51d |  |  | finish no earlier than 2002-03-26 | S4 | 408h | 408h |  |  |  |  |  | 26.234 |  | TSG |  |
| 624 | 82.3 | RTP usage model |  | 242d | 2002-01-03 A | 2002-12-06 |  | 90% | 24.2d | 2002-01-03 | 2002-12-06 | 242d | 365d |  | finish no earlier than 2002-12-06 | S4 | 1936h | 1742.4h |  |  |  |  |  | 26.937 |  |  |  |
| 625 | 83 | **Rel-5 OSA enhancements** |  | 504d | 2000-07-11 A | 2002-06-14 |  | 95% | 25.55d | 2000-07-11 | 2002-12-13 | 634d | 490d |  |  | S1 | 46736h | 41443.5h | OSA1 |  | Jörg Swetina, SIEMENS AG | NA |  | 22.127, 23.127, 29.198-x, 29.998-x |  | TSG | Adrian |
| 626 | 83.1 | General Stage 2 for Rel5 |  | 194d | 2001-09-11 A | 2002-06-07 |  | 47% | 103d | 2001-09-11 | 2002-06-07 | 194d | 495d |  |  | S2 | 1232h | 408h |  |  |  |  | 2116 |  |  |  |  |

Notes:
- 603: SA16: Part of Rel5 only if Si completed in September 02
- 604: DAB 12.12.01 split into cn4 and cn2 parts
- 605: DAB 12.12.01 split into cn4 and cn2 parts
- 606: DAB 12.12.01 split into cn4 and cn2 parts
- 607: [DAB 08-03-02] - UID 12004 is MASTER of UID 14998 / 17 May need to be recearch possible impact on 23.008 & 23.016, changes to 29.002 are done.
- 608: [DAB 08-03-02] - No activity on this in CN4
- 610: Changed Rapp email
- 613: Was introduced at SA#13 by Ileana Leuca (exact position in the WP and related WG have to be defined)
- 617: The task is a building block, individual work items are being considered but are constrained by lack of supporting companies
- 621: 2nd resp SA4
- 622: 2nd resp SA4
- 623: 2nd resp SA2

| ID | WBS | Task | Duration | Start | Finish | Predecessors | Complete | Remaining | Baseline start | Baseline finish | Baseline duration | Total slack | Constraint | Resources | Work | Actual work | Text1 | Text6 | Text7 | Text2 | Text3 | Text4 | Text5 | Text8 | Text9 |
| --- | --- | --- | --- | --- | --- | --- | --- | --- | --- | --- | --- | --- | --- | --- | --- | --- | --- | --- | --- | --- | --- | --- | --- | --- | --- |
| 627 | 83.2 | **OSA APIs for Multimedia Call Control** | 499d | 2000-07-11 A | 2002-06-07 A |  | 100% |  | 2000-07-11 | 2002-06-07 | 499d |  |  | S2 | 5960h | 5960h | OSA1-CSCF | Rel5 | TSG |  |  |  |  |  |  |
| 628 | 83.2.1 | Stage 1 | 438d | 2000-07-11 A | 2002-03-14 A |  | 100% |  | 2000-07-11 | 2002-03-14 | 438d |  | finish no earlier than 2002-03-14 | S1 | 3504h | 3504h |  |  | TSG | Ser | 22.127 | Manfred Leitgeb, SIEMENS AG | Manfred.leitgeb@siemens.at | Michael | 1430 |
| 629 | 83.2.2 | (Multimedia) Call Control - Stages 2 and 3 | 194d | 2001-09-11 A | 2002-06-07 A |  | 100% |  | 2001-09-11 | 2002-06-07 | 194d |  | finish no earlier than 2002-06-07 | N5 | 1552h | 1552h |  |  | TSG |  | 29.198-04 |  |  |  |  |
| 630 | 83.3 | Generic user interaction - Stage 3 | 194d | 2001-09-11 A | 2002-06-07 A |  | 100% |  | 2001-09-11 | 2002-06-07 | 194d |  | finish no earlier than 2002-06-07 | N5 | 1552h | 1552h |  | Rel5 | TSG |  | 29.198-05 |  |  |  |  |
| 631 | 83.4 | Charging - Stage 3 | 194d | 2001-09-11 A | 2002-06-07 A |  | 100% |  | 2001-09-11 | 2002-06-07 | 194d |  | finish no earlier than 2002-06-07 | N5 | 1552h | 1552h |  | Rel5 | TSG |  | 29.198-12 |  |  |  |  |
| 632 | 83.5 | Call Control Service Mapping; Multiparty Call Control SIP - Stage 3 | 194d | 2001-09-11 A | 2002-06-07 A |  | 100% |  | 2001-09-11 | 2002-06-07 | 194d |  | finish no earlier than 2002-06-07 | N5 | 1552h | 1552h |  | Rel5 | TSG |  | 29.998-04-4 |  |  |  |  |
| 633 | 83.6 | WSDL APIs for SOAP/HTTP - Stage 3 | 455d | 2000-09-11 A | 2002-06-07 A |  | 100% |  | 2000-09-11 | 2002-06-07 | 455d |  | finish no earlier than 2002-06-07 | N5 | 3640h | 3640h |  | Rel5 | TSG |  | 29.198, 29.998 |  |  |  |  |
| 634 | 83.7 | **OSA security** | 504d | 2000-07-11 A | 2002-06-14 |  | 92% | 41.92d | 2000-07-11 | 2002-06-14 | 504d | 490d |  | S3 | 12304h | 11280.6h | OSA1-SEC | Rel5 | TSG | Ser |  | Colin Blanchard, BT | colin.blanchard@bt.com |  | 1419 |
| 635 | 83.7.1 | Stage 1 | 349d | 2000-07-11 A | 2001-11-09 A |  | 100% |  | 2000-07-11 | 2001-11-09 | 349d |  | finish no earlier than 2001-11-09 | S1 | 2792h | 2792h |  |  | TSG |  | 22.127 | Manfred Leitgeb, SIEMENS AG | Manfred.leitgeb@siemens.at | Michael | 2121 |
| 636 | 83.7.2 | Stage 3 | 430d | 2000-10-23 A | 2002-06-14 |  | 80% | 86d | 2000-10-23 | 2002-06-14 | 430d | 490d | finish no earlier than 2002-06-14 | S3 | 3440h | 2752h |  |  | TSG | Ser | ??? |  |  |  | 1421 |
| 637 | 83.7.3 | security related SCF(s) definition | 186d | 2001-09-21 A | 2002-06-07 A |  | 100% |  | 2001-09-21 | 2002-06-07 | 186d |  | finish no earlier than 2002-06-07 | N5 | 1488h | 1488h |  |  | TSG | Ser | 29.198, 29.998 | Ard-Jan MOERDIJK (Ericsson) | Ard.Jan.Moerdijk@eln.ericsson.se |  | 1422 |
| 638 | 83.7.4 | (possibly) changes required from supporting platforms, e.g. gsmSCF, HLR | 69d | 2000-09-11 A | 2000-12-14 A |  | 100% |  | 2000-09-11 | 2000-12-14 | 69d |  | finish no earlier than 2000-12-14 | S3 | 552h | 552h |  |  | TSG | Ser | ??? |  |  |  | 1423 |
| 639 | 83.8 | **Interactions OSA - e-commerce** | 499d | 2000-07-11 A | 2002-06-07 |  | 96% | 17.51d | 2000-07-11 | 2002-06-07 | 499d | 495d |  | S2 | 6152h | 5976.8h | OSA1-ECOM | Rel5 | TSG |  |  |  |  |  | 1424 |
| 640 | 83.8.1 | Stage 1 | 438d | 2000-07-11 A | 2002-03-14 |  | 95% | 21.9d | 2000-07-11 | 2002-03-14 | 438d | 556d | finish no earlier than 2000-12-28 | S1 | 3504h | 3328.8h |  |  | TSG |  | 22.127 | Jörg Swetina, SIEMENS AG |  |  | 1425 |
| 641 | 83.8.2 | Stages 2 and 3 | 186d | 2001-09-21 A | 2002-06-07 A |  | 100% |  | 2001-09-21 | 2002-06-07 | 186d |  | finish no earlier than 2002-06-07 | N5 | 1488h | 1488h |  |  | TSG |  | 29.198, 29.998 | Ard-Jan MOERDIJK (Ericsson) | Ard.Jan.Moerdijk@eln.ericsson.se |  | 1529 |
| 642 | 83.9 | Policy Management - Stage 3 | 194d | 2001-09-11 A | 2002-06-07 A |  | 100% |  | 2001-09-11 | 2002-06-07 | 194d |  | finish no earlier than 2002-06-07 | N5 | 1552h | 1552h |  | Rel5 | TSG |  | 29.198-13 |  |  |  |  |
| 643 | 83.10 | Presence and Availability Management (PAM) - Stage 3 | 194d | 2001-09-11 A | 2002-06-07 A |  | 100% |  | 2001-09-11 | 2002-06-07 | 194d |  | finish no earlier than 2002-06-07 | N5 | 1552h | 1552h |  | Rel5 | TSG |  | 29.198-14 |  |  |  |  |
| 644 | 83.11 | **CHECK STATUS - LCS - OSA interfaces** | 455d | 2000-09-11 A | 2002-06-07 |  | 99% | 0d | 2000-09-11 | 2002-06-07 | 455d | 0d |  | S1 | 5656h | 2590.4h | OSA1-LCSI | Rel5 | TSG | Ser |  | Jörg Swetina, SIEMENS AG |  |  | 1786 |
| 645 | 83.11.1 | Stage 1 | 65d | 2000-09-11 A | 2000-12-08 A |  | 100% |  | 2000-09-11 | 2000-12-08 | 65d |  | finish no earlier than 2000-12-08 | S1 | 520h | 520h |  |  | TSG | Ser | 22.127 | Jörg Swetina, SIEMENS AG |  |  | 1787 |
| 646 | 83.11.2 | Stage 2 | 1d | 2000-12-11 A | 2000-12-11 A | 645 | 100% |  | 2000-12-11 | 2000-12-11 | 1d |  | finish no earlier than 2000-12-11 | S2 | 8h | 8h |  |  | TSG |  | 23.127 | Christophe GOURRAUD, Ericsson Canada |  |  | 2124 |
| 647 | 83.11.3 | Stage 3 | 186d | 2001-09-21 A | 2002-06-07 A | 646 | 100% |  | 2001-09-21 | 2002-06-07 | 186d |  | finish no earlier than 2002-06-07 | N5 | 1488h | 1488h |  |  | TSG | Ser | 29.198, 29.998 | Ard-Jan MOERDIJK (Ericsson) | Ard.Jan.Moerdijk@eln.ericsson.se |  | 1788 |
| 648 | 84 | **CAMEL phase 4** | 625d | 2000-04-17 A | 2002-09-06 |  | 99% | 0d | 2000-04-17 | 2002-06-14 | 565d | 0d |  | S1 | 41104h | 36244h | CAMEL4 | Rel5 | WG |  |  | Keijo Palviainen, Nokia | keijo.palviainen@nokia.com | Andrijana | 1638 |
| 649 | 84.1 | Service requirements | 565d | 2000-04-17 A | 2002-06-14 A |  | 100% |  | 2000-04-17 | 2002-06-14 | 565d |  | finish no earlier than 2002-06-14 | S1 | 4520h | 4520h |  |  | WG | Ser |  |  |  |  | 1461 |
| 650 | 84.2 | Call Party Handling | 500d | 2000-07-10 A | 2002-06-07 A |  | 100% |  | 2000-07-10 | 2002-06-07 | 500d |  | finish no earlier than 2002-06-07 | N2 | 4000h | 4000h | CAMEL4-CPH |  | WG | Ser |  |  |  |  | 2012 |
| 651 | 84.3 | Mid call procedure for MO and MT calls | 495d | 2000-07-17 A | 2002-06-07 A |  | 100% |  | 2000-07-17 | 2002-06-07 | 495d |  | finish no earlier than 2002-06-07 | N2 | 3960h | 3960h | CAMEL4-MCP |  | WG | Ser |  |  |  |  | 2013 |
| 652 | 84.4 | Interactions with Optimal Routing | 430d | 2000-07-17 A | 2002-03-08 A |  | 100% |  | 2000-07-17 | 2002-03-08 | 430d |  | finish no earlier than 2002-03-08 | N2 | 3440h | 3440h | CAMEL4-IOR |  | WG | Ser |  |  |  |  | 2014 |
| 653 | 84.5 | Inclusion of flexible tone injection | 430d | 2000-07-17 A | 2002-03-08 A |  | 100% |  | 2000-07-17 | 2002-03-08 | 430d |  | finish no earlier than 2002-03-08 | N2 | 3440h | 3440h | CAMEL4-IFTI |  | WG | Ser |  |  |  |  | 2015 |
| 654 | 84.6 | CSE control over MT SMS | 430d | 2000-07-17 A | 2002-03-08 A |  | 100% |  | 2000-07-17 | 2002-03-08 | 430d |  | finish no earlier than 2002-03-08 | N2 | 3440h | 3440h | CAMEL4-CCSMS |  | WG | Ser |  |  |  |  | 2016 |
| 655 | 84.7 | Notification of GPRS mobility management to CSE | 331d | 2001-03-02 A | 2002-06-07 A |  | 100% |  | 2001-03-02 | 2002-06-07 | 331d |  | finish no earlier than 2002-06-07 | N2 | 2648h | 2648h | CAMEL4-NMM |  | WG |  |  |  |  |  | 2460 |
| 656 | 84.8 | Provision of location information of called subscriber | 266d | 2001-03-02 A | 2002-03-08 A |  | 100% |  | 2001-03-02 | 2002-03-08 | 266d |  | finish no earlier than 2002-03-08 | N2 | 2128h | 2128h | CAMEL4-LOCB |  | WG |  |  |  |  |  | 2458 |
| 657 | 84.9 | Inclusion of ODB data in the CSE_HLR interface | 175d | 2001-07-09 A | 2002-03-08 A |  | 100% |  | 2001-07-09 | 2002-03-08 | 175d |  | finish no earlier than 2002-03-08 | N2 | 1400h | 1400h | CAMEL4-ODB |  | WG |  |  |  |  |  |  |
| 658 | 84.10 | Location information during an ongoing call (Handover DP) | 280d | 2001-05-14 A | 2002-06-07 A |  | 100% |  | 2001-05-14 | 2002-06-07 | 280d |  | finish no earlier than 2002-06-07 | N2 | 2240h | 2240h | CAMEL4-HODP |  | WG |  |  |  |  |  |  |
| 659 | 84.11 | GPRS Any Time Interrogation | 240d | 2001-07-09 A | 2002-06-07 A |  | 100% |  | 2001-07-09 | 2002-06-07 | 240d |  | finish no earlier than 2002-06-07 | N2 | 1920h | 1920h | CAMEL4-ATI |  | WG |  |  |  |  |  |  |
| 660 | 84.12 | Transfer of IMEI (with SW version) to CSE | 240d | 2001-07-09 A | 2002-06-07 A |  | 100% |  | 2001-07-09 | 2002-06-07 | 240d |  | finish no earlier than 2002-06-07 | N2 | 1920h | 1920h | CAMEL4-ATI |  | WG |  |  |  |  |  |  |
| 661 | 84.13 | Handling of partial implementations of CAMEL4 | 131d | 2002-03-08 A | 2002-09-06 A |  | 100% |  | 2002-03-08 | 2002-06-07 | 66d |  | finish no earlier than 2002-06-07 | N2 | 1048h | 1048h | CAMEL4-SUB |  | WG |  |  |  |  |  |  |

Notes:
- 627: For Rel5 even if completed by March
- 634: CR to correct security specifications in 29.198 scheduled for approval at CN#15
- 636: ??
- 644: az: CN#13 - changed to Rel5
- 646: az 24/05/01: Rel4 completion 90->100%.
- 657: Added on May 29, 2001
- 661: stage2 and stage3 CRs for approval at CN#17

| ID | WBS | Task | Type | Duration | Start | Finish | Predecessors | Complete | Remaining | Baseline start | Baseline finish | Baseline duration | Total slack | Constraint | Resources | Work | Actual work | Text1 | Text2 | Text6 | Text7 | Text8 | Text9 | Text3 | Text4 | Text5 |
| --- | --- | --- | --- | --- | --- | --- | --- | --- | --- | --- | --- | --- | --- | --- | --- | --- | --- | --- | --- | --- | --- | --- | --- | --- | --- | --- |
| 662 | 85 | **Rel-5 MExE enhancements** |  | 250d | 2001-03-26 A | 2002-03-08 A |  | 100% |  | 2001-02-21 | 2002-06-20 | 347d |  |  | T2 | 2880h | 2880h | MEXE5 | Ter | Rel5 | TSG | Friedhelm | 2464 |  |  |  |
| 663 | 85.1 | MExE Rel-5 Improvements and Investigations |  | 110d | 2001-03-26 A | 2002-03-08 A |  | 100% |  | 2001-03-26 | 2002-03-08 | 110d |  | finish no earlier than 2001-12-17 | T2 | 880h | 880h | MEXE5-ENHANC | Ter |  | TSG |  | 2466 | 22.057, 23.057 | Mark CATALDO, Motorola | mcatald1@MOTOROLA.COM |
| 664 | 86 | **Wideband Telephony Service - AMR** |  | 1035d | 2000-01-01 A | 2003-12-19 |  | 83% | 179.73d | 2000-01-01 | 2002-12-02 | 761d | 95d |  | S4 | 83992h | 65964.1h | AMRWB |  | Rel5 | TSG | Paolo |  |  | Imre Varga, Siemens AG | Imre.Varga@mch.siemens.de |
| 665 | 86.1 | **Specification** |  | 704d | 2000-01-01 A | 2002-09-12 |  | 99% | 0.4d | 2000-01-01 | 2002-06-28 | 650d | 426d |  | S4 | 22512h | 22481.9h |  |  |  |  |  |  |  |  |  |
| 666 | 86.1.1 | Stage 1 |  | 125d | 2001-10-01 A | 2002-03-22 A |  | 100% |  | 2001-10-01 | 2002-03-22 | 125d |  | finish no earlier than 2002-03-22 | S1 | 1000h | 1000h |  |  |  |  |  |  |  |  |  |
| 667 | 86.1.2 | **Stage 2** |  | 76d | 2000-01-03 A | 2000-04-17 A |  | 100% |  | 2000-01-03 | 2000-04-17 | 76d |  |  | S4 | 1224h | 1224h |  |  |  |  |  |  |  |  |  |
| 668 | 86.1.2.1 | Design Constraints |  | 26d | 2000-01-03 A | 2000-02-07 A |  | 100% |  | 2000-01-03 | 2000-02-07 | 26d |  |  | S4 | 208h | 208h |  | Cod |  |  |  | 1459 |  |  |  |
| 669 | 86.1.2.2 | General Description |  | 51d | 2000-02-07 A | 2000-04-17 A | 668 | 100% |  | 2000-02-07 | 2000-04-17 | 51d |  | start no earlier than 2000-09-25 | S4 | 408h | 408h |  | Cod |  |  |  | 1460 |  |  |  |
| 670 | 86.1.3 | Feasibility Study |  | 26d | 2000-04-28 A | 2000-06-02 A | 669 | 100% |  | 2000-04-28 | 2000-06-02 | 26d |  | finish no earlier than 2000-06-02 | S4 | 208h | 208h |  | Cod |  | TSG |  | 1626 | TR 26.901 |  |  |
| 671 | 86.1.4 | N1 Aspects |  | 66d | 2001-09-21 A | 2001-12-21 A |  | 100% |  | 2001-09-21 | 2001-12-21 | 66d |  | finish no earlier than 2001-12-21 | N1 | 528h | 528h |  |  |  | TSG |  | 1656 |  |  |  |
| 672 | 86.1.5 | N4 work |  | 83d | 2002-02-13 A | 2002-06-07 A |  | 100% |  | 2002-02-13 | 2002-06-07 | 83d |  | finish no earlier than 2002-06-07 | N4 | 664h | 664h |  |  |  | TSG |  | 1656 |  |  |  |
| 673 | 86.1.6 | **Codec issues** |  | 704d | 2000-01-03 A | 2002-09-12 |  | 99% | 0.54d | 2000-01-03 | 2002-06-28 | 650d | 426d |  | S4 | 11504h | 11496h |  |  |  |  |  |  |  |  |  |
| 674 | 86.1.6.1 | Codec qualification |  | 86d | 2000-02-01 A | 2000-05-30 A |  | 100% |  | 2000-02-01 | 2000-05-30 | 86d |  | finish no earlier than 2000-05-31 | S4 | 688h | 688h |  | Cod |  | TSG |  | 1627 |  |  |  |
| 675 | 86.1.6.2 | Codec selection tests |  | 102d | 2000-06-01 A | 2000-10-20 A | 674 | 100% |  | 2000-06-01 | 2000-10-20 | 102d |  | finish no earlier than 2000-10-20 | S4 | 816h | 816h |  | Cod |  |  |  | 74 |  |  |  |
| 676 | 86.1.6.3 | Codec selection |  | 5d | 2000-10-23 A | 2000-10-27 A | 675 | 100% |  | 2000-10-23 | 2000-10-27 | 5d |  | finish no earlier than 2000-10-27 | S4 | 40h | 40h |  | Cod |  |  |  | 891 |  |  |  |
| 677 | 86.1.6.4 | TFO AMR-WB |  | 63d | 2001-12-18 A | 2002-03-14 A |  | 100% |  | 2001-12-18 | 2002-03-14 | 63d |  | finish no earlier than 2002-03-14 | S4 | 504h | 504h | AMRWB-TFO |  |  |  |  |  |  |  |  |
| 678 | 86.1.6.5 | Other codec issues (verif., caracterisation) |  | 441d | 2000-09-29 A | 2002-06-07 A |  | 100% |  | 2000-09-29 | 2002-06-07 | 441d |  | finish no earlier than 2002-06-07 | S4 | 3528h | 3528h |  | Cod |  |  |  | 890 | TR 26.976 |  |  |
| 679 | 86.1.6.6 | AMR-WB and narrrowband interworking |  | 121d | 2001-09-27 A | 2002-03-14 A |  | 100% |  | 2001-09-27 | 2002-03-14 | 121d |  | finish no earlier than 2002-03-14 | S4 | 968h | 968h | AMRWB-IWG |  |  |  |  |  |  |  |  |
| 680 | 86.1.6.7 | Interworking with fixed broadband networks |  | 121d | 2001-09-27 A | 2002-03-14 A |  | 100% |  | 2001-09-27 | 2002-03-14 | 121d |  | finish no earlier than 2002-03-14 | S4 | 968h | 968h |  |  |  |  |  |  |  |  |  |
| 681 | 86.1.6.8 | Tones and announcements |  | 121d | 2001-09-27 A | 2002-03-14 A |  | 100% |  | 2001-09-27 | 2002-03-14 | 121d |  | finish no earlier than 2002-03-14 | S4 | 968h | 968h |  |  |  |  |  |  |  |  |  |
| 682 | 86.1.6.9 | WB Conferencing and WB Voice Group calls |  | 1d | 2000-01-03 | 2000-01-03 |  |  |  | 2000-01-03 | 2000-01-03 | 1d | 1129d | finish no earlier than 2000-01-03 | S1 | 8h |  |  |  |  |  |  |  |  |  |  |
| 683 | 86.1.6.10 | Billing, accounting and call detail record aspects |  | 251d | 2001-09-27 A | 2002-09-12 A |  | 100% |  | 2001-09-27 | 2002-06-28 | 197d |  | finish no earlier than 2002-09-12 | S5 | 2008h | 2008h |  |  | Rel5 |  |  |  | 32.2xy | Karl-Heinz NENNER (T-Mobile) | Karl-Heinz.Nenner@T-MOBILE.DE |
| 684 | 86.1.7 | Start Testing | milestone | 0d | 2002-02-25 | 2002-02-25 |  |  |  | 2002-02-25 | 2002-02-25 | 0d | 570d | start no earlier than 2002-02-25 | MLST |  |  |  |  |  |  |  | 1989 |  |  |  |
| 685 | 86.1.8 | **Conformance tests (CRs to 34 series)** |  | 73d | 2000-01-01 A | 2000-04-12 A | 684 | 100% |  | 2000-01-01 | 2000-04-12 | 73d |  |  | T1 | 1752h | 1752h |  | Cod |  |  |  | 1855 |  |  |  |
| 686 | 86.1.8.1 | **Terminal Acoustic Characteristics** |  | 73d | 2000-01-01 A | 2000-04-12 A |  | 100% |  | 2000-01-01 | 2000-04-12 | 73d |  |  | S4 | 1168h | 1168h |  | Cod |  |  |  | 76 |  |  |  |
| 687 | 86.1.8.1.1 | Definition |  | 21d | 2000-01-01 A | 2000-01-31 A |  | 100% |  | 2000-01-01 | 2000-01-31 | 21d |  | finish no earlier than 2000-01-28 | S4 | 168h | 168h |  | Cod |  | TSG |  | 1628 | 26.131 |  |  |
| 688 | 86.1.8.1.2 | Test specification |  | 52d | 2000-02-01 A | 2000-04-12 A | 687 | 100% |  | 2000-02-01 | 2000-04-12 | 52d |  | finish no earlier than 2000-03-13 | S4 | 416h | 416h |  | Cod |  | TSG |  | 1629 | 26.132 |  |  |
| 689 | 86.2 | Floating-point ANSI-C code for the AMR-WB speech codec |  | 123d | 2001-09-25 A | 2002-03-14 A |  | 100% |  | 2001-09-25 | 2002-03-14 | 123d |  | finish no earlier than 2002-03-14 | S4 | 984h | 984h | AMRWB-FP |  |  | TSG |  |  | TS 26.204 | J. Vainio (Nokia) | janne.m.vainio@nokia.com |

Notes:
- 670: S4,TD SP-000024: TR 26.901 v.4.0.0
- 671: Some of N1 tasks: Indication of supported codecs by the MS, Bearer cap negociation, codec indication to MS... / One common set of codec negotiation procedures will be specified as in ID1657.
- 672: CN4#11 30/11/01: No inputs to CN4 at this meeting / 14/02/02 work started 50% reached / 17 May work is done 100%
- 678: ANSI C-Code , Test Sequences, Speech Transcoding Functions, Error Concealment of lost frames, Source Controlled Bit-Rate Operation, Voice Activity Detector, Frame Structure

| ID | WBS | Task | Duration | Start | Finish | Complete | Remaining | Baseline start | Baseline finish | Baseline duration | Total slack | Constraint | Resources | Work | Actual work | Text1 | Text2 | Text7 | Text8 | Text9 | Text3 | Text4 | Text5 | Text6 |
| --- | --- | --- | --- | --- | --- | --- | --- | --- | --- | --- | --- | --- | --- | --- | --- | --- | --- | --- | --- | --- | --- | --- | --- | --- |
| 690 | 86.3 | **Support of AMR-WB in GERAN: GMSK and 8PSK WB FR / HR** | 650d | 2000-01-03 A | 2002-06-28 A | 100% |  | 2000-01-03 | 2002-06-28 | 650d |  |  | GP | 23480h | 23480h | GAMRWB | Cod | TSG | Paolo | 80 |  |  |  |  |
| 691 | 86.3.1 | Channel coding in 45.003 | 590d | 2000-01-03 A | 2002-04-05 A | 100% |  | 2000-01-03 | 2002-04-05 | 590d |  |  | GP | 4720h | 4720h |  |  | TSG |  | 2265 |  |  |  |  |
| 692 | 86.3.2 | Signalling for the A interface | 390d | 2000-01-03 A | 2001-06-29 A | 100% |  | 2000-01-03 | 2001-06-29 | 390d |  | finish no earlier than 2001-06-29 | GP | 3120h | 3120h |  |  | TSG |  | 2266 |  |  |  |  |
| 693 | 86.3.3 | Signalling for Iu | 650d | 2000-01-03 A | 2002-06-28 A | 100% |  | 2000-01-03 | 2002-06-28 | 650d |  | finish no earlier than 2002-06-28 | GP | 5200h | 5200h |  |  | TSG |  | 2267 |  |  |  |  |
| 694 | 86.3.4 | Receiver performance in TS 45.005 | 325d | 2001-04-02 A | 2002-06-28 A | 100% |  | 2001-04-02 | 2002-06-28 | 325d |  | finish no earlier than 2002-06-28 | GP | 2600h | 2600h |  |  | TSG |  | 2268 |  |  |  |  |
| 695 | 86.3.5 | Link Adaptation in 45.009 | 330d | 2001-03-26 A | 2002-06-28 A | 100% |  | 2001-03-26 | 2002-06-28 | 330d |  | finish no earlier than 2002-06-28 | GP | 2640h | 2640h |  |  |  |  |  |  |  |  |  |
| 696 | 86.4 | **GERAN MS conformance test for AMR-WB** | 1035d | 2000-01-03 | 2003-12-19 |  |  | 2000-01-03 | 2002-12-02 | 761d | 95d |  | GP | 16560h |  |  |  | TSG | Paolo | 2269 |  |  |  |  |
| 697 | 86.4.1 | MS test | 1035d | 2000-01-03 | 2003-12-19 |  |  | 2000-01-03 | 2002-12-02 | 761d | 95d | finish no earlier than 2003-12-19 | GP | 8280h |  |  |  | TSG |  | 2270 |  |  |  |  |
| 698 | 86.5 | **GERAN BTS conformance test for AMR-WB** | 761d | 2000-01-03 A | 2002-12-02 A | 100% |  | 2000-01-03 | 2002-12-02 | 761d |  |  | GP | 12176h | 12176h |  |  | TSG | Paolo | 2271 |  |  |  |  |
| 699 | 86.5.1 | BTS test | 761d | 2000-01-03 A | 2002-12-02 A | 100% |  | 2000-01-03 | 2002-12-02 | 761d |  | finish no earlier than 2002-12-02 | GP | 6088h | 6088h |  |  | TSG |  | 2272 |  |  |  |  |
| 700 | 87 | Terminal local model enhancements | 223d | 2001-05-14 A | 2002-03-20 A | 100% |  | 2001-05-14 | 2002-03-20 | 223d |  | finish no earlier than 2002-03-20 | T2 | 1784h | 1784h | TLM5 | Ter | TSG |  | 1832 | 23.227 | Olga Tomé, Ericsson | Olga.Tome@ECS.ERICSSON.SE | Rel5 |
| 701 | 88 | **Rel-5 Location Services enhancements** | 845d | 2000-04-03 A | 2003-06-27 | 80% | 167.61d | 2000-04-03 | 2003-06-30 | 846d | 220d |  | S2 | 175255h | 147009h | LCS1 |  | TSG | Alain |  |  | Jan Kall, Nokia |  | Rel5 |
| 702 | 88.1 | **UE positioning** | 315d | 2001-01-15 A | 2002-03-29 | 99% | 0d | 2000-08-28 | 2003-06-30 | 741d | 0d |  | RP | 5560h | 5368.13h | LCS1-UEpos |  | TSG |  | 1600 |  |  |  | NA |
| 703 | 88.1.1 | UE positioning enhancements for 1.28 Mcps TDD | 255d | 2001-04-09 A | 2002-03-29 A | 100% |  | 2001-04-09 | 2002-03-29 | 255d |  | finish no earlier than 2002-03-29 | R2 | 2040h | 2040h | LCS-128Pos |  | TSG |  | 2474 |  | Xiaohua Mei, CATT |  | Rel5 |
| 704 | 88.1.2 | Open SMLC-SRNC Interface within the UTRAN to support A-GPS Positioning | 195d | 2001-01-15 A | 2001-10-12 A | 100% |  | 2001-01-15 | 2001-10-12 | 195d |  |  | R2 | 1560h | 1560h | LCS-INTF |  | TSG |  | 2125 |  | Kirk Burroughs, Qualcomm |  | Rel5 |
| 705 | 88.2 | **Event based and Periodic LCS** | 535d | 2000-05-22 A | 2002-06-07 | 88% | 62.67d | 2000-05-22 | 2002-06-07 | 535d | 495d |  | S1 | 6288h | 5551.48h | LCS1-EBP | Loc |  |  | 1171 |  |  |  | Rel5 |
| 706 | 88.2.1 | Stage 1 | 130d | 2000-05-22 A | 2000-11-17 A | 100% |  | 2000-05-22 | 2000-11-17 | 130d |  | finish no earlier than 2000-07-21 | S1 | 1040h | 1040h |  | Loc |  |  | 1641 | 22.071 | Randolph Wohlert, Pacific Bell Wireless | rwohlert@tri.sbc.com |  |
| 707 | 88.2.2 | Stage 2 specification | 60d | 2000-11-06 A | 2001-01-26 | 51% | 29.4d | 2000-11-06 | 2001-01-26 | 60d | 850d | finish no earlier than 2001-01-26 | S2 | 480h | 244.8h |  | Loc |  |  | 1538 |  |  |  |  |
| 708 | 88.2.3 | Impact on MAP | 61d | 2002-03-15 A | 2002-06-07 A | 100% |  | 2002-03-15 | 2002-06-07 | 61d |  | finish no earlier than 2002-06-07 | N4 | 488h | 488h |  | Loc |  |  | 1179 |  |  |  |  |
| 709 | 88.3 | **Location Services for GERAN in A/Gb Mode** | 485d | 2000-04-03 A | 2002-02-08 A | 100% |  | 2000-04-03 | 2002-02-08 | 485d |  |  | GP | 24032h | 24032h | LCS-GERAN |  | TSG | Paolo | 2436 |  |  |  | Rel5 |
| 710 | 88.3.1 | GERAN LCS Stage 2 (first release) | 485d | 2000-04-03 A | 2002-02-08 A | 100% |  | 2000-04-03 | 2002-02-08 | 485d |  | finish no earlier than 2002-02-08 | GP; S2; G1; G2 | 13152h | 13152h |  |  | TSG |  | 2437 |  |  |  |  |
| 711 | 88.3.2 | Gb interface support for LCS | 370d | 2000-04-03 A | 2001-08-31 A | 100% |  | 2000-04-03 | 2001-08-31 | 370d |  | finish no earlier than 2001-08-31 | GP | 2960h | 2960h |  |  | TSG |  | 2438 |  |  |  |  |
| 712 | 88.3.3 | L3 protocol support for LCS | 305d | 2000-04-03 A | 2001-06-01 A | 100% |  | 2000-04-03 | 2001-06-01 | 305d |  | finish no earlier than 2001-06-01 | GP | 2440h | 2440h |  |  | TSG |  | 2440 |  |  |  |  |
| 713 | 88.3.4 | Stage 3 specifications | 305d | 2000-04-03 A | 2001-06-01 A | 100% |  | 2000-04-03 | 2001-06-01 | 305d |  | finish no earlier than 2001-06-01 | GP | 2440h | 2440h |  |  | TSG |  | 2441 |  |  |  |  |

Notes:
- 696: Not started
- 704: Finished at RAN#13
- 706: Evaluate Event based and Periodic LCS to be included in R00, corresponding Stage 1 description
- 708: Possible impact on UTRAN of LCS quality level request / 17 May No stage 2 for event-based & periodic LCS. Work 100% completefor current stage 2

| ID | WBS | Task | Duration | Start | Finish | Complete | Remaining | Baseline start | Baseline finish | Baseline duration | Total slack | Constraint | Resources | Work | Actual work | Text6 | Text7 | Text8 | Text9 | Text1 | Text2 | Text3 | Text5 |
| --- | --- | --- | --- | --- | --- | --- | --- | --- | --- | --- | --- | --- | --- | --- | --- | --- | --- | --- | --- | --- | --- | --- | --- |
| 714 | 88.4 | **Location Services for GERAN in Iu Mode** | 585d | 2000-04-03 A | 2002-06-28 A | 100% |  | 2000-04-03 | 2002-06-28 | 585d |  |  | GP | 78498.6h | 78498.6h | Rel5 | TSG | Paolo |  |  |  |  |  |
| 715 | 88.4.1 | GERAN LCS Stage 2 | 585d | 2000-04-03 A | 2002-06-28 A | 100% |  | 2000-04-03 | 2002-06-28 | 585d |  | finish no earlier than 2002-06-28 | GP; R2; R3; S2; G1; G2 | 22880.9h | 22880.9h |  | TSG |  | 2443 |  |  |  |  |
| 716 | 88.4.2 | Iu-ps interface support for LCS | 585d | 2000-04-03 A | 2002-06-28 A | 100% |  | 2000-04-03 | 2002-06-28 | 585d |  | finish no earlier than 2002-06-28 | GP; R2; R3; S2; G1; G2 | 19000.9h | 19000.9h |  | TSG |  |  |  |  |  |  |
| 717 | 88.4.3 | Iu-cs interface support for LCS | 585d | 2000-04-03 A | 2002-06-28 A | 100% |  | 2000-04-03 | 2002-06-28 | 585d |  | finish no earlier than 2002-06-28 | GP; R2; R3; S2; G1; G2 | 19000.9h | 19000.9h |  | TSG |  | 2445 |  |  |  |  |
| 718 | 88.4.4 | Iur-g interface support for LCS | 62.5d | 2002-01-23 A | 2002-04-19 A | 100% |  | 2002-01-23 | 2002-04-19 | 62.5d |  | finish no earlier than 2002-04-19 | GP; R2; R3; S2; G1; G2 | 3000h | 3000h |  | TSG |  | 2446 |  |  |  |  |
| 719 | 88.4.5 | RRC protocol support for LCS | 75d | 2001-08-20 A | 2001-11-30 A | 100% |  | 2001-08-20 | 2001-11-30 | 75d |  | finish no earlier than 2001-11-30 | GP; R2; R3; S2; G1; G2 | 3600h | 3600h |  | TSG |  | 2447 |  |  |  |  |
| 720 | 88.4.6 | Additional impacts on Broadcast of LCS data on packet channels | 77.5d | 2001-08-20 A | 2001-12-05 A | 100% |  | 2001-08-20 | 2001-12-05 | 77.5d |  | finish no earlier than 2001-12-05 | GP; R2; R3; S2; G1; G2 | 3000h | 3000h |  | TSG |  | 2448 |  |  |  |  |
| 721 | 88.4.7 | Stage 3 specifications | 69.5d | 2002-03-25 A | 2002-06-28 A | 100% |  | 2002-03-25 | 2002-06-28 | 69.5d |  | finish no earlier than 2002-06-28 | GP; R2; R3; S2; G1; G2 | 3336h | 3336h |  | TSG |  | 2449 |  |  |  |  |
| 722 | 88.5 | **GERAN MS Conformance test for LCS** | 280d | 2002-06-03 A | 2003-06-27 | 60% | 112d | 2001-11-30 | 2002-12-02 | 262d | 220d |  | GP | 11200h | 6720h |  |  |  |  | LCS-GERAN-MSconf |  |  |  |
| 723 | 88.5.1 | Develop LCS MS test case work plan (Release 98/99/4) | 280d | 2002-06-03 A | 2003-06-27 | 60% | 112d | 2001-11-30 | 2002-12-02 | 262d | 220d | finish no earlier than 2003-06-27 | G4; G5 | 4480h | 2688h |  |  |  |  |  |  |  |  |
| 724 | 88.5.2 | Develop LCS MS test cases | 280d | 2002-06-03 A | 2003-06-27 | 60% | 112d | 2001-11-30 | 2002-12-02 | 262d | 220d | finish no earlier than 2003-06-27 | G4; G5 | 4480h | 2688h |  |  |  |  |  |  |  |  |
| 725 | 88.6 | **GERAN BTS Conformance test for LCS** | 280d | 2002-06-03 | 2003-06-27 |  |  | 2001-11-30 | 2002-12-02 | 262d | 220d |  | GP | 11200h |  |  |  |  |  | LCS-GERAN-BTSconf |  |  |  |
| 726 | 88.6.1 | Develop LCS BTS test case work plan (Release 98/99/4) | 280d | 2002-06-03 | 2003-06-27 |  |  | 2001-11-30 | 2002-12-02 | 262d | 220d | finish no earlier than 2003-06-27 | G4; G5 | 4480h |  |  |  |  |  |  |  |  |  |
| 727 | 88.6.2 | Develop LCS BTS test cases | 280d | 2002-06-03 | 2003-06-27 |  |  | 2001-11-30 | 2002-12-02 | 262d | 220d | finish no earlier than 2003-06-27 | G4; G5 | 4480h |  |  |  |  |  |  |  |  |  |
| 728 | 88.7 | LCS interoperation stage 2 aspects | 480d | 2000-08-28 A | 2002-06-28 | 17% | 400.8d | 2000-08-28 | 2002-06-28 | 480d | 480d |  | S2 | 3840h | 633.6h |  |  |  | 544 |  | Loc |  |  |
| 729 | 88.8 | **LCS interoperability aspects to GERAN** | 480d | 2000-08-28 A | 2002-06-28 A | 100% |  | 2000-08-28 | 2002-06-28 | 480d |  |  | GP | 19632h | 19632h | Rel5 | TSG | Paolo | 2434 | LCS-GERAN |  |  |  |
| 730 | 88.8.1 | Co-ordinated development of GSM LCS Phase 2 and UMTS LCS, S2 and GERAN | 480d | 2000-08-28 A | 2002-06-28 A | 100% |  | 2000-08-28 | 2002-06-28 | 480d |  | finish no earlier than 2002-06-28 | GP; S2; S5; R2; R3; G2; G1 | 15792h | 15792h |  | TSG |  | 2435 | LCS-GERAN |  |  |  |
| 731 | 88.9 | FS on LCS support in the IMS | 90d | 2001-02-12 A | 2002-01-18 | 28% | 65d | 2001-02-12 | 2002-01-18 | 90d | 595d | start no earlier than 2001-02-12 | S1 | 720h | 200h |  |  |  | 1183 |  | Loc |  |  |
| 732 | 88.10 | Charging and OAM&P for LCS enhancements | 201d | 2001-09-21 A | 2002-06-28 A | 100% |  | 2001-09-21 | 2002-06-28 | 201d |  | finish no earlier than 2002-06-28 | S5 | 1608h | 1608h | Rel5 | TSG |  | 519 | LCS1-OAM |  | 32-series | Albert.Yuhan@voicestream.com; Michael.Truss@MOTOROLA.COM |
| 733 | 88.11 | New security aspects of LCS (not identified) | 446d | 2000-04-14 A | 2001-12-28 A | 100% |  | 2000-04-14 | 2001-12-28 | 446d |  | finish no earlier than 2001-12-28 | S3 | 3568h | 3568h | Rel5 |  |  | 521 | LCS1-SEC | Loc |  | valtteri.niemi@nokia.com |
| 734 | 88.12 | Specification for the Le Interface | 45d | 2002-01-14 A | 2002-03-15 A | 100% |  | 2002-01-14 | 2002-03-15 | 45d |  | start no earlier than 2002-01-14 | S2 | 360h | 360h | Rel5 | TSG |  |  | LCS1-Le |  |  |  |
| 735 | 88.13 | CHECK STATUS - Inter-GMLC interface | 153d | 2002-05-30 | 2002-12-30 |  |  | 2002-05-30 | 2002-12-30 | 153d | 349d | finish no earlier than 2002-12-30 | S2 | 1224h |  |  |  |  |  |  |  |  |  |
| 736 | 89 | **Rel-5 Security enhancements** | 615d | 2000-02-21 A | 2002-06-28 | 99% | 4.24d | 2000-01-03 | 2002-12-06 | 765d | 480d |  | S3 | 29974.9h | 28337.4h | NA | TSG | Maurice |  | SEC1 |  |  | Peter.Howard@vodafone.com |
| 737 | 89.1 | **Network domain security** | 615d | 2000-02-21 A | 2002-06-28 | 99% | 4.24d | 2000-02-21 | 2002-06-28 | 615d | 480d |  | S3 | 25054.9h | 23451.3h | Rel5 | TSG |  | 1576 | SEC1-NDS | Sec |  | Geir-myrdahl.koien@telenor.com |
| 738 | 89.1.1 | **Control plane protection in core network (e.g., GTP, CAP, MAP/IP, provided by IPsec)** | 541d | 2000-05-12 A | 2002-06-07 | 99% | 0d | 2000-05-12 | 2002-06-07 | 541d | 0d |  | S3 | 7118.9h | 5722.99h |  |  |  | 1577 |  | Sec |  |  |
| 739 | 89.1.1.1 | Main aspects | 290d | 2000-05-12 A | 2001-06-21 A | 100% |  | 2000-05-12 | 2001-06-21 | 290d |  | finish no earlier than 2001-06-21 | S3 | 2320h | 2320h |  |  |  | 1578 |  | Sec |  |  |
| 740 | 89.1.1.2 | Integration of GTP signalling security architecture | 191d | 2001-09-14 A | 2002-06-07 A | 100% |  | 2001-09-14 | 2002-06-07 | 191d |  | finish no earlier than 2002-06-07 | N4 | 1528h | 1528h |  |  |  | 1579 |  | Sec |  |  |

Notes:
- 718: FFS
- 722: On-going
- 725: Not started
- 732: Text4: Albert YUHAN (VoiceStream Wireless), Michael TRUSS (Motorola)
- 733: 14/09/00: End date 28/12/01 WI may need to be split to improve on this date. S3#17 15% complete. No progress since S3#17 / Text4: Valtteri Niemi, Nokia
- 736: Added BB UE authentication and rapporteur added. TO BE DELETED / Text4: Peter Howard, Vodafone
- 737: S3#17: All due in Rel5. (WI Update at S3#18). Replaced by NDS-IP and NDS-MAP. TO BE DELETED OR MOVED TO HISTORY FILE / Text4: Geir M. Køien, Telenor
- 739: TO BE DELETED
- 740: Waiting for input from SA3! / 14/02/2002 requirements are not clear/not received / 17 May 100% complete

| ID | WBS | Task | Duration | Start | Finish | Predecessors | Complete | Remaining | Baseline start | Baseline finish | Baseline duration | Total slack | Constraint | Resources | Work | Actual work | Text2 | Text9 | Text1 | Text3 | Text5 | Text7 | Text6 | Text8 |
| --- | --- | --- | --- | --- | --- | --- | --- | --- | --- | --- | --- | --- | --- | --- | --- | --- | --- | --- | --- | --- | --- | --- | --- | --- |
| 741 | 89.1.2 | **User plane protection in core network (e.g., provided by IPsec)** | 615d | 2000-02-21 A | 2002-06-28 |  | 98% | 11.41d | 2000-02-21 | 2002-06-28 | 615d | 480d |  | S3 | 9360h | 9186.29h | Sec | 1580 |  |  |  |  |  |  |
| 742 | 89.1.2.1 | Main aspects | 349d | 2000-02-21 A | 2001-06-21 A |  | 100% |  | 2000-02-21 | 2001-06-21 | 349d |  | finish no earlier than 2001-06-21 | S3 | 2792h | 2792h | Sec | 1581 |  |  |  |  |  |  |
| 743 | 89.1.2.2 | Integration of GTP signalling security architecture | 206d | 2001-09-14 A | 2002-06-28 |  | 95% | 10.3d | 2001-09-14 | 2002-06-28 | 206d | 480d | finish no earlier than 2002-06-28 | N4 | 1648h | 1565.6h | Sec | 1582 |  |  |  |  |  |  |
| 744 | 89.1.3 | IP network layer security (NDS/IP) | 457d | 2000-06-15 A | 2002-03-15 A |  | 100% |  | 2000-06-15 | 2002-03-15 | 457d |  | finish no earlier than 2002-03-15 | S3 | 3656h | 3656h |  |  | SEC1-NDS-IP | TS 33.210 | Geir-myrdahl.koien@telenor.com | WG |  |  |
| 745 | 90 | **Intra Domain Connection of RAN Nodes to Multiple CN Nodes** | 455d | 2000-10-02 A | 2002-06-28 A |  | 100% |  | 2000-01-03 | 2002-06-28 | 650d |  |  | S2 | 15136h | 15136h |  |  | IUFLEX | 23.236 |  | TSG | Rel5 | Alain |
| 746 | 90.1 | Overall System Architecture | 188d | 2001-01-03 A | 2001-09-21 A |  | 100% |  | 2001-01-03 | 2001-09-21 | 188d |  | finish no earlier than 2001-06-01 | S2 | 1504h | 1504h |  | 2244 |  |  |  | TSG |  |  |
| 747 | 90.2 | Stage 3: RAN node selecting CN node | 130d | 2001-09-24 A | 2002-03-22 A | 746 | 100% |  | 2001-09-24 | 2002-03-22 | 130d |  | finish no earlier than 2002-03-22 | R3 | 1040h | 1040h |  |  |  |  |  | TSG |  |  |
| 748 | 90.3 | N1 work | 205d | 2001-09-17 A | 2002-06-28 A |  | 100% |  | 2000-01-03 | 2001-03-14 | 313d |  | start no earlier than 2001-09-17 | N1 | 1640h | 1640h |  |  |  | 24.008 and check 29.018 |  | TSG |  |  |
| 749 | 90.4 | N4 work | 375d | 2000-10-02 A | 2002-03-08 A |  | 100% |  | 2000-10-02 | 2002-03-08 | 375d |  | finish no earlier than 2002-03-15 | N4 | 3000h | 3000h |  | 2249 |  |  |  | TSG |  |  |
| 750 | 90.5 | **GERAN work for Intra Domain Connection of RAN Nodes to Multiple CN Nodes** | 101d | 2002-02-08 A | 2002-06-28 A |  | 100% |  | 2002-02-08 | 2002-06-28 | 101d |  |  | GP | 4848h | 4848h |  |  | IDCRAN-GERAN |  | ingemar.backlund@era.ericsson.se |  | Rel5 |  |
| 751 | 90.5.1 | Stage 2 (changes to ) | 101d | 2002-02-08 A | 2002-06-28 A |  | 100% |  | 2002-02-08 | 2002-06-28 | 101d |  | finish no earlier than 2002-06-28 | G1 | 808h | 808h |  |  |  |  |  |  |  |  |
| 752 | 90.5.2 | 43.051 Introduction of support for IDNNS in GERAN Iu mode | 101d | 2002-02-08 A | 2002-06-28 A |  | 100% |  | 2002-02-08 | 2002-06-28 | 101d |  | finish no earlier than 2002-06-28 | G1 | 808h | 808h |  |  |  |  |  |  |  |  |
| 753 | 90.5.3 | Stage 3 (changes to ) | 101d | 2002-02-08 A | 2002-06-28 A |  | 100% |  | 2002-02-08 | 2002-06-28 | 101d |  | finish no earlier than 2002-06-28 | G2 | 808h | 808h |  |  |  |  |  |  |  |  |
| 754 | 90.5.4 | 48.016 Use of Gb interface concepts when a network applies IDNNS | 101d | 2002-02-08 A | 2002-06-28 A |  | 100% |  | 2002-02-08 | 2002-06-28 | 101d |  | finish no earlier than 2002-06-28 | G2 | 808h | 808h |  |  |  |  |  |  |  |  |
| 755 | 90.5.5 | 48.018 Include MSC/VLR identity in CS IMSI paging | 101d | 2002-02-08 A | 2002-06-28 A |  | 100% |  | 2002-02-08 | 2002-06-28 | 101d |  | finish no earlier than 2002-06-28 | G2 | 808h | 808h |  |  |  |  |  |  |  |  |
| 756 | 91 | **GERAN improvements 3 (new transport layer on interface A)** | 446d | 2001-04-06 | 2002-12-20 |  |  |  | 2001-04-06 | 2002-06-28 | 321d | 355d |  | GP | 14272h |  |  | 2320 | GEIMP3 |  |  | TSG | Rel5 | Paolo |
| 757 | 91.1 | **Evolution of the transport for A** | 446d | 2001-04-06 | 2002-12-20 |  |  |  | 2001-04-06 | 2002-06-28 | 321d | 355d |  | GP | 10704h |  |  | 2321 | GEIMP3-EtA |  |  | TSG |  | Paolo |
| 758 | 91.1.1 | Definition of a new A/Ater interface Transport Layer option based on the Iu Interface Transport Layer | 446d | 2001-04-06 | 2002-12-20 |  |  |  | 2001-04-06 | 2002-06-28 | 321d | 355d | finish no earlier than 2002-12-20 | GP | 3568h |  |  | 2322 |  |  |  | TSG |  |  |
| 759 | 91.1.2 | Adaptation of the Layer 3 BSSMAP procedures as required | 446d | 2001-04-06 | 2002-12-20 |  |  |  | 2001-04-06 | 2002-06-28 | 321d | 355d | finish no earlier than 2002-12-20 | GP | 3568h |  |  | 2323 |  |  |  | TSG |  |  |
| 760 | 92 | **Rel-5 Charging and OAM&P** | 264d | 2001-09-10 A | 2002-09-12 A |  | 100% |  | 2001-09-10 | 2002-06-28 | 210d |  |  | S5 | 9976h | 9976h |  |  | OAM | 32-series | Albert.Yuhan@voicestream.com; Michael.Truss@MOTOROLA.COM | TSG | NA | Adrian |
| 761 | 92.1 | Rel5 Principles, high level Requirements and Architecture | 205d | 2001-09-17 A | 2002-06-28 A |  | 100% |  | 2001-09-17 | 2002-06-28 | 205d |  | finish no earlier than 2002-06-28 | S5 | 1640h | 1640h | BCaM | 2089 | OAM-AR/PR | 32.101, 32.102 | Michael.Truss@MOTOROLA.COM | TSG | Rel5 |  |
| 762 | 92.2 | Rel5 Performance Management | 259d | 2001-09-17 A | 2002-09-12 A |  | 100% |  | 2001-09-17 | 2002-06-28 | 205d |  | finish no earlier than 2002-09-12 | S5 | 2072h | 2072h | BCaM | 2088 | OAM-PM | 32.4xy, 52.402 | toche@NORTELNETWORKS.COM | TSG | Rel5 |  |
| 763 | 92.3 | Rel5 Charging Management | 264d | 2001-09-10 A | 2002-09-12 A |  | 100% |  | 2001-09-10 | 2002-06-28 | 210d |  | finish no earlier than 2002-09-12 | S5 | 2112h | 2112h |  | 2083 | OAM-CH | 32.2xy | Karl-Heinz.Nenner@T-MOBILE.DE | TSG | Rel5 |  |
| 764 | 92.4 | Rel5 Network Infrastructure Management | 255d | 2001-09-21 A | 2002-09-12 A |  | 100% |  | 2001-09-21 | 2002-06-28 | 201d |  | finish no earlier than 2002-09-12 | S5 | 2040h | 2040h |  |  | OAM-NIM | 32.6xy, 32.3xy | Thomas.Tovinger@emw.ericsson.se | TSG | Rel5 |  |

Notes:
- 741: TO BE DELETED
- 742: ??
- 743: 14/02/2002 requirements are not clear/not received
- 744: TS 33.210 will be presented for info at SA#14 and is scheduled for approval at SA#15. 2002/12: All IPsec RFCs are stable STD Track RFCs. WID updated SA#17 / Text4: Geir M. Køien, Telenor
- 745: No clear indication on the end date. Put to Rel5 by AS. / Text4: Stephen Terrill, Ericsson
- 747: Not identified / Text4: Brendan McWilliams, Vodafone
- 749: DAB 12.12.01 - % complete to 66% / 14/02/02 Work completed
- 750: Accept changes Gb over IP / Text4: Ingemar Backlund, Ericsson
- 754: Closed, accept changes for Gb over IP
- 756: TERMINATED - NOT STANDARDIZED
- 757: TERMINATED - NOT STANDARDIZED
- 758: TERMINATED - NOT STANDARDIZED
- 759: TERMINATED - NOT STANDARDIZED
- 760: Text4: Albert YUHAN (VoiceStream Wireless), Michael TRUSS (Motorola)
- 761: Text4: Michael TRUSS (Motorola)
- 762: Text4: Christian TOCHE (Nortel Networks)
- 763: Text4: Karl-Heinz NENNER (T-Mobile)
- 764: Text4: Thomas TOVINGER (Ericsson)

| ID | WBS | Task | Duration | Start | Finish | Predecessors | Complete | Remaining | Baseline start | Baseline finish | Baseline duration | Total slack | Constraint | Resources | Work | Actual work | Text6 | Text8 | Text9 | Text1 | Text5 | Text7 | Text2 |
| --- | --- | --- | --- | --- | --- | --- | --- | --- | --- | --- | --- | --- | --- | --- | --- | --- | --- | --- | --- | --- | --- | --- | --- |
| 765 | 93 | **GERAN enhancements for streaming services 1 (RLC enhancements)** | 430d | 2000-11-06 A | 2002-06-28 A |  | 100% |  | 2000-11-06 | 2002-06-28 | 430d |  |  | GP | 8944h | 8944h | Rel5 | Paolo | 2392 |  |  |  |  |
| 766 | 93.1 | Concept | 258d | 2000-11-06 A | 2001-10-31 A |  | 100% |  | 2000-11-06 | 2001-10-31 | 258d |  | finish no earlier than 2001-10-31 | GP | 2064h | 2064h |  |  | 2394 |  |  |  |  |
| 767 | 93.2 | RLC protocol enhancement (SDU Discard) | 430d | 2000-11-06 A | 2002-06-28 A |  | 100% |  | 2000-11-06 | 2002-06-28 | 430d |  | finish no earlier than 2002-06-28 | GP | 3440h | 3440h |  |  | 2395 |  |  |  |  |
| 768 | 94 | **GERAN enhancements for streaming services 2 (usage of ECSD)** | 430d | 2000-11-06 A | 2002-06-28 |  | 99% | 0d | 2000-11-06 | 2002-06-28 | 430d | 0d |  | GP | 19840h | 16400h | Rel5 | Paolo | 2396 |  |  |  |  |
| 769 | 94.1 | Usage of ECSD Concept | 380d | 2000-11-06 A | 2002-04-19 A |  | 100% |  | 2000-11-06 | 2002-04-19 | 380d |  | finish no earlier than 2002-04-19 | GP | 3040h | 3040h |  |  | 2398 |  |  |  |  |
| 770 | 94.2 | Stage 2 | 380d | 2000-11-06 A | 2002-04-19 A |  | 100% |  | 2000-11-06 | 2002-04-19 | 380d |  | finish no earlier than 2002-04-19 | GP | 3040h | 3040h |  |  | 2399 |  |  |  |  |
| 771 | 94.3 | Stage 3 | 430d | 2000-11-06 A | 2002-06-28 A |  | 100% |  | 2000-11-06 | 2002-06-28 | 430d |  | finish no earlier than 2002-06-28 | GP | 3440h | 3440h |  |  | 2400 |  |  |  |  |
| 772 | 94.4 | RLC PDU formats | 430d | 2000-11-06 A | 2002-06-28 A |  | 100% |  | 2000-11-06 | 2002-06-28 | 430d |  | finish no earlier than 2002-06-28 | GP | 3440h | 3440h |  |  | 2401 |  |  |  |  |
| 773 | 94.5 | MAC header | 430d | 2000-11-06 A | 2002-06-28 A |  | 100% |  | 2000-11-06 | 2002-06-28 | 430d |  | finish no earlier than 2002-06-28 | GP | 3440h | 3440h |  |  | 2402 |  |  |  |  |
| 774 | 95 | **GERAN/UTRAN interface evolution 1 (evolution of Iu PS)** | 476d | 2000-09-01 A | 2002-06-28 A |  | 100% |  | 2000-09-01 | 2002-06-28 | 476d |  |  | GP; R3 | 17825.6h | 17825.6h | Rel5 | Paolo | 2412 | GERUEV1 |  |  |  |
| 775 | 95.1 | **Evolution of Iu ps** | 476d | 2000-09-01 A | 2002-06-28 A |  | 100% |  | 2000-09-01 | 2002-06-28 | 476d |  |  | GP; R3 | 12205.6h | 12205.6h |  |  | 2413 | GERUEV1-IuPS |  |  |  |
| 776 | 95.1.1 | Identification of GERAN requirements on Iu ps | 326d | 2000-09-01 A | 2001-11-30 A |  | 100% |  | 2000-09-01 | 2001-11-30 | 326d |  | finish no earlier than 2001-11-30 | GP; R3 | 4185.6h | 4185.6h |  |  | 2414 |  |  |  |  |
| 777 | 95.1.2 | Update of specifications | 150d | 2001-12-03 A | 2002-06-28 A | 776 | 100% |  | 2001-12-03 | 2002-06-28 | 150d |  | finish no earlier than 2002-06-28 | GP; R3 | 2400h | 2400h |  |  | 2415 |  |  |  |  |
| 778 | 96 | **GERAN/UTRAN interface evolution 2 (evolution of Iu CS)** | 476d | 2000-09-01 A | 2002-06-28 A |  | 100% |  | 2000-09-01 | 2002-06-28 | 476d |  |  | GP; R3 | 23025.6h | 23025.6h | Rel5 | Paolo | 2416 | GERUEV2 |  |  |  |
| 779 | 96.1 | **Evolution of Iu cs** | 476d | 2000-09-01 A | 2002-06-28 A |  | 100% |  | 2000-09-01 | 2002-06-28 | 476d |  |  | GP; R3 | 17845.6h | 17845.6h |  | Paolo | 2417 | GERUEV2-IuCS |  |  |  |
| 780 | 96.1.1 | Identification of GERAN requirements on Iu cs | 426d | 2000-09-01 A | 2002-04-19 A |  | 100% |  | 2000-09-01 | 2002-04-19 | 426d |  | finish no earlier than 2002-04-19 | GP; R3 | 5049.6h | 5049.6h |  |  | 2418 |  |  |  |  |
| 781 | 96.1.2 | Update of specifications | 476d | 2000-09-01 A | 2002-06-28 A |  | 100% |  | 2000-09-01 | 2002-06-28 | 476d |  | finish no earlier than 2002-06-28 | GP; R3 | 7616h | 7616h |  |  | 2419 |  |  |  |  |
| 782 | 97 | **End to End QoS for PS Domain including IMS** | 480d | 2000-08-28 A | 2002-06-28 |  | 97% | 13.22d | 2000-08-28 | 2002-06-28 | 480d | 480d |  | S2 | 9856h | 9584.49h | Rel5 | Alain |  | E2EQoS | Johnson.oyama@era.ericcson.se | TSG |  |
| 783 | 97.1 | E2E QoSConcept and Architecture | 178d | 2001-01-03 A | 2001-09-07 A |  | 100% |  | 2001-01-03 | 2001-09-07 | 178d |  | finish no earlier than 2001-09-07 | S2 | 1424h | 1424h |  |  |  |  |  | TSG |  |
| 784 | 97.2 | E2E QoS interworking | 465d | 2000-08-28 A | 2002-06-07 |  | 95% | 23.25d | 2000-08-28 | 2002-06-07 | 465d | 495d | finish no earlier than 2002-06-07 | N3 | 3720h | 3534h |  |  |  | E2EQoS-IW | yokota@lucent.com | WG |  |
| 785 | 97.3 | QoS Management (Provisioning and Monitoring) | 201d | 2001-09-21 A | 2002-06-28 A |  | 100% |  | 2001-09-21 | 2002-06-28 | 201d |  | finish no earlier than 2002-06-28 | S5 | 1608h | 1608h | Rel5 |  |  | E2EQoS-OAM | Albert.Yuhan@voicestream.com; Michael.Truss@MOTOROLA.COM | TSG |  |
| 786 | 98 | **Messaging enhancements Rel-5** | 256d | 2001-06-15 A | 2002-06-07 |  | 75% | 65.08d | 2001-06-15 | 2002-06-07 | 256d | 495d |  | T2 | 13936h | 7742.17h | Rel5 | Friedhelm | 1818 | MESS5 |  | TSG | Mes |
| 787 | 98.1 | **Multimedia Messaging (MMS) enhancements** | 256d | 2001-06-15 A | 2002-06-07 |  | 73% | 69.18d | 2001-06-15 | 2002-06-07 | 256d | 495d |  | T2 | 8312h | 4579.2h |  |  | 1819 | MESS5-MMS | Josef.Laumen@SAL.SIEMENS.DE | TSG | Mes |
| 788 | 98.1.1 | Definition of service requirements | 196d | 2001-06-15 A | 2002-03-15 |  | 90% | 19.6d | 2001-06-15 | 2002-03-15 | 196d | 555d | finish no earlier than 2002-03-15 | S1 | 1568h | 1411.2h | Rel5 |  |  | MESS5-SR | Josef.Laumen@SAL.SIEMENS.DE |  |  |
| 789 | 98.1.2 | Technical realization | 256d | 2001-06-15 A | 2002-06-07 |  | 95% | 12.8d | 2001-06-15 | 2002-06-07 | 256d | 495d | finish no earlier than 2002-06-07 | T2 | 2048h | 1945.6h |  |  |  |  | Josef.Laumen@SAL.SIEMENS.DE |  |  |
| 790 | 98.1.3 | WAP Forum dependency: MM1 stage 3 | 256d | 2001-06-15 A | 2002-06-07 |  | 30% | 179.2d | 2001-06-15 | 2002-06-07 | 256d | 495d | finish no earlier than 2002-06-07 | T2 | 2048h | 614.4h |  |  |  |  |  |  |  |
| 791 | 98.1.4 | MMS formats and codecs | 75d | 2001-12-03 A | 2002-03-15 A |  | 100% |  | 2001-12-03 | 2002-03-15 | 75d |  | finish no earlier than 2002-03-15 | S4 | 600h | 600h |  |  |  |  |  |  |  |

Notes:
- 768: AWS, Nokia, Ericsson, Nortel, Siemens, Motorola, Vodafone / Text4: Frank Muller, Ericsson
- 774: SBC, Motorola, Nokia, Ericsson, Nortel / Text4: Marc Grant , SBC
- 779: Lucent, Ericsson, AWS, Nortel / Text4: Krishna Balachandran, Lucent
- 782: Text4: Johnson Oyama, Ericsson
- 783: Text3: 23.207
- 784: [DAB - 30/07/02] - % complete to 95% (if we exclude Diffserv) / Text3: 29.208, 29.207, 27.060, 29.061, 24.008, 24.228, , 24.229, 29.060, 29.163 / Text4: Daisuke Yokota, Lucent
- 785: Text3: 32-series / Text4: Albert YUHAN (VoiceStream Wireless), Michael TRUSS (Motorola)
- 786: support of UAProf, so this in my opinion is 100% complete
- 787: Text4: Josef Laumen, Siemens
- 788: Text3: 22.140 / Text4: Josef Laumen, Siemens
- 789: stage 3 MM7 is missing / Text3: 23.140 / Text4: Josef Laumen, Siemens
- 791: Text3: 26.140

| ID | WBS | Task | Duration | Start | Finish | Complete | Remaining | Baseline start | Baseline finish | Baseline duration | Total slack | Constraint | Resources | Work | Actual work | Text1 | Text2 | Text3 | Text4 | Text5 | Text7 | Text9 | Text6 | Text8 |
| --- | --- | --- | --- | --- | --- | --- | --- | --- | --- | --- | --- | --- | --- | --- | --- | --- | --- | --- | --- | --- | --- | --- | --- | --- |
| 792 | 98.2 | **Enhanced Messaging Service (EMS) enhancements** | 191d | 2001-06-15 A | 2002-03-08 | 79% | 39.24d | 2001-06-15 | 2002-03-08 | 191d | 560d |  | T2 | 3584h | 1641.6h | MESS5-EMS | Mes | 23.040 | Alan Baldwin, Ericsson | Alan.Baldwin@EML.ERICSSON.SE | TSG | 1820 |  |  |
| 793 | 98.2.1 | Definition of service requirements | 66d | 2001-06-15 A | 2001-09-14 | 20% | 52.8d | 2001-06-15 | 2001-09-14 | 66d | 685d | finish no earlier than 2001-09-14 | S1 | 528h | 105.6h |  |  |  | Alan Baldwin, Ericsson | Alan.Baldwin@EML.ERICSSON.SE |  |  |  |  |
| 794 | 98.2.2 | Technical realization | 191d | 2001-06-15 A | 2002-03-08 A | 100% |  | 2001-06-15 | 2002-03-08 | 191d |  | finish no earlier than 2002-03-08 | T2 | 1528h | 1528h |  |  | 23.040 | Alan Baldwin, Ericsson | Alan.Baldwin@EML.ERICSSON.SE |  |  |  |  |
| 795 | 99 | **GERAN Inter BSC NACC improvements over the Gb Interface** | 215d | 2001-09-03 A | 2002-06-28 A | 100% |  | 2001-09-03 | 2002-06-28 | 215d |  |  | GP | 11184h | 11184h | GERNACC |  |  |  |  |  |  | Rel5 | Paolo |
| 796 | 99.1 | **Modification of core network protocols for GERAN Inter BSC NACC over Gb Interface** | 165d | 2001-09-03 A | 2002-04-19 A | 100% |  | 2001-09-03 | 2002-04-19 | 165d |  |  | N4; S2 | 7048h | 7048h | GERNACC-Cnmod |  |  |  |  |  |  |  |  |
| 797 | 99.1.1 | Stage 2 - Concept | 43d | 2001-09-03 A | 2001-10-31 A | 100% |  | 2001-09-03 | 2001-10-31 | 43d |  | finish no earlier than 2001-10-31 | N4; S2 | 688h | 688h |  |  |  |  |  |  |  |  |  |
| 798 | 99.1.2 | Stage 2 - 23.060 change - Definition of Inter BSC NACC | 165d | 2001-09-03 A | 2002-04-19 A | 100% |  | 2001-09-03 | 2002-04-19 | 165d |  | finish no earlier than 2002-04-19 | N4; S2 | 2640h | 2640h |  |  |  |  |  |  |  |  |  |
| 799 | 99.1.3 | Stage 3 (changes to TS 29.060) | 135d | 2001-09-03 A | 2002-03-08 A | 100% |  | 2001-09-03 | 2002-03-08 | 135d |  | finish no earlier than 2002-03-08 | N4 | 1080h | 1080h |  |  |  |  |  |  |  |  |  |
| 800 | 99.2 | **Modification of Gb protocols for GERAN Inter BSC NACC over Gb Interface** | 151d | 2001-11-30 A | 2002-06-28 A | 100% |  | 2001-11-30 | 2002-06-28 | 151d |  |  | GP | 2416h | 2416h | GERNACC-Gbmod |  |  |  |  |  |  |  |  |
| 801 | 99.2.1 | Stage 3 (changes to TS 48.018) | 151d | 2001-11-30 A | 2002-06-28 A | 100% |  | 2001-11-30 | 2002-06-28 | 151d |  | finish no earlier than 2002-06-28 | GP | 1208h | 1208h |  |  |  |  |  |  |  |  |  |
| 802 | 100 | **Enhanced Power Control** | 540d | 2001-11-26 A | 2003-12-19 |  | 537.46d | 2001-11-26 | 2002-06-28 | 155d | 95d |  | GP | 12840h | 60.28h | EPC |  |  |  |  |  |  | Rel5 |  |
| 803 | 100.1 | Realization of Enhanced power control and signaling support | 5d | 2001-11-26 A | 2001-11-30 A | 100% |  | 2001-11-26 | 2001-11-30 | 5d |  | finish no earlier than 2001-11-30 | GP | 40h | 40h |  |  |  |  |  |  |  |  |  |
| 804 | 100.2 | GERAN MS Conformance test for Enhanced Power Control | 530d | 2001-12-10 | 2003-12-19 |  |  | 2001-12-10 | 2002-06-28 | 145d | 95d | finish no earlier than 2003-12-19 | GP | 4240h |  |  |  |  |  |  |  |  |  |  |
| 805 | 100.3 | GERAN BTS Conformance test for Enhanced Power Control | 530d | 2001-12-10 | 2003-12-19 |  |  | 2001-12-10 | 2002-06-28 | 145d | 95d | finish no earlier than 2003-12-19 | GP | 4240h |  |  |  |  |  |  |  |  |  |  |
| 806 | 101 | **8PSK AMR HR** | 530d | 2001-12-10 A | 2003-12-19 | 73% | 143.32d | 2001-12-10 | 2002-06-28 | 145d | 95d |  | GP | 21080h | 15693.5h | 8PSK-AH |  |  |  |  |  |  | Rel5 | Paolo |
| 807 | 101.1 | **Definition of channel coding, performance requirements and signaling support** | 145d | 2001-12-10 A | 2002-06-28 A | 100% |  | 2001-12-10 | 2002-06-28 | 145d |  |  | GP | 10440h | 10440h |  |  |  |  |  |  |  |  |  |
| 808 | 101.1.1 | Concept | 145d | 2001-12-10 A | 2002-06-28 A | 100% |  | 2001-12-10 | 2002-06-28 | 145d |  | finish no earlier than 2002-06-28 | GP | 1160h | 1160h |  |  |  |  |  |  |  |  |  |
| 809 | 101.1.2 | Changes to 44.018 | 145d | 2001-12-10 A | 2002-06-28 A | 100% |  | 2001-12-10 | 2002-06-28 | 145d |  | finish no earlier than 2002-06-28 | G2 | 1160h | 1160h |  |  |  |  |  |  |  |  |  |
| 810 | 101.1.3 | Changes to 45.001 | 145d | 2001-12-10 A | 2002-06-28 A | 100% |  | 2001-12-10 | 2002-06-28 | 145d |  | finish no earlier than 2002-06-28 | G1 | 1160h | 1160h |  |  |  |  |  |  |  |  |  |
| 811 | 101.1.4 | Changes to 45.002 | 145d | 2001-12-10 A | 2002-06-28 A | 100% |  | 2001-12-10 | 2002-06-28 | 145d |  | finish no earlier than 2002-06-28 | G1 | 1160h | 1160h |  |  |  |  |  |  |  |  |  |
| 812 | 101.1.5 | Changes to 45.003 | 145d | 2001-12-10 A | 2002-06-28 A | 100% |  | 2001-12-10 | 2002-06-28 | 145d |  | finish no earlier than 2002-06-28 | G1 | 1160h | 1160h |  |  |  |  |  |  |  |  |  |
| 813 | 101.1.6 | Changes to 45.005 | 145d | 2001-12-10 A | 2002-06-28 A | 100% |  | 2001-12-10 | 2002-06-28 | 145d |  | finish no earlier than 2002-06-28 | G1 | 1160h | 1160h |  |  |  |  |  |  |  |  |  |
| 814 | 101.1.7 | Changes to 24.008 | 145d | 2001-12-10 A | 2002-06-28 A | 100% |  | 2001-12-10 | 2002-06-28 | 145d |  | finish no earlier than 2002-06-28 | G2 | 1160h | 1160h |  |  |  |  |  |  |  |  |  |
| 815 | 101.1.8 | Changes to 48.058 | 145d | 2001-12-10 A | 2002-06-28 A | 100% |  | 2001-12-10 | 2002-06-28 | 145d |  | finish no earlier than 2002-06-28 | G2 | 1160h | 1160h |  |  |  |  |  |  |  |  |  |
| 816 | 101.2 | GERAN MS Conformance test for 8PSK HR | 530d | 2001-12-10 | 2003-12-19 |  |  | 2001-12-10 | 2002-06-28 | 145d | 95d | finish no earlier than 2003-12-19 | GP | 4240h |  |  |  |  |  |  |  |  |  |  |
| 817 | 101.3 | GERAN BTS Conformance test for 8PSK HR | 270d | 2001-12-10 A | 2002-12-20 A | 100% |  | 2001-12-10 | 2002-06-28 | 145d |  | finish no earlier than 2002-12-20 | GP | 2160h | 2160h |  |  |  |  |  |  |  |  |  |
| 818 | 102 | Service Change and UDI Fallback | 175d | 2001-10-08 A | 2002-06-07 A | 100% |  | 2001-10-08 | 2002-06-07 | 175d |  | finish no earlier than 2002-06-07 | N3 | 1400h | 1400h | SCUDIF |  | 29.007, 27.001, 24.008 | Rune Werner Wiik, Ericsson AS | Rune.Werner.Wiik@ericsson.no | WG |  | Rel5 | David |

Notes:
- 799: IP 30/11/01: Input awaited from GERAN2 to CN4 / 17 May Work complete 100%
- 803: Ready
- 804: Not started
- 805: Not started
- 806: Completed for Rel-5
- 818: [DAB - 15/11/02] - NOTE INTERWORKING ISSUES IDENTIFIED THAT NEED CLARIFICATION

| ID | WBS | Task | Duration | Start | Finish | Complete | Remaining | Baseline start | Baseline finish | Baseline duration | Total slack | Constraint | Resources | Work | Actual work | Text1 | Text2 | Text6 | Text8 | Text9 | Text4 | Text3 | Text7 | Text5 |
| --- | --- | --- | --- | --- | --- | --- | --- | --- | --- | --- | --- | --- | --- | --- | --- | --- | --- | --- | --- | --- | --- | --- | --- | --- |
| 819 | 103 | **Rel-5 USIM toolkit enhancements** | 865d | 2000-06-05 A | 2003-09-26 | 51% | 425.77d | 2000-06-05 | 2003-09-26 | 865d | 155d |  | T3 | 24352h | 13591.2h | USAT1 | Ter | NA | Claus | 1800 |  |  |  |  |
| 820 | 103.1 | Test specification for USIM toolkit security mechanims | 349d | 2002-05-28 | 2003-09-26 |  |  | 2002-05-28 | 2003-09-26 | 349d | 155d | finish no earlier than 2003-09-26 | T3 | 2792h |  |  |  |  |  |  | Sophie Viallet (Gemplus) |  |  |  |
| 821 | 103.2 | **Protocol Standardisation of a SIM Toolkit Interpreter** | 688d | 2000-06-05 A | 2003-01-22 | 64% | 250.88d | 2000-06-05 | 2003-01-22 | 688d | 332d |  | T3 | 12512h | 7949.4h | USAT1-Interpr | Ter | Rel5 |  | 1801 | Michael Meyer, G & D | 27.103 | TSG |  |
| 822 | 103.2.1 | Stage 1 | 205d | 2000-06-05 A | 2001-03-16 A | 100% |  | 2000-06-05 | 2001-03-16 | 205d |  | finish no earlier than 2001-03-16 | T3 | 1640h | 1640h |  |  |  |  |  |  |  | TSG |  |
| 823 | 103.2.2 | Stage 2 and 3 | 308d | 2001-01-03 A | 2002-03-08 A | 100% |  | 2001-01-03 | 2002-03-08 | 308d |  | finish no earlier than 2002-03-08 | T3 | 2464h | 2464h |  |  |  |  |  |  |  | TSG |  |
| 824 | 103.2.3 | Test specification | 363d | 2001-09-03 A | 2003-01-22 | 12% | 319.44d | 2001-09-03 | 2003-01-22 | 363d | 332d | finish no earlier than 2003-01-22 | T3 | 2904h | 348.48h |  |  |  |  |  | Gérald MAUNIER (Gemplus) |  | TSG |  |
| 825 | 103.4 | **(U)SIM API** | 133d | 2002-03-20 A | 2002-09-20 A | 100% |  | 2000-09-25 | 2002-09-27 | 525d |  |  | T3 | 2128h | 2128h | USAT1-API |  | NA |  |  |  |  |  |  |
| 826 | 103.4.1 | Java API Test specification | 133d | 2002-03-20 A | 2002-09-20 A | 100% |  | 2002-03-20 | 2002-09-20 | 133d |  | finish no earlier than 2002-09-20 | T3 | 1064h | 1064h |  |  |  |  |  | Mario Pérez (Microelectrónica Española) |  |  |  |
| 827 | 104 | small Technical Enhancements and Improvements for Rel5 | 325d | 2000-12-25 A | 2002-03-22 A | 100% |  | 2000-12-25 | 2002-03-22 | 325d |  | start no earlier than 2000-12-25 | Generic | 2600h | 2600h | TEI5 |  | Rel5 |  | 1993 |  |  | TSG |  |
| 828 | 105 | Technical Report on UE Functionality Split | 86d | 2000-01-03 | 2000-05-01 |  |  | 2002-04-22 | 2002-08-19 | 86d | 1044d |  | S1 | 688h |  | UESPLIT |  | Rel5 | Michael |  | Sanjay Gupta, Motorola |  | TSG | sanjay.gupta@motorola.com |
| 829 | 106 | **User Equipment Management** | 267d | 2001-06-21 A | 2002-06-28 | 99% | 0d | 2001-06-21 | 2002-06-28 | 267d | 0d |  | S5 | 3752h | 3752h | UEM |  | NA | Adrian |  | John Mudge (Vodafone) |  | TSG | john.mudge@vf.vodafone.co.uk |
| 830 | 106.1 | FS on User Equipment (UE) Management | 267d | 2001-06-21 A | 2002-06-28 A | 100% |  | 2001-06-21 | 2002-06-28 | 267d |  | finish no earlier than 2002-06-28 | S5 | 2136h | 2136h | OAM-UEM |  | Rel5 | Adrian |  | John Mudge (Vodafone) | 32.802 | TSG | john.mudge@VF.VODAFONE.CO.UK |
| 831 | 107 | **Flow control supporting an MS with multiple data flows with different QoS over the Gb interface** | 50d | 2002-06-24 A | 2002-08-30 A | 100% |  |  |  |  |  |  | GP | 1288h | 1288h | FlowCon |  | Rel5 |  |  | Ingemar Backlund, Ericsson |  | TSG |  |
| 832 | 107.1 | **Update of stage 2 specifications** | 50d | 2002-06-24 A | 2002-08-30 A | 100% |  |  |  |  |  |  | GP | 808h | 808h |  |  |  |  |  |  |  | TSG |  |
| 833 | 107.1.1 | Concept document 23.060 (changes to) | 46d | 2002-06-28 A | 2002-08-30 A | 100% |  |  |  |  |  | finish no earlier than 2002-08-30 | S2 | 368h | 368h |  |  |  |  |  |  |  |  |  |
| 834 | 107.1.2 | Flow Control | 5d | 2002-06-24 A | 2002-06-28 A | 100% |  |  |  |  |  | finish no earlier than 2002-06-28 | GP | 40h | 40h |  |  |  |  |  |  |  |  |  |
| 835 | 107.2 | **Modification of BSSGP protocol** | 5d | 2002-06-24 A | 2002-06-28 A | 100% |  |  |  |  |  |  | GP | 80h | 80h |  |  |  |  |  | Ingemar Backlund, Ericsson |  | TSG |  |
| 836 | 107.2.1 | Stage 3 (changes to 48.018) | 5d | 2002-06-24 A | 2002-06-28 A | 100% |  |  |  |  |  | finish no earlier than 2002-06-28 | G2 | 40h | 40h |  |  |  |  |  |  |  |  |  |
| 837 | 108 | **Multiple TBF in A/Gb mode** | 421d | 2002-04-19 A | 2003-11-28 | 17% | 349.82d | 2002-04-19 | 2002-06-28 | 51d | 110d |  | GP | 17480h | 2716.74h | MULTBF |  | Rel5 |  |  | Gunnar Mildh, Ericsson |  | TSG | gunnar.mildh@era.ericsson.se |
| 838 | 108.1 | **Multiple TBF in A/Gb mode** | 351d | 2002-04-19 A | 2003-08-22 | 26% | 258.09d | 2002-04-19 | 2002-06-28 | 51d | 180d |  | GP | 8112h | 2147.29h | MULTBF-Agbmode |  |  |  |  |  |  |  |  |
| 839 | 108.1.1 | Multiple TBF Concept paper | 351d | 2002-04-19 A | 2003-08-22 | 50% | 175.5d | 2002-04-19 | 2002-06-28 | 51d | 180d | finish no earlier than 2003-08-22 | GP | 2808h | 1404h |  |  |  |  |  |  |  |  |  |
| 840 | 108.1.2 | Multiple TBF Stage 2 (43.064) CRs | 156d | 2002-04-19 | 2002-11-22 |  |  | 2002-04-19 | 2002-06-28 | 51d | 375d | finish no earlier than 2002-11-22 | G1 | 1248h |  |  |  |  |  |  |  |  |  |  |
| 841 | 108.1.3 | Multiple TBF Stage 3 (44.060) CRs | 156d | 2002-04-19 | 2002-11-22 |  |  | 2002-04-19 | 2002-06-28 | 51d | 375d | finish no earlier than 2002-11-22 | G2 | 1248h |  |  |  |  |  |  |  |  |  |  |
| 842 | 108.2 | **Multiple TBF in A/Gb mode – MS testing** | 375d | 2002-06-24 | 2003-11-28 |  |  |  |  |  | 110d |  | GP | 6000h |  |  |  |  |  |  | Ingemar Backlund, Ericsson |  |  |  |
| 843 | 108.2.1 | MS conformance tests | 375d | 2002-06-24 | 2003-11-28 |  |  |  |  |  | 110d | finish no earlier than 2003-11-28 | G4 | 3000h |  |  |  |  |  |  |  |  |  |  |

Notes:
- 821: 28/5/2001: T3-19 proposed that since the stage 2 and 3 will not be presented to TP-12 for approval as expected, the WI will be moved to rel-5, with completion expected at TP-13.
- 822: 5/10/2001: Stage one comepeted at TP-12.
- 823: 5/10/2001: TS 31.112 and 31.113 approved at TP-13. TS 31.114 to be presented to TP-14.
- 824: 5/10/2001: Work started on test specification
- 825: 8/3/2001: test spec is based on R99 core spec, so deleted from Workplan
- 827: "Joker" WI, to be used for a Rel 5 CR not related to any feature and with very limited impact on the system
- 829: az: Rel-5->NA (to cover also Rel-6)
- 838: Started
- 843: Not started

| ID | WBS | Task | Duration | Start | Finish | Complete | Remaining | Baseline start | Baseline finish | Baseline duration | Total slack | Constraint | Resources | Work | Actual work | Text1 | Text4 | Text6 | Text7 | Text8 | Text9 |
| --- | --- | --- | --- | --- | --- | --- | --- | --- | --- | --- | --- | --- | --- | --- | --- | --- | --- | --- | --- | --- | --- |
| 844 | 109 | **Alignment of 3G functional split and Iu** | 922d | 2000-06-08 A | 2003-12-19 | 85% | 141.74d | 2000-06-08 | 2002-12-06 | 652d | 95d |  | GP | 161582h | 123264h | GER3GAL | Frank Muller, Ericsson | Rel5 | TSG | Paolo | 2345 |
| 845 | 109.1 | **GERAN user / control plane** | 540d | 2000-08-07 A | 2002-08-30 | 99% | 0d | 2000-07-19 | 2002-06-28 | 507.5d | 0d |  | GP | 36232h | 32092h | GER3GAL-GUCOPL | Frank Muller, Ericsson |  | TSG | Paolo | 2346 |
| 846 | 109.1.1 | **Alignment with UMTS bearer concept** | 540d | 2000-08-07 A | 2002-08-30 | 99% | 0d | 2000-07-19 | 2002-06-28 | 507.5d | 0d |  | GP | 24952h | 22392h |  |  |  | TSG |  | 2347 |
| 847 | 109.1.1.1 | Enhanced power control | 1d | 2001-08-31 A | 2001-08-31 A | 100% |  | 2001-08-31 | 2001-08-31 | 1d |  | finish no earlier than 2001-08-31 | GP | 8h | 8h |  |  |  | TSG |  |  |
| 848 | 109.1.1.2 | Stage 2 | 235d | 2000-08-07 A | 2001-06-29 A | 100% |  | 2000-08-07 | 2001-06-29 | 235d |  | finish no earlier than 2001-06-29 | GP | 1880h | 1880h |  |  |  | TSG |  | 2423 |
| 849 | 109.1.1.3 | Adoption of the UTRAN PDCP | 295d | 2000-11-06 A | 2001-12-21 A | 100% |  | 2000-11-06 | 2001-12-21 | 295d |  | finish no earlier than 2001-12-21 | GP | 2360h | 2360h |  |  |  | TSG |  | 2348 |
| 850 | 109.1.1.4 | Development of RLC / MAC | 261d | 2001-08-31 A | 2002-08-30 A | 100% |  | 2001-08-31 | 2002-06-28 | 216d |  | finish no earlier than 2002-08-30 | GP | 2088h | 2088h |  |  |  | TSG |  |  |
| 851 | 109.1.1.5 | Development of GERAN RRC | 266d | 2001-06-22 A | 2002-06-28 A | 100% |  | 2001-06-22 | 2002-06-28 | 266d |  | finish no earlier than 2002-06-28 | GP | 2128h | 2128h |  |  |  | TSG |  |  |
| 852 | 109.1.1.6 | Ciphering and integrity protection concept paper | 166d | 2001-08-31 A | 2002-04-19 A | 100% |  | 2001-08-31 | 2002-04-19 | 166d |  | finish no earlier than 2002-04-19 | GP | 1328h | 1328h |  |  |  | TSG |  |  |
| 853 | 109.1.1.7 | Multiple TBF or equivalent Concept paper | 116d | 2001-08-31 A | 2002-02-08 A | 100% |  | 2001-08-31 | 2002-02-08 | 116d |  | finish no earlier than 2002-02-08 | GP | 928h | 928h |  |  |  | TSG |  |  |
| 854 | 109.1.1.8 | Paging concept | 166d | 2001-08-31 A | 2002-04-19 A | 100% |  | 2001-08-31 | 2002-04-19 | 166d |  | finish no earlier than 2002-04-19 | GP | 1328h | 1328h |  |  |  | TSG |  |  |
| 855 | 109.1.1.9 | Dedicated Physical subchannels, includes traffic and control channels | 66d | 2001-08-31 A | 2001-11-30 A | 100% |  | 2001-08-31 | 2001-11-30 | 66d |  | finish no earlier than 2001-11-30 | GP | 528h | 528h |  |  |  | TSG |  |  |
| 856 | 109.1.1.10 | Iu support and broadcast concept | 166d | 2001-08-31 A | 2002-04-19 A | 100% |  | 2001-08-31 | 2002-04-19 | 166d |  | finish no earlier than 2002-04-19 | GP | 1328h | 1328h |  |  |  | TSG |  |  |
| 857 | 109.1.1.11 | Impact of using RLC instead of LAPDm concept | 116d | 2001-08-31 A | 2002-02-08 A | 100% |  | 2001-08-31 | 2002-02-08 | 116d |  | finish no earlier than 2002-02-08 | GP | 928h | 928h |  |  |  | TSG |  |  |
| 858 | 109.1.1.12 | Contention resolution, mobile station identity, and access concept | 66d | 2001-08-31 A | 2001-11-30 A | 100% |  | 2001-08-31 | 2001-11-30 | 66d |  | finish no earlier than 2001-11-30 | GP | 528h | 528h |  |  |  | TSG |  |  |
| 859 | 109.1.1.13 | PDCP concept | 166d | 2001-08-31 A | 2002-04-19 A | 100% |  | 2001-08-31 | 2002-04-19 | 166d |  | finish no earlier than 2002-04-19 | GP | 1328h | 1328h |  |  |  | TSG |  |  |
| 860 | 109.1.1.14 | Downlink delayed TBF release | 261d | 2001-08-31 A | 2002-08-30 A | 100% |  | 2001-08-31 | 2001-11-30 | 66d |  | finish no earlier than 2002-08-30 | GP | 2088h | 2088h |  |  |  | TSG |  |  |
| 861 | 109.1.1.15 | Add transparent RLC Concept | 116d | 2001-08-31 A | 2002-02-08 A | 100% |  | 2001-08-31 | 2002-02-08 | 116d |  | finish no earlier than 2002-02-08 | GP | 928h | 928h |  |  |  | TSG |  |  |
| 862 | 109.1.1.16 | Handover concept | 116d | 2001-08-31 A | 2002-02-08 A | 100% |  | 2001-08-31 | 2002-02-08 | 116d |  | finish no earlier than 2002-02-08 | GP | 928h | 928h |  |  |  |  |  |  |
| 863 | 109.1.2 | **Physical layer alignment with UMTS bearer concept** | 280d | 2000-11-06 A | 2001-11-30 | 99% | 0d | 2000-11-06 | 2001-11-30 | 280d | 0d |  | GP | 6960h | 5380h |  |  |  | TSG |  | 2424 |
| 864 | 109.1.2.1 | PDTCH/TCH in 45.003 | 155d | 2000-11-06 A | 2001-06-08 A | 100% |  | 2000-11-06 | 2001-06-08 | 155d |  | finish no earlier than 2001-06-08 | GP | 1240h | 1240h |  |  |  | TSG |  | 2356 |
| 865 | 109.1.2.2 | Control channels in 45.003 | 155d | 2000-11-06 A | 2001-06-08 A | 100% |  | 2000-11-06 | 2001-06-08 | 155d |  | finish no earlier than 2001-06-08 | GP | 1240h | 1240h |  |  |  | TSG |  | 2357 |
| 866 | 109.1.2.3 | Receiver performance in 45.005 for PDTCH/TCH and control channels | 280d | 2000-11-06 A | 2001-11-30 A | 100% |  | 2000-11-06 | 2001-11-30 | 280d |  | finish no earlier than 2001-11-30 | GP | 2240h | 2240h |  |  |  | TSG |  | 2358 |
| 867 | 109.2 | **Iu rg interface** | 430d | 2000-11-06 A | 2002-06-28 A | 100% |  | 2000-11-06 | 2002-06-28 | 430d |  |  | GP; RP | 59660h | 56220h | GER3GAL-Iurg | Frank Muller, Ericsson |  | TSG | Paolo | 2359 |
| 868 | 109.2.1 | **Inter BSS interface** | 430d | 2000-11-06 A | 2002-06-28 A | 100% |  | 2000-11-06 | 2002-06-28 | 430d |  |  | GP; RP | 24080h | 24080h |  |  |  |  |  | 2425 |
| 869 | 109.2.1.1 | Identification of requirements | 430d | 2000-11-06 A | 2002-06-28 A | 100% |  | 2000-11-06 | 2002-06-28 | 430d |  | finish no earlier than 2002-06-28 | GP | 3440h | 3440h |  |  |  |  |  | 2360 |
| 870 | 109.2.1.2 | Stage 2 | 430d | 2000-11-06 A | 2002-06-28 A | 100% |  | 2000-11-06 | 2002-06-28 | 430d |  | finish no earlier than 2002-06-28 | GP | 3440h | 3440h |  |  |  |  |  | 2361 |
| 871 | 109.2.1.3 | Adoption of relevant parts from Iur | 430d | 2000-11-06 A | 2002-06-28 A | 100% |  | 2000-11-06 | 2002-06-28 | 430d |  | finish no earlier than 2002-06-28 | GP | 3440h | 3440h |  |  |  |  |  | 2362 |
| 872 | 109.2.1.4 | Complementation with GERAN specifics | 430d | 2000-11-06 A | 2002-06-28 A | 100% |  | 2000-11-06 | 2002-06-28 | 430d |  | finish no earlier than 2002-06-28 | GP | 3440h | 3440h |  |  |  |  |  | 2363 |
| 873 | 109.2.1.5 | Stage 3 | 430d | 2000-11-06 A | 2002-06-28 A | 100% |  | 2000-11-06 | 2002-06-28 | 430d |  | finish no earlier than 2002-06-28 | GP | 3440h | 3440h |  |  |  |  |  | 2364 |

Notes:
- 844: AWS, Nokia, Ericsson, Nortel, Siemens, Vodafone
- 845: AWS, Nokia, Ericsson, Nortel, Siemens, Vodafone
- 849: Responsible is GERAN; RAN WG2 help may be needed.
- 867: AWS, Nokia, Ericsson, Nortel, Siemens, Vodafone

| ID | WBS | Task | Duration | Start | Finish | Complete | Remaining | Baseline start | Baseline finish | Baseline duration | Total slack | Constraint | Resources | Work | Actual work | Text9 | Text8 | Text1 | Text4 | Text6 | Text7 |
| --- | --- | --- | --- | --- | --- | --- | --- | --- | --- | --- | --- | --- | --- | --- | --- | --- | --- | --- | --- | --- | --- |
| 874 | 109.2.2 | **Inter BSS-RNS interface** | 430d | 2000-11-06 A | 2002-06-28 A | 100% |  | 2000-11-06 | 2002-06-28 | 430d |  |  | GP; RP | 28700h | 28700h | 2426 |  |  |  |  |  |
| 875 | 109.2.2.1 | Identification of requirements | 430d | 2000-11-06 A | 2002-06-28 A | 100% |  | 2000-11-06 | 2002-06-28 | 430d |  | start no earlier than 2000-11-06 | GP; R3 | 6880h | 6880h | 2365 |  |  |  |  |  |
| 876 | 109.2.2.2 | Stage 2 | 430d | 2000-11-06 A | 2002-06-28 A | 100% |  | 2000-11-06 | 2002-06-28 | 430d |  | finish no earlier than 2002-06-28 | GP; R3 | 5744.8h | 5744.8h | 2366 |  |  |  |  |  |
| 877 | 109.2.2.3 | Adoption of relevant parts from Iur | 430d | 2000-11-06 A | 2002-06-28 A | 100% |  | 2000-11-06 | 2002-06-28 | 430d |  | finish no earlier than 2002-06-28 | GP; R3 | 6880h | 6880h | 2367 |  |  |  |  |  |
| 878 | 109.2.2.4 | Complementation with GERAN specifics | 107.5d | 2002-01-30 A | 2002-06-28 A | 100% |  | 2002-01-30 | 2002-06-28 | 107.5d |  | finish no earlier than 2002-06-28 | GP; R3 | 1720h | 1720h | 2368 |  |  |  |  |  |
| 879 | 109.2.2.5 | Stage 3 | 107.5d | 2002-01-30 A | 2002-06-28 A | 100% |  | 2002-01-30 | 2002-06-28 | 107.5d |  | finish no earlier than 2002-06-28 | GP; R3 | 1720h | 1720h | 2369 |  |  |  |  |  |
| 880 | 109.3 | **Voice over GERAN PS and CS concept** | 430d | 2000-11-06 A | 2002-06-28 A | 100% |  | 2000-11-06 | 2002-06-28 | 430d |  |  | GP; R3 | 33338.4h | 33338.4h | 2370 | Paolo |  |  |  |  |
| 881 | 109.3.1 | Architecture for A, Iu cs and Iu ps | 430d | 2000-11-06 A | 2002-06-28 A | 100% |  | 2000-11-06 | 2002-06-28 | 430d |  | finish no earlier than 2002-06-28 | GP; R3 | 6412.8h | 6412.8h | 2371 |  |  |  |  |  |
| 882 | 109.3.2 | Transcoder position/operation | 115d | 2000-11-06 A | 2001-04-13 A | 100% |  | 2000-11-06 | 2001-04-13 | 115d |  | finish no earlier than 2001-04-13 | GP | 920h | 920h | 2372 |  |  |  |  |  |
| 883 | 109.3.3 | Handover | 430d | 2000-11-06 A | 2002-06-28 A | 100% |  | 2000-11-06 | 2002-06-28 | 430d |  | finish no earlier than 2002-06-28 | GP; R3 | 6412.8h | 6412.8h | 2373 |  |  |  |  |  |
| 884 | 109.3.4 | RTP payload | 430d | 2000-11-06 A | 2002-06-28 A | 100% |  | 2000-11-06 | 2002-06-28 | 430d |  | finish no earlier than 2002-06-28 | GP; R3 | 6412.8h | 6412.8h | 2374 |  |  |  |  |  |
| 885 | 109.3.5 | Codec renegotiation concept | 365d | 2000-11-06 A | 2002-03-29 A | 100% |  |  |  |  |  | finish no earlier than 2002-03-29 | GP; R3 | 5840h | 5840h |  |  |  |  |  |  |
| 886 | 109.3.6 | LA | 115d | 2000-11-06 A | 2001-04-13 A | 100% |  |  |  |  |  | finish no earlier than 2001-04-13 | GP | 920h | 920h |  |  |  |  |  |  |
| 887 | 109.4 | **GERAN MS Conformance test for GERAN interface evolution** | 660d | 2001-06-11 | 2003-12-19 |  |  | 2001-06-11 | 2002-12-06 | 390d | 95d |  | GP | 10560h |  | 2388 | Paolo |  |  |  |  |
| 888 | 109.4.1 | MS test | 660d | 2001-06-11 | 2003-12-19 |  |  | 2001-06-11 | 2002-12-06 | 390d | 95d | finish no earlier than 2003-12-19 | GP | 5280h |  | 2389 |  |  |  |  |  |
| 889 | 109.5 | **GERAN BSS Conformance test for GERAN interface evolution** | 922d | 2000-06-08 | 2003-12-19 |  |  | 2000-06-08 | 2002-12-06 | 652d | 95d |  | GP | 14752h |  | 2390 | Paolo |  |  |  |  |
| 890 | 109.5.1 | BSS test | 922d | 2000-06-08 | 2003-12-19 |  |  | 2000-06-08 | 2002-12-06 | 652d | 95d | finish no earlier than 2003-12-19 | GP | 7376h |  | 2391 |  |  |  |  |  |
| 891 | 110 | **GERAN support for IMS** | 690d | 2000-05-01 A | 2002-12-20 | 59% | 286.24d | 2000-05-01 | 2002-12-20 | 690d | 355d |  | GP | 66591.8h | 29961h |  | Paolo | GERIMS | Shkumbin Hamiti, Nokia | Rel5 | TSG |
| 892 | 110.1 | **GERAN Header adaptation** | 690d | 2000-05-01 A | 2002-12-20 | 100% | 0d | 2000-05-01 | 2002-12-20 | 690d | 0d |  | GP; S2; RP | 27325.8h | 18525.8h |  | Paolo | GERIMS-HEADAPT | Shkumbin Hamiti, Nokia |  | TSG |
| 893 | 110.1.1 | Definition of compression and removal modes for PDCP protocol | 22.1d | 2000-05-01 A | 2000-11-10 A | 100% |  | 2000-05-01 | 2000-11-10 | 22.1d |  | finish no earlier than 2000-09-01 | GP; S2; RP | 248.4h | 248.4h | 2332 |  |  |  |  | TSG |
| 894 | 110.1.2 | Conceptual description in stage 2 | 393d | 2000-05-01 A | 2001-10-31 A | 100% |  | 2000-05-01 | 2001-10-31 | 393d |  | finish no earlier than 2001-10-31 | GP; S2; RP | 5989.92h | 5989.92h | 2333 |  |  |  |  | TSG |
| 895 | 110.1.3 | Necessary changes on stage 3 regarding header removal | 439.8d | 2000-11-06 A | 2002-12-20 A | 100% |  | 2000-11-06 | 2002-12-20 | 439.8d |  | finish no earlier than 2002-12-20 | GP; S2; RP | 6767.47h | 6767.47h |  |  |  |  |  | TSG |
| 896 | 110.2 | **GERAN Radio access bearer design for IMS** | 430d | 2000-11-06 A | 2002-06-28 | 89% | 46.49d | 2000-11-06 | 2002-06-28 | 430d | 480d |  | GP; S2; RP | 21658h | 8621.71h | 2335 | Paolo | GERIMS-RABDES | Shkumbin Hamiti, Nokia |  | TSG |
| 897 | 110.2.1 | **MuM control signalling for conversational multimedia services** | 430d | 2000-11-06 A | 2002-06-28 | 89% | 46.49d | 2000-11-06 | 2002-06-28 | 430d | 480d |  | GP; S2; RP | 12458h | 5553.6h | 2422 |  |  |  |  | TSG |
| 898 | 110.2.1.1 | Identification of requirements | 330d | 2000-11-06 A | 2002-02-08 A | 100% |  | 2000-11-06 | 2002-02-08 | 330d |  | finish no earlier than 2002-02-08 | GP; S2; RP | 5545.6h | 5545.6h | 2431 |  |  |  |  | TSG |
| 899 | 110.2.1.2 | Necessary modifications due to SIP | 40d | 2002-05-06 | 2002-06-28 |  |  | 2002-05-06 | 2002-06-28 | 40d | 480d | finish no earlier than 2002-06-28 | GP; S2; RP | 960h |  | 2337 |  |  |  |  | TSG |

Notes:
- 887: Not started
- 888: Not started
- 889: Not started
- 890: Not started
- 891: AWS, Nokia, Ericsson, Nortel, Siemens, Motorola
- 892: AWS, Nokia, Ericsson, Nortel, Siemens, Motorola
- 896: TERMINATED - NOT STANDARDIZED
- 897: TERMINATED - NOT STANDARDIZED
- 898: TERMINATED - NOT STANDARDIZED
- 899: TERMINATED - NOT STANDARDIZED

| ID | WBS | Task | Duration | Start | Finish | Complete | Remaining | Baseline start | Baseline finish | Baseline duration | Total slack | Constraint | Resources | Work | Actual work | Text1 | Text4 | Text7 | Text8 | Text9 | Text6 |
| --- | --- | --- | --- | --- | --- | --- | --- | --- | --- | --- | --- | --- | --- | --- | --- | --- | --- | --- | --- | --- | --- |
| 900 | 110.3 | **GERAN MS Conformance test for support of IMS** | 400d | 2001-06-11 | 2002-12-20 |  |  | 2001-06-11 | 2002-12-20 | 400d | 355d |  | GP | 6400h |  | GERIMS-MSconf | Shkumbin Hamiti, Nokia | TSG | Paolo | 2341 |  |
| 901 | 110.3.1 | MS test | 400d | 2001-06-11 | 2002-12-20 |  |  | 2001-06-11 | 2002-12-20 | 400d | 355d | finish no earlier than 2002-12-20 | G4 | 3200h |  |  |  | TSG |  | 2342 |  |
| 902 | 110.4 | **GERAN BTS Conformance test for support of IMS** | 400d | 2001-06-11 | 2002-12-20 |  |  | 2001-06-11 | 2002-12-20 | 400d | 355d |  | GP | 6400h |  | GERIMS-BTSconf | Shkumbin Hamiti, Nokia | TSG | Paolo | 2343 |  |
| 903 | 110.4.1 | BTS test | 400d | 2001-06-11 | 2002-12-20 |  |  | 2001-06-11 | 2002-12-20 | 400d | 355d | finish no earlier than 2002-12-20 | G3 | 3200h |  |  |  | TSG |  | 2344 |  |
| 904 | 115 | MS Conformance Testing of Dual Transfer Mode | 65d? | 2002-11-11 A | 2003-02-07 A | 100% |  |  |  |  |  | finish no earlier than 2003-02-07 | G4; G5 | 1040h | 1040h | MSCTDTM | Dave Fox, Vodafone | TSG |  |  | NA |
| 905 | 116 | Single Antenna Receiver Interference Cancellation (SAIC) | 161d? | 2002-11-15 A | 2003-06-27 | 20% | 128.8d? |  |  |  | 220d | finish no earlier than 2003-06-27 | G1 | 1288h | 257.6h | SAIC | Marc Grant, Cingular Wireless | TSG |  |  | Rel6 |
| 906 | 117 | **Support of Conversational Services in A/Gb mode via the PS domain** | 321d? | 2003-02-07 | 2004-04-30 |  |  |  |  |  | 0d |  | GP | 17096h |  | SCSAGB | David Bladsjö, Ericsson | TSG |  |  | Rel6 |
| 907 | 117.1 | Creation of a TR | 211d? | 2003-02-07 | 2003-11-28 |  |  |  |  |  | 110d | finish no earlier than 2003-11-28 | GP | 1688h |  | SCSAGB-TR | David Bladsjö, Ericsson | TSG |  |  |  |
| 908 | 117.2 | Stage 2 | 321d? | 2003-02-07 | 2004-04-30 |  |  |  |  |  | 0d | finish no earlier than 2004-04-30 | GP | 2568h |  | SCSAGB-Stage2 | David Bladsjö, Ericsson | TSG |  |  |  |
| 909 | 117.3 | Radio Channel Support | 321d? | 2003-02-07 | 2004-04-30 |  |  |  |  |  | 0d | finish no earlier than 2004-04-30 | GP | 2568h |  | SCSAGB-RCS | David Bladsjö, Ericsson | TSG |  |  |  |
| 910 | 117.4 | Definition of radio resource management functionality | 160.5d? | 2003-02-07 | 2003-09-19 |  |  |  |  |  | 160.5d | finish no earlier than 2003-09-19 | GP; G2 | 2568h |  | SCSAGB-RRM | David Bladsjö, Ericsson | TSG |  |  |  |
| 911 | 117.5 | PS Handover | 321d? | 2003-02-07 | 2004-04-30 |  |  |  |  |  | 0d | finish no earlier than 2004-04-30 | GP | 2568h |  | SCSAGB-PSH | David Bladsjö, Ericsson | TSG |  |  |  |
| 912 | 117.6 | Modifications to FLO | 160.5d? | 2003-02-07 | 2003-09-19 |  |  |  |  |  | 160.5d | finish no earlier than 2003-09-19 | GP; G2 | 2568h |  | SCSAGB-FLO | David Bladsjö, Ericsson | TSG |  |  |  |

Notes:
- 900: TERMINATED - NOT STANDARDIZED
- 901: TERMINATED - NOT STANDARDIZED
- 902: TERMINATED - NOT STANDARDIZED
- 903: TERMINATED - NOT STANDARDIZED
- 904: Needed to complete DTM (R99)
- 905: Ongoing
- 907: Started
- 908: Not Started
- 909: Not Started
- 910: Not Started
- 911: Not Started
- 912: Not Started
